# 3GPP_Release-2000

Schedule from MS Project, 1984-10-18 to 2019-12-13, A marks actual dates.

| ID | WBS | Task | Type | Duration | Start | Finish | Complete | Remaining | Baseline start | Baseline finish | Baseline duration | Total slack | Constraint | Resources | Work | Actual work | Acronym | WI rapporteur name | WI rapporteur e-mail | Release | MCC resp | Acronym_3GU_Export | TSG stopped |
| --- | --- | --- | --- | --- | --- | --- | --- | --- | --- | --- | --- | --- | --- | --- | --- | --- | --- | --- | --- | --- | --- | --- | --- |
| 4758 | 1280 | **Downlink Dual Carrier** |  | 947d? | 2006-01-20 A | 2009-09-04 A | 100% |  | 2006-01-20 | 2009-09-04 | 947d? |  |  | GP | 15446.6h | 15446.6h | GDCDL | Nokia Siemens Networks | leonardo.provvedi@roke.co.uk | Rel-7 | Paolo | GDCDL |  |
| 4759 | 1280.1 | Downlink Dual Carrier Stage 2 |  | 116d? | 2006-01-20 A | 2006-06-30 A | 100% |  | 2006-01-20 | 2006-06-30 | 116d? |  | finish no earlier than 2006-06-30 | G1 | 928h | 928h | GDCDL-Stage2 | Nokia Siemens Networks | leonardo.provvedi@roke.co.uk | Rel-7 | Paolo | GDCDL-Stage2 |  |
| 4760 | 1280.2 | Downlink Dual Carrier Stage 3 |  | 421d? | 2006-01-20 A | 2007-08-31 A | 100% |  | 2006-01-20 | 2007-08-31 | 421d? |  | finish no earlier than 2007-08-31 | G1 | 3368h | 3368h | GDCDL-Stage3 | Nokia Siemens Networks | leonardo.provvedi@roke.co.uk | Rel-7 | Paolo | GDCDL-Stage3 |  |
| 4761 | 1280.3 | Downlink Dual Carrier – MS Conformance Test |  | 446.82d? | 2006-01-20 A | 2009-09-04 A | 100% |  | 2006-01-20 | 2009-09-04 | 446.82d? |  | finish no earlier than 2009-09-04 | G3new | 3574.6h | 3574.6h | GDCDL-MStest | Nokia Siemens Networks | leonardo.provvedi@roke.co.uk | Rel-7 | Ingbert | GDCDL-MStest |  |
| 4762 | 1281 | Support of SIGTRAN in GERAN |  | 116d? | 2006-01-20 A | 2006-06-30 A | 100% |  | 2006-01-20 | 2006-06-30 | 116d? |  | finish no earlier than 2006-06-30 | GP | 928h | 928h | GSIGT | Ericsson | peter.ostrup@ericsson.com | Rel-7 | Ingbert | GSIGT |  |
| 4763 | 1282 | **Latency Reductions** |  | 306d? | 2006-06-30 A | 2007-08-31 A | 100% |  | 2006-06-30 | 2007-08-31 | 306d? |  |  | GP | 7344h | 7344h | LATRED | Ericsson | Hakan.Persson@Ericsson.com | Rel-7 | Paolo | LATRED |  |
| 4764 | 1282.1 | Improved Ack/Nack reporting |  | 306d? | 2006-06-30 A | 2007-08-31 A | 100% |  | 2006-06-30 | 2007-08-31 | 306d? |  | finish no earlier than 2007-08-31 | G2 | 2448h | 2448h | LATRED-ACKNAR | Ericsson | Hakan.Persson@Ericsson.com | Rel-7 | Gert | LATRED-ACKNAR |  |
| 4765 | 1282.2 | Reduced TTI |  | 306d? | 2006-06-30 A | 2007-08-31 A | 100% |  | 2006-06-30 | 2007-08-31 | 306d? |  | finish no earlier than 2007-08-31 | G2 | 2448h | 2448h | LATRED-REDTTI | Ericsson | Hakan.Persson@Ericsson.com | Rel-7 | Gert | LATRED-REDTTI |  |
| 4766 | 1283 | PS Handover between GERAN/UTRAN mode and GAN Mode |  | 166d? | 2006-06-30 A | 2007-02-16 A | 100% |  | 2006-06-30 | 2007-02-16 | 166d? |  | finish no earlier than 2007-02-16 | G2 | 1328h | 1328h | GUGAN | Ericsson | John.Diachina@Ericsson.com | Rel-7 | Gert | GUGAN |  |
| 4767 | 1284 | **Higher Uplink performance for GERAN Evolution** |  | 1227d? | 2006-09-08 A | 2011-05-20 A | 100% |  | 2006-09-08 | 2011-05-20 | 1227d? |  |  | GP | 37184h | 37184h | HUGE | Nokia Siemens Networks, Ericsson | eddie.riddington@nokia.com, stefan.g.eriksson@ericsson.com | Rel-7 | Paolo | HUGE |  |
| 4768 | 1284.1 | Stage 2 for HUGE |  | 261d? | 2006-09-08 A | 2007-09-07 A | 100% |  | 2006-09-08 | 2007-09-07 | 261d? |  | finish no earlier than 2007-09-07 | G1 | 2088h | 2088h | HUGE-Stage2 | Nokia Siemens Networks, Ericsson | eddie.riddington@nokia.com, stefan.g.eriksson@ericsson.com | Rel-7 | Paolo | HUGE-Stage2 |  |
| 4769 | 1284.2 | Layer 1 Support for HUGE |  | 381d? | 2006-09-08 A | 2008-02-22 A | 100% |  | 2006-09-08 | 2008-02-22 | 381d? |  | finish no earlier than 2008-02-22 | G1 | 3048h | 3048h | HUGE-Layer1 | Nokia Siemens Networks, Ericsson | eddie.riddington@nokia.com, stefan.g.eriksson@ericsson.com | Rel-7 | Paolo | HUGE-Layer1 |  |
| 4770 | 1284.3 | Layer 2/3 Support for HUGE |  | 256d? | 2006-09-08 A | 2007-08-31 A | 100% |  | 2006-09-08 | 2007-08-31 | 256d? |  | finish no earlier than 2007-08-31 | G2 | 2048h | 2048h | HUGE-Layer23 | Nokia Siemens Networks, Ericsson | eddie.riddington@nokia.com, stefan.g.eriksson@ericsson.com | Rel-7 | Gert | HUGE-Layer23 |  |
| 4771 | 1284.4 | Performance requirements for HUGE |  | 516d? | 2006-09-08 A | 2008-08-29 A | 100% |  | 2006-09-08 | 2008-08-29 | 516d? |  | finish no earlier than 2008-08-29 | G1 | 4128h | 4128h | HUGE-Perfreq | Nokia Siemens Networks, Ericsson | eddie.riddington@nokia.com, stefan.g.eriksson@ericsson.com | Rel-7 | Paolo | HUGE-Perfreq |  |
| 4772 | 1284.5 | BTS Conformance Test for HUGE |  | 782d? | 2006-09-08 A | 2009-09-04 A | 100% |  | 2006-09-08 | 2009-09-04 | 782d? |  | finish no earlier than 2009-09-04 | G1 | 6248h | 6248h | HUGE-BTStest | Nokia Siemens Networks, Ericsson | eddie.riddington@nokia.com, stefan.g.eriksson@ericsson.com | Rel-7 | Paolo | HUGE-BTStest |  |
| 4773 | 1284.6 | MS Conformance Test for HUGE |  | 1226d? | 2006-09-08 A | 2011-05-20 A | 100% |  | 2006-09-08 | 2011-05-20 | 1226d? |  | finish no earlier than 2011-05-20 | G3new | 9808h | 9808h | HUGE-Mstest | Nokia Siemens Networks, Ericsson | eddie.riddington@nokia.com, stefan.g.eriksson@ericsson.com | Rel-7 | Ingbert | HUGE-Mstest |  |
| 4774 | 1285 | **REduced symbol Duration, Higher Order modulation and Turbo coding (RED HOT) for downlink** |  | 1177d? | 2006-11-17 A | 2011-05-20 A | 100% |  | 2006-11-17 | 2011-05-20 | 1177d? |  |  | GP | 28808h | 28808h | REDHOT | Ericsson, Nokia Siemens Networks, Marvell | stefan.g.eriksson@ericsson.com | Rel-7 | Paolo | REDHOT |  |
| 4775 | 1285.1 | Stage 2 for REDHOT |  | 206d? | 2006-11-17 A | 2007-08-31 A | 100% |  | 2006-11-17 | 2007-08-31 | 206d? |  | finish no earlier than 2007-08-31 | G1 | 1648h | 1648h | REDHOT-Stage2 | Ericsson, Nokia Siemens Networks, Marvell | stefan.g.eriksson@ericsson.com | Rel-7 | Paolo | REDHOT-Stage2 |  |
| 4776 | 1285.2 | Stage 3 for REDHOT |  | 391d? | 2006-11-17 A | 2008-05-16 A | 100% |  | 2006-11-17 | 2008-05-16 | 391d? |  | finish no earlier than 2008-05-16 | G1 | 3128h | 3128h | REDHOT-Stage3 | Ericsson, Nokia Siemens Networks, Marvell | stefan.g.eriksson@ericsson.com | Rel-7 | Paolo | REDHOT-Stage3 |  |
| 4777 | 1285.3 | BTS Conformance Tests for REDHOT |  | 651d? | 2006-11-17 A | 2009-05-15 A | 100% |  | 2006-11-17 | 2009-05-15 | 651d? |  | finish no earlier than 2009-05-15 | G1 | 5208h | 5208h | REDHOT-BTStest | Ericsson, Nokia Siemens Networks, Marvell | stefan.g.eriksson@ericsson.com | Rel-7 | Paolo | REDHOT-BTStest |  |
| 4778 | 1285.4 | MS Conformance Tests for REDHOT |  | 1176d? | 2006-11-17 A | 2011-05-20 A | 100% |  | 2006-11-17 | 2011-05-20 | 1176d? |  | finish no earlier than 2011-05-20 | G3new | 9408h | 9408h | REDHOT-Mstest | Ericsson, Nokia Siemens Networks, Marvell | stefan.g.eriksson@ericsson.com | Rel-7 | Ingbert | REDHOT-Mstest |  |
| 4779 | 1286 | (Small) Technical Enhancements and Improvements for Rel-7 | milestone | 0d? | 2007-03-26 A | 2007-03-26 A | 100% |  | 2007-03-26 | 2007-03-26 | 0d? |  | start no earlier than 2007-03-26 | SP; CP; RP; GP |  |  | TEI7 |  |  | Rel-7 | All | TEI7 |  |
| 4780 | 1287 | Test - (Small) Technical Enhancements and Improvements for Rel-7 |  | 389d? | 2006-06-02 A | 2007-11-28 A | 100% |  | 2006-06-02 | 2007-11-28 | 389d? |  | finish no earlier than 2010-06-04 | R5 | 3112h | 3112h | TEI7_Test |  |  | Rel-7 | Ingbert | TEI7_Test |  |
| 4781 | 1288 | **Deleted - PS domain and IMS support for IMS Emergency sessions** |  | 63.69d? | 2006-06-23 A | 2006-09-21 | 99% | 0d? | 2006-06-23 | 2006-09-21 | 63.69d? | 0d |  | S2 |  |  | IMS-EMER | Nokia | curt.c.wong@nokia.com | Rel-7 | Maurice | IMS-EMER | SP-30 |
| 4782 | 1288.1 | Deleted - IMS aspects to support IMS Emergency sessions | milestone | 0d? | 2006-06-23 A | 2006-09-21 A | 100% |  | 2006-06-23 | 2006-09-21 | 0d? |  | start no earlier than 2006-06-23 | S2 |  |  |  | Nokia | curt.c.wong@nokia.com | Rel-7 | Maurice |  | SP-30 |
| 4783 | 1288.2 | Deleted - PS domain aspects to support IMS Emergency sessions | milestone | 0d? | 2006-06-23 A | 2006-09-21 A | 100% |  | 2006-06-23 | 2006-09-21 | 0d? |  | start no earlier than 2006-06-23 | S2 |  |  |  | Nokia | curt.c.wong@nokia.com | Rel-7 | Maurice |  | SP-30 |

Notes:
- 4758: GP#35 completed
- 4759: GP#30 completed / Impacted TSs and TRs: 43.055, 43.064
- 4760: GP#35 completed / Impacted TSs and TRs: 24.008, 44.018, 44.060, 45.001, 45.002, 45.005, 45.008
- 4761: GP#43 completed / Impacted TSs and TRs: 51.010
- 4762: GP#30 completed / Impacted TSs and TRs: 48.001, 48.006, 43.059, 49.031
- 4763: GP#35 completed / Impacted TSs and TRs: 45.001, 45.002, 45.003, 45.005, 45.010, 43.055, 43.064, 44.060, 51.010-1, 51.021
- 4764: GP#35 completed / Impacted TSs and TRs: 45.001, 45.002, 45.003, 45.005, 45.010, 43.055, 43.064, 44.060, 51.010-1, 51.021
- 4765: GP#35 completed / Impacted TSs and TRs: 45.001, 45.002, 45.003, 45.005, 45.010, 43.055, 43.064, 44.060, 51.010-1, 51.021
- 4766: GP#33 completed / Impacted TSs and TRs: 43.318, 44.318, 43.129, 25.306, 24.008, 44.060, 25.331, 51.010
- 4767: GP#39 completed
- 4768: GP#35 completed / Impacted TSs and TRs: 43.055, 43.064
- 4769: GP#37 completed / Impacted TSs and TRs: 45.001, 45.002, 45.003, 45.004, 45.008
- 4770: GP#35 completed / Impacted TSs and TRs: 24.008, 44.018, 44.060
- 4771: GP#39 completed / Impacted TSs and TRs: 45.005
- 4772: GP#43 completed / Impacted TSs and TRs: 51.021
- 4773: GP#50 completed / Impacted TSs and TRs: 51.010
- 4774: GP#38 completed
- 4775: GP#35 completed / Impacted TSs and TRs: 43.055, 43.064
- 4776: GP#38 completed / Impacted TSs and TRs: 24.008, 44.018, 44.060, 45.001, 45.002, 45.003, 45.004, 45.005, 45.008
- 4777: GP#42 completed / Impacted TSs and TRs: 51.021
- 4778: GP#50 completed / Impacted TSs and TRs: 51.010
- 4779: -
- 4780: -
- 4781: Approved at SP#29 / Impacted TSs and TRs: 23.867, 23.abc, 23.060, 23.002, 23.271
- 4782: Approved at SP#29 / Impacted TSs and TRs: 23.867, 23.abc, 23.060, 23.002, 23.271
- 4783: Approved at SP#29 / Impacted TSs and TRs: 23.867, 23.abc, 23.060, 23.002, 23.271

| ID | WBS | Task | Type | Duration | Start | Finish | Complete | Remaining | Baseline start | Baseline finish | Baseline duration | Total slack | Constraint | Resources | Work | Actual work | Acronym | Impacted TSs and TRs | Release | MCC resp | TSG stopped | Acronym_3GU_Export | WI rapporteur name | WI rapporteur e-mail | PCG approved | TSG approved | Special Focus Doc |
| --- | --- | --- | --- | --- | --- | --- | --- | --- | --- | --- | --- | --- | --- | --- | --- | --- | --- | --- | --- | --- | --- | --- | --- | --- | --- | --- | --- |
| 4784 | 16.7 | **Deleted - IMS Local services** |  | 0d? | 2006-01-06 A | 2006-01-06 | 99% | 0d? | 2006-01-06 | 2006-01-06 | 0d? | 0d |  | S2 |  |  | IMSLocal | 23.228 | Rel-7 | Maurice | SP-28 | IMSLocal |  |  |  |  |  |
| 4785 | 16.7.1 | Deleted - Stage 2 | milestone | 0d | 2006-01-06 A | 2006-01-06 A | 100% |  | 2006-01-06 | 2006-01-06 | 0d |  | start no earlier than 2006-01-06 | S2 |  |  |  |  | Rel-7 | Maurice | SP-26 |  |  |  |  |  |  |
| 4786 | 1289.2 | Deleted - Stage 3 for IMS Local services | milestone | 0d? | 2006-01-06 A | 2006-01-06 A | 100% |  | 2006-01-06 | 2006-01-06 | 0d? |  | finish no earlier than 2006-01-06 | C1 |  |  |  |  | Rel-7 | Frederic | SP-25 |  | Lucent | Keith Drage (drage@alcatel-lucent.com) |  |  |  |
| 4787 | 1290 | Deleted - IMS Phase 3 | milestone | 0d? | 2006-01-06 A | 2006-01-06 A | 100% |  | 2006-01-06 | 2006-01-06 | 0d? |  | start no earlier than 2006-01-06 | S2 |  |  |  |  | Rel-7 | Maurice | SP-25 |  |  |  |  |  |  |
| 4788 | 1291 | Deleted - Improvements of Radio Interface | milestone | 0d? | 2004-09-15 A | 2004-09-15 A | 100% |  | 2004-09-15 | 2004-09-15 | 0d? |  | start no earlier than 2004-09-15 | RP |  |  |  |  | Rel-7 | Issam | SP-24 |  |  |  | 36 | 70 |  |
| 4789 | 1292 | Deleted: Generic User Profile Phase 2 | milestone | 0d | 2005-08-08 A | 2006-06-30 A | 100% |  | 2005-08-08 | 2006-06-30 | 0d |  |  | C4 |  |  |  |  | Rel-7 | Kimmo | SP-27 |  |  |  |  |  |  |
| 4790 | 30.4 | Deleted - Stage 3 - Common objects | milestone | 0d | 2005-08-08 A | 2006-06-30 A | 100% |  | 2005-08-08 | 2006-06-30 | 0d |  | finish no earlier than 2006-06-30 | C4 |  |  |  | 24.241 | Rel-7 | Kimmo | SP-27 |  |  |  |  |  |  |
| 4791 | 1294 | Release 7 Studies |  | 841d? | 2004-06-28 A | 2007-09-17 A | 100% |  | 2004-06-28 | 2007-09-17 | 841d? |  |  | CP; GP; RP; SP | 26912h | 26912h |  |  | Rel-7 | All |  |  |  |  |  |  |  |
| 4792 | 1295 | Study on Multimedia Telephony Capabilities for IMS |  | 276d? | 2005-07-11 A | 2006-07-31 A | 100% |  | 2005-07-11 | 2006-07-31 | 276d? |  |  | S1 | 2145.6h | 2145.6h | MITE | 22.973 | Rel-7 | Alain |  | MITE | Ericsson | peter.bleckert@ericsson.com |  |  |  |
| 4793 | 1296 | Study on Behaviour of Multi system UEs |  | 384d? | 2004-06-28 A | 2005-12-15 A | 100% |  | 2004-06-28 | 2005-12-15 | 384d? |  | start no earlier than 2004-06-28 | S1 | 3072h | 3072h | BMSU | 22.936 | Rel-7 | Alain |  | BMSU | Qualcomm | dwilliams@qualcomm.com |  |  |  |
| 4794 | 1297 | Study on Combining CS calls and IMS sessions |  | 189d? | 2004-06-28 A | 2005-03-17 A | 100% |  | 2004-06-28 | 2005-03-17 | 189d? |  | start no earlier than 2004-06-28 | S1 | 1512h | 1512h | IRTSD-CS_IMS | 22.979 | Rel-7 | Alain |  | IRTSD-CS_IMS | TeliaSonera | robert.frank@teliasonera.com |  |  |  |
| 4795 | 1298 | Study on All-IP Network |  | 188d? | 2004-06-28 A | 2005-03-16 A | 100% |  | 2004-06-28 | 2005-03-16 | 188d? |  | start no earlier than 2004-06-28 | S1 | 1504h | 1504h | FS_AIPN | 22.978 | Rel-7 | Alain |  | FS_AIPN | NTT DoCoMo | Shin-ichi Isobe (isobes@nttdocomo.co.jp) |  |  |  |
| 4796 | 1299 | Study on Videotelephony teleservice |  | 231d? | 2005-03-01 A | 2006-01-17 A | 100% |  | 2005-03-01 | 2006-01-17 | 231d? |  |  | S1 | 1848h | 1848h | VidTel | 22.903 | Rel-7 | Alain |  | VidTel | T-Mobile | michael.kurz@t-mobile.at |  |  |  |
| 4797 | 1300 | Study on Network Selection Principles |  | 193d? | 2005-03-15 A | 2005-12-08 A | 100% |  | 2005-03-15 | 2005-12-08 | 193d? |  |  | S1 | 1544h | 1544h | NetSel | 22.811 | Rel-7 | Alain |  | NetSel | O2 | chris.friel@O2.com |  |  |  |
| 4798 | 1301 | Study on Multimedia Priority Service |  | 851d? | 2003-03-28 A | 2006-06-30 A | 100% |  | 2003-03-28 | 2006-06-30 | 851d? |  | finish no earlier than 2005-12-16 | S1 | 6808h | 6808h | PRIOR-MM | 22.953 | Rel-7 | Alain |  | PRIOR-MM | Telcordia | James Garrahan (jgarraha@telcordia.com) |  |  | Public Safety (I-A) |
| 4799 | 1302 | Study on Transferring of emergency Call data |  | 190d? | 2005-07-11 A | 2006-03-31 A | 100% |  | 2005-07-11 | 2006-03-31 | 190d? |  | finish no earlier than 2005-12-08 | S1 | 1520h | 1520h | eCALL | 22.967 | Rel-7 | Alain |  | eCALL | Motorola | jian.j.wu@motorola.com |  |  | Public Safety (I-A) |
| 4800 | 1303 | Study on Enhancement of E2E QoS |  | 281.4d? | 2004-06-28 A | 2005-09-15 A | 100% |  | 2004-06-28 | 2005-09-15 | 281.4d? |  | finish no earlier than 2005-12-01 | S2 | 2251.2h | 2251.2h | QoS7 | 23.802 | Rel-7 | Maurice |  | QoS7 | Huawei | Robert Jaksa |  |  |  |
| 4801 | 1304 | Study on SOAP/HTTP IRP Solution Sets |  | 330d? | 2005-09-02 A | 2006-12-07 A | 100% |  | 2005-09-02 | 2006-12-07 | 330d? |  | finish no earlier than 2006-12-07 | S5 | 2640h | 2640h | OAM7-NIM-XML | 32.809 | Rel-7 | Mirko |  | OAM7-NIM-XML | Nortel | Suzèle Lariven (lariven@nortel.com) |  |  |  |
| 4802 | 1305 | Study on Itf-N Implementation Conformance Statement (ICS) template |  | 400d? | 2005-09-02 A | 2007-03-15 A | 100% |  | 2005-09-02 | 2007-03-15 | 400d? |  | finish no earlier than 2007-03-15 | S5 | 3200h | 3200h | OAM7-NIM-ICS | 32.812 | Rel-7 | Mirko |  | OAM7-NIM-ICS | China Mobile | Li Yewen (liyewen@chinamobile.com) |  |  |  |
| 4803 | 1306 | Study on IRP Information Model |  | 400d? | 2005-09-02 A | 2007-03-15 A | 100% |  | 2005-09-02 | 2007-03-15 | 400d? |  | finish no earlier than 2007-03-15 | S5 | 3200h | 3200h | OAM7-NIM-IM | 32.810 | Rel-7 | Mirko |  | OAM7-NIM-IM | Motorola | trevor.pirt@motorola.com |  |  |  |
| 4804 | 1307 | Study on Bandwidth Saving at Nb Interface with IP transport |  | 261d? | 2006-03-10 A | 2007-03-09 A | 100% |  | 2006-03-10 | 2007-03-09 | 261d? |  | finish no earlier than 2007-03-09 | C3 | 2088h | 2088h | BSNbIP | 29.814 | Rel-7 | Adrian |  | BSNbIP | Siemens | Thomas.Belling@siemens.com |  |  |  |
| 4805 | 1308 | Study on Routeing of MT-SMS via the HPLMN |  | 301d? | 2005-10-07 A | 2006-12-01 A | 100% |  | 2005-10-07 | 2006-12-01 | 301d? |  | finish no earlier than 2006-12-01 | C4 | 2408h | 2408h | SMS7 | 23.840 | Rel-7 | Kimmo |  | SMS7 | Vodafone | Nick.Russell@vodafone.com |  |  |  |
| 4806 | 1309 | Feasibility Study on the TCAPsec Gateway concept |  | 96d? | 2005-10-28 A | 2006-03-10 A | 100% |  | 2005-10-28 | 2006-03-10 | 96d? |  | finish no earlier than 2006-03-10 | C4 | 768h | 768h | FS_SEC7-TCAP | 29.800 | Rel-7 | Kimmo |  | FS_SEC7-TCAP | Siemens | Ulrich.wiehe@gksag.de |  |  |  |
| 4807 | 1310 | Study on using M2PA in 3GPP network |  | 318d? | 2006-03-22 A | 2007-06-08 A | 100% |  | 2006-03-22 | 2007-06-08 | 318d? |  | finish no earlier than 2007-06-08 | C4 | 2544h | 2544h | FS-M2PA | 29.801 | Rel-7 | Kimmo |  | FS-M2PA | China Mobile | zhaoyuyi@chinamobile.com |  |  |  |

Notes:
- 4784: -
- 4785: DAB - Not yet required in SA2 as it exists in previous releases
- 4786: -
- 4787: -
- 4788: Stage 2 description of Interim conclusion
- 4789: Created at TSG#27 by A. Sultan because of the move to Rel-7 of "Common Objects".
- 4790: No progress in CN4#26. This have to be moved to Rel-7. It was deleted from WID
- 4791: -
- 4792: Spin-off Feature UID_7038 (MTSI)
- 4793: -
- 4794: -
- 4795: 07/08 Moved to Rel-7 as Study out of stopped Rel-8 Feature UID_31067 All-IP Network (AIPN)
- 4796: -
- 4797: Spin-off Feature Network selection enhancements (NSP-CR) UID_7041
- 4798: Spin-off Feature PRIOR UID_340044
- 4799: -
- 4800: -
- 4801: SP#34 completed
- 4802: SP#35 completed
- 4803: SP#35 completed
- 4804: Moved to FS at CT32 (in line with slides)
- 4805: Previously known as "Study of a SMS Centre for MT SMS"
- 4806: TR 29.800 content moved to TS 29.204 under implementation WI UID_310005 TCAPsec Gateway
- 4807: -

| ID | WBS | Task | Type | Duration | Start | Finish | Complete | Baseline start | Baseline finish | Baseline duration | Constraint | Resources | Work | Actual work | Acronym | Impacted TSs and TRs | WI rapporteur name | WI rapporteur e-mail | Release | MCC resp | Acronym_3GU_Export | Status Report | TSG stopped | Special Focus Doc |
| --- | --- | --- | --- | --- | --- | --- | --- | --- | --- | --- | --- | --- | --- | --- | --- | --- | --- | --- | --- | --- | --- | --- | --- | --- |
| 4808 | 1311 | **Study on Support of (G)MSC-S - (G)MSC-S Nc Interface based on the SIP-I protocol** |  | 350d? | 2006-05-15 A | 2007-09-14 A | 100% | 2006-05-15 | 2007-09-14 | 350d? |  | C4; C3 | 10600h | 10600h | NcSIP | 29.802 | Vodafone | david.hutton@vodafone.com | Rel-7 | Kimmo | NcSIP |  |  |  |
| 4809 | 1311.1 | CT4 aspects of NcSIP |  | 275d? | 2006-05-15 A | 2007-06-01 A | 100% | 2006-05-15 | 2007-06-01 | 275d? | finish no earlier than 2007-06-01 | C4 | 2200h | 2200h |  | 29.802 | Vodafone | david.hutton@vodafone.com | Rel-7 | Kimmo |  |  |  |  |
| 4810 | 1311.2 | CT3 aspects of NcSIP |  | 350d? | 2006-05-15 A | 2007-09-14 A | 100% | 2006-05-15 | 2007-09-14 | 350d? | finish no earlier than 2007-09-14 | C3 | 2800h | 2800h |  | 29.802 | Ericsson | ragnar.huslende@ericsson.com | Rel-7 | Adrian |  |  |  |  |
| 4811 | 1312 | Study on Evolved UTRA and UTRAN |  | 458d? | 2004-12-15 A | 2006-09-15 A | 100% | 2004-12-15 | 2006-09-15 | 458d? | finish no earlier than 2006-09-15 | RP | 3664h | 3664h | RANFS-Evo | 25.912 | NTT DoCoMo | nakamurata@NTTDOCOMO.CO.JP | Rel-7 | Issam | RANFS-Evo | RP-060472 |  |  |
| 4812 | 1313 | Study on Performance Evaluation of the UE behaviour in high speed trains with speeds up to 350 kmph |  | 328d? | 2005-03-15 A | 2006-06-15 A | 100% | 2005-03-15 | 2006-06-15 | 328d? | finish no earlier than 2006-06-15 | R4 | 2624h | 2624h | RANFS-HSTrains | none | Vodafone | Mike.vogel@vodafone.com,tim.frost@vodafone.com | Rel-7 | Issam | RANFS-HSTrains | RP-060412 |  |  |
| 4813 | 1314 | Study on UTRA Tower Mounted Amplifier (FDD) |  | 195d? | 2005-06-15 A | 2006-03-14 A | 100% | 2005-06-15 | 2006-03-14 | 195d? | finish no earlier than 2006-03-15 | R4 | 1560h | 1560h | RANFS-TMA | 25.818 | Ericsson | Klas.Sjerling@ericsson.com | Rel-7 | Issam | RANFS-TMA | RP-060035 |  |  |
| 4814 | 1315 | Study on Continuous connectivity for packet data users |  | 132d? | 2005-03-15 A | 2005-09-14 A | 100% | 2005-03-15 | 2005-09-14 | 132d? | finish no earlier than 2005-09-15 | R1 | 1056h | 1056h | RANFS-cont-packet | none | Siemens | joerg.gustrau@siemens.com | Rel-7 | Patrick | RANFS-cont-packet | RP-050427 |  |  |
| 4815 | 1316 | Study on Improvement of the Multimedia Broadcast Multicast Service (MBMS) in UTRAN |  | 262d? | 2005-12-15 A | 2006-12-15 A | 100% | 2005-12-15 | 2006-12-15 | 262d? | finish no earlier than 2006-12-15 | R2 | 2096h | 2096h | RANFS-MBMSImp | 25.905 | LG Electronics | leego@lge.com | Rel-7 | Yong-Jun | RANFS-MBMSImp | RP-060692 |  |  |
| 4816 | 1317 | Deleted - Study on Performance Improvements in Small Cells using HSDPA/EDCH |  | 131d? | 2005-12-15 A | 2006-06-15 A | 100% | 2005-12-15 | 2006-06-15 | 131d? | finish no earlier than 2006-06-15 | R1; R4 | 2096h | 2096h | SMALLCELLS | none | Cingular | Marc Grant | Rel-7 | Issam | SMALLCELLS | RP-060263 | SP-69 | Small cell |
| 4817 | 1318 | Study on Further Improved Performance Requirements for UMTS/HSDPA UE (FDD) |  | 383d? | 2005-12-15 A | 2007-06-04 A | 100% | 2005-12-15 | 2007-06-04 | 383d? | finish no earlier than 2007-06-04 | R4 | 3064h | 3064h | RANFS-IC | 25.963 | Cingular | Marc Grant | Rel-7 | Issam | RANFS-IC | RP-070499 |  |  |
| 4818 | 1319 | Study on Scope of future FDD HSPA Evolution |  | 394d? | 2006-03-15 A | 2007-09-17 A | 100% | 2006-03-15 | 2007-09-17 | 394d? | finish no earlier than 2007-09-17 | RP | 3152h | 3152h | RANFS-HSPAEvo | 25.999 | Cingular | Don Zelmer (dz1069@att.com) | Rel-7 | Issam | RANFS-HSPAEvo | RP-070533 |  |  |
| 4819 | 1320 | Study on Dynamically reconfiguring a FDD UE receiver to reduce power consumption when desired Quality of Service is met | milestone | 0d? | 2007-06-22 A | 2007-06-22 A | 100% | 2007-06-22 | 2007-06-22 | 0d? |  | R4 |  |  | FSUEPow | 25.906 | Nokia | Chris.callender@nokia.com, tiina.s.koskinen@nokia.com | Rel-7 | Issam | FSUEPow | RP-070534 |  |  |
| 4820 | 1321 | Study on Future GERAN Evolution |  | 486d? | 2005-04-08 A | 2007-02-16 A | 100% | 2005-04-08 | 2007-02-16 | 486d? | finish no earlier than 2007-02-16 | GP | 3888h | 3888h | FGE | 45.912 | Nokia | eddie.riddington@nokia.com | Rel-7 | Paolo | FGE |  |  |  |
| 4821 | 1322 | Study on GAN Enhancements | milestone | 0d? | 2007-08-31 A | 2007-08-31 A | 100% | 2007-08-31 | 2007-08-31 | 0d? | start no earlier than 2007-08-31 | GP |  |  | EGAN | 43.902 | T-Mobile | janne.linkola@t-mobile.com | Rel-7 | Paolo | EGAN |  |  |  |
| 4822 | 1323 | Deleted - Study on IMS with real time services deployment |  | 316d? | 2004-06-28 A | 2005-09-12 A | 100% | 2004-06-28 | 2005-09-12 | 316d? |  | S1 | 2528h | 2528h | IRTSD |  |  |  | Rel-7 | Alain | IRTSD |  | SP-30 |  |
| 4823 | 1324 | Deleted - Covered by SI - Personal Network (PN) and Personal Area Network (PAN) | milestone | 0d? | 2005-12-08 A | 2005-12-20 A | 100% | 2005-12-08 | 2005-12-20 | 0d? | start no earlier than 2005-12-08 | S1 |  |  | PNPAN |  | Vodafone | armin.toepfer@vodafone.com | Rel-7 | Alain | PNPAN |  | SP-30 |  |
| 4824 | 1325 | Deleted - Study on Customised Alerting Tone (CAT) Requirements (was duplicated) | milestone | 0d? | 2006-06-30 A | 2006-06-30 A | 100% | 2006-06-30 | 2006-06-30 | 0d? | start no earlier than 2006-06-30 | S1 |  |  |  |  |  |  | Rel-7 | Alain |  |  | SP-31 |  |
| 4825 | 1326 | Deleted - IMS security extensions (covered by UID33027) | milestone | 0d? | 2005-12-08 A | 2005-12-08 A | 100% | 2005-12-08 | 2005-12-08 | 0d? | start no earlier than 2005-12-08 | S3 |  |  | IMS-SE |  | Ericsson | Bengt.Sahlin@ericsson.com | Rel-7 | Mirko | IMS-SE |  | SP-30 |  |
| 4826 | 1327 | **Deleted - Study on applicability of GALILEO for LCS** |  | 0d? | 2005-06-30 A | 2005-06-30 A | 100% | 2005-06-30 | 2005-06-30 | 0d? |  | S2 |  |  | Galileo |  |  |  | Rel-7 | Maurice | Galileo |  | SP-25 |  |
| 4827 | 1327.1 | Deleted - TR on Stage 2 | milestone | 0d? | 2005-06-30 A | 2005-06-30 A | 100% | 2005-06-30 | 2005-06-30 | 0d? | finish no earlier than 2005-06-30 | S2 |  |  |  |  |  |  | Rel-7 | Maurice |  |  | SP-25 |  |
| 4828 | 1327.2 | Deleted - GERAN review of the TR | milestone | 0d? | 2005-06-30 A | 2005-06-30 A | 100% | 2005-06-30 | 2005-06-30 | 0d? | start no earlier than 2005-06-30 | GP |  |  |  |  |  |  | Rel-7 | Paolo |  |  | SP-26 |  |
| 4829 | 1328 | Deleted - Study on Stage 2 (IMS services using CS bearers) |  | 316d? | 2004-06-28 A | 2005-09-12 A | 100% | 2004-06-28 | 2005-09-12 | 316d? | finish no earlier than 2005-09-12 | S2 | 2528h | 2528h | IRTSD-IMSCS | 23.899 | Nortel | Mark Watson | Rel-7 | Maurice | IRTSD-IMSCS |  | SP-30 |  |
| 4830 | 1329 | **Deleted - VoIMS bearer related enhancements** |  | 0d? | 2006-07-21 A | 2006-07-21 A | 100% | 2006-07-21 | 2006-07-21 | 0d? |  | S2 |  |  | VoIMS |  |  |  | Rel-7 | Maurice | VoIMS |  | SP-32 |  |
| 4831 | 1329.1 | Deleted - Study on enhancement of radio performance for VoIMS | milestone | 0d? | 2006-07-21 A | 2006-07-21 A | 100% | 2006-07-21 | 2006-07-21 | 0d? | start no earlier than 2006-07-21 | S2 |  |  |  | 23.807 | Nortel | Laurence Lautier (lautierl@nortel.com) | Rel-7 | Maurice |  |  | SP-32 |  |
| 4832 | 1330 | Deleted - Study on IMS enhancements and optimizations for real time communication. |  | 430d? | 2005-10-10 A | 2007-06-01 A | 100% | 2005-10-10 | 2007-06-01 | 430d? | finish no earlier than 2007-06-01 | S2 | 3440h | 3440h | IMS-RT | 23.818 | Ericsson | stephen.terrill@ericsson.com | Rel-7 | Maurice | IMS-RT |  | SP-35 |  |
| 4833 | 1331 | Deleted - Study on Terminating Session handling |  | 255d? | 2006-01-09 A | 2006-12-29 A | 100% | 2006-01-09 | 2006-12-29 | 255d? | finish no earlier than 2006-12-29 | S2 | 2040h | 2040h | CSIterm | 23.819 | Samsung |  | Rel-7 | Maurice | CSIterm |  | SP-32 |  |
| 4834 | 1332 | Deleted eCALLIBMS - Study on Transferring of emergency call data – in-band modem solution (moved to Rel-8) | milestone | 0d? | 2007-06-22 A | 2007-06-22 A | 100% | 2007-06-22 | 2007-06-22 | 0d? | start no earlier than 2007-06-22 | S4 |  |  |  | 26.967 | Airbiquity | lhong@airbiquity.com | Rel-7 | Paolo |  |  | SP-38 | Public Safety (I-A) |
| 4835 | 1333 | Deleted - Study on IRP usage scenarios |  | 330d? | 2005-09-02 A | 2006-12-07 A | 100% | 2005-09-02 | 2006-12-07 | 330d? | finish no earlier than 2006-12-07 | S5 | 2640h | 2640h | OAM-Study | 32.8xy | Lucent |  | Rel-7 | Mirko | OAM-Study |  | SP-32 |  |
| 4836 | 1334 | Deleted - Study on Interference Cancellation for UTRA FDD UE (covered by UID 20053) |  | 1d? | 2007-03-28 A | 2007-03-28 A | 100% | 2007-03-28 | 2007-03-28 | 1d? | start no earlier than 2007-03-28 | R4 | 8h | 8h | RANFS-InterfCanc |  |  |  | Rel-7 | Issam | RANFS-InterfCanc |  | SP-38 |  |
| 4837 | 1335 | Deleted - Study on enhanced support of Video Telephony | milestone | 0d? | 2006-06-30 A | 2006-06-30 A | 100% | 2006-06-30 | 2006-06-30 | 0d? | start no earlier than 2006-06-30 | GP |  |  | VIDGER |  | Ericsson | stefan.g.eriksson@ericsson.com | Rel-7 | Paolo | VIDGER |  | SP-32 |  |
| 4838 | 1336 | Release 6 Features |  | 915d? | 2002-06-28 A | 2005-12-30 A | 100% | 2002-06-28 | 2005-12-30 | 915d? |  | NP; GP; RP; SP; TP | 36600h | 36600h |  |  |  |  | Rel-6 | All |  |  |  |  |

Notes:
- 4808: -
- 4809: -
- 4810: -
- 4811: RP#33 (Sep 2006) completed. SR in RP-060472
- 4812: RP#32 (Jun 2006) completed. SR in RP-060412
- 4813: RP#31 (Mar 2006) completed. SR in RP-060035
- 4814: RP#29 (Sep 2006) completed. SR in RP-050427
- 4815: RP#34 completed
- 4816: RP#32 (Jun 2006) stopped at 0% completion
- 4817: RP#36 (May 2007) completed. SR in RP-070499
- 4818: RP#37 (Sep 2007) completed. SR in RP-070533
- 4819: RP#37 (Sep 2007) completed. SR in RP-070534
- 4820: GP#33 completed
- 4821: GP#35 completed
- 4822: -
- 4823: -
- 4824: Awaiting MCC SA3 input
- 4825: -
- 4826: -
- 4827: -
- 4828: -
- 4829: SP-30: S2 has no intention for TR completion
- 4830: Created by MCC to group all VoIMS related items, after consultation of chairs
- 4831: WID approved SP#28. SA2#52 stopped
- 4832: abandoned at 65%
- 4833: SP#32 Jun 2006 Study abandoned => spin-off Implementation work UID_320029
- 4834: SP-38 stopped
- 4835: -
- 4836: Deleted. Same as FS on Further Improved Performance Requirements for UMTS/HSDPA UE (FDD)
- 4837: FS CLOSED at G#28 (no input)
- 4838: -

| ID | WBS | Task | Type | Duration | Start | Finish | Complete | Baseline start | Baseline finish | Baseline duration | Constraint | Resources | Work | Actual work | Release | Acronym | WI rapporteur name | WI rapporteur e-mail | MCC resp | Acronym_3GU_Export | Impacted TSs and TRs | Created at | TSG stopped |
| --- | --- | --- | --- | --- | --- | --- | --- | --- | --- | --- | --- | --- | --- | --- | --- | --- | --- | --- | --- | --- | --- | --- | --- |
| 4839 | 8 | **Rel-6 Improvements of Radio Interface** |  | 1645d? | 2000-08-14 A | 2006-12-01 A | 100% | 2000-08-14 | 2006-12-01 | 1645d? |  | R2; R4; R5 | 87632h | 87632h | Rel-6 |  |  |  |  |  |  |  |  |
| 4840 | 1337.1 | Improved support of IMS Realtime Services using HSDPA/EDCH |  | 197d? | 2005-03-15 A | 2005-12-14 A | 100% | 2005-03-15 | 2005-12-14 | 197d? | finish no earlier than 2005-12-14 | R2 | 1576h | 1576h | Rel-6 | RInImp-IMSRealTime | Cingular | Don Zelmer (dz1069@att.com) | Yong-Jun | RInImp-IMSRealTime |  |  |  |
| 4841 | 1337.2 | Improving Receiver Performance Requirements for the FDD UE |  | 401d | 2002-03-08 A | 2003-09-19 A | 100% | 2002-03-08 | 2003-09-19 | 401d | start no earlier than 2002-03-08 | R4 | 3208h | 3208h | Rel-6 | RInImp-UERecPerf | Intel | shimon.moshavi@INTEL.COM | Issam | RInImp-UERecPerf | 25.101 |  |  |
| 4842 | 8.2 | **Base station classification for FDD** |  | 603d | 2000-08-14 A | 2002-12-04 A | 100% | 2000-08-14 | 2002-12-04 | 603d |  | R4 | 9648h | 9648h | Rel-6 | RInImp-BSClass-FDD |  |  | Issam | RInImp-BSClass-FDD |  |  |  |
| 4843 | 8.2.1 | FDD Base station classification |  | 603d | 2000-08-14 A | 2002-12-04 A | 100% | 2000-08-14 | 2002-12-04 | 603d | finish no earlier than 2002-12-04 | R4 | 4824h | 4824h | Rel-6 |  | Nokia | antti.toskala@nokia.com | Issam |  | 25.104, 25.141 |  |  |
| 4844 | 1337.4 | UMTS-850 |  | 266d | 2002-12-06 A | 2003-12-12 A | 100% | 2002-12-06 | 2003-12-12 | 266d | finish no earlier than 2003-12-15 | R4 | 2128h | 2128h | Rel-6 | RInImp-UMTS850 | Cingular | Don Zelmer (dz1069@att.com) | Issam | RInImp-UMTS850 | 25.101, 25.104, 25.133, 25.141, 25.307, 25.331, 25.942 |  |  |
| 4845 | 1337.5 | DS-CDMA introduction in the 800 MHz band |  | 196d | 2003-03-14 A | 2003-12-12 A | 100% | 2003-03-14 | 2003-12-12 | 196d | finish no earlier than 2003-12-15 | R4 | 1568h | 1568h | Rel-6 | RInImp-UMTS800 | NTT DoCoMo | Takehiro Nakamura (nakamurata@nttdocomo.co.jp) | Issam | RInImp-UMTS800 | 25.101, 25.104, 25.133, 25.141, 25.307, 25.331 |  |  |
| 4846 | 1337.6 | UMTS 1.7/2.1 GHz | milestone | 0d? | 2003-03-14 A | 2003-03-14 A | 100% | 2003-03-14 | 2003-03-14 | 0d? |  | R4 |  |  | Rel-6 | RInImp-UMTS1721 | Nokia | jussi.numminen@NOKIA.COM | Issam | RInImp-UMTS1721 | 25.101, 25.104, 25.133, 25.141, 25.307, 25.331 |  |  |
| 4847 | 1337.7 | Conformance Test Aspects – UMTS 1.7/2.1 GHz Band |  | 191d? | 2006-03-10 A | 2006-12-01 A | 100% | 2006-03-10 | 2006-12-01 | 191d? | finish no earlier than 2006-12-01 | R5 | 1528h | 1528h | Rel-6 | RInImp-UMTS1721_Test | Motorola | carolyn.taylor@motorola.com | Ingbert | RInImp-UMTS1721_Test | TS34.121, TS34.108 |  |  |
| 4848 | 1337.8 | **Improved Receiver Performance Requirements for HSDPA** |  | 711d | 2003-09-19 A | 2006-06-09 A | 100% | 2003-09-19 | 2006-06-09 | 711d |  | R4; R5 | 28496h | 28496h | Rel-6 | RInImp-HSPerf | Nokia | jussi.numminen@NOKIA.COM | Issam | RInImp-HSPerf |  |  |  |
| 4849 | 1337.8.1 | Improved Minimum Performance Requirements for HSDPA UE categories 7 and 8 |  | 453d | 2004-09-15 A | 2006-06-09 A | 100% | 2004-09-15 | 2006-06-09 | 453d |  | R4 | 3624h | 3624h | Rel-6 | RInImp-HSPerf-10code | Nokia | jussi.numminen@nokia.com | Issam | RInImp-HSPerf-10code | 25.101 |  |  |
| 4850 | 1337.8.2 | Testing of Improved Minimum Performance for HSDPA |  | 650d | 2003-09-19 A | 2006-03-16 A | 100% | 2003-09-19 | 2006-03-16 | 650d | finish no earlier than 2006-03-16 | R5 | 5200h | 5200h | Rel-6 | RInImp-HSPerf-10Code_Test | Motorola | carolyn.taylor@motorola.com | Ingbert | RInImp-HSPerf-10Code_Test | 34.108, 34.121, 34.122, 34.123-1, 34.123-2, 34.123-3 | 19/9/2003 |  |
| 4851 | 1337.8.3 | Performance Requirements of Receive Diversity for HSDPA |  | 387d | 2003-12-15 A | 2005-06-07 A | 100% | 2003-12-15 | 2005-06-07 | 387d |  | R4 | 3096h | 3096h | Rel-6 | RInImp-HSPerf-RxDiv | NTT DoCoMo | Takehiro Nakamura (nakamurata@nttdocomo.co.jp) | Issam | RInImp-HSPerf-RxDiv | 25.101 |  |  |
| 4852 | 1337.8.4 | Testing of Performance of Receiver diversity for HSDPA |  | 650d | 2003-09-19 A | 2006-03-16 A | 100% | 2003-09-19 | 2006-03-16 | 650d | finish no earlier than 2006-03-16 | R5 | 5200h | 5200h | Rel-6 | RInImp-HSPerf-RxDiv_Test | Motorola | carolyn.taylor@motorola.com | Ingbert | RInImp-HSPerf-RxDiv_Test | 34.108, 34.121, 34.122, 34.123-1, 34.123-2, 34.123-3 | 19/9/2003 |  |
| 4853 | 1338 | **Rel-6 RAN Feasibility Studies** |  | 1196d? | 2000-08-14 A | 2005-03-14 A | 100% | 2000-08-14 | 2005-03-14 | 1196d? |  | RP | 43048h | 43048h | Rel-6 |  |  |  |  |  |  |  |  |
| 4854 | 1338.1 | FS of the improved access to UE measurement data for CRNC to support TDD RRM |  | 270d? | 2002-12-06 A | 2003-12-18 A | 100% | 2002-12-06 | 2003-12-18 | 270d? | finish no earlier than 2003-09-19 | R3 | 2160h | 2160h | Rel-6 | RANimp-RRMopt-FSUEMsD | Interdigital | jim.miller@interdigital.com | Juha | RANimp-RRMopt-FSUEMsD | 25.801, 25.423 | SP-24 |  |
| 4855 | 1338.2 | FS on Radio link performance enhancements |  | 1067d | 2000-08-14 A | 2004-09-14 A | 100% | 2000-08-14 | 2004-09-14 | 1067d | finish no earlier than 2004-09-14 | R1 | 8536h | 8536h | Rel-6 | RInImp-Rlperf | Nokia | antti.toskala@nokia.com | Patrick | RInImp-Rlperf | 25.899 |  |  |
| 4856 | 1338.3 | FS on Improvement of inter-frequency and inter-system measurements for 1.28 Mcps TDD |  | 461d | 2001-12-14 A | 2003-09-19 A | 100% | 2001-12-14 | 2003-09-19 | 461d | start no earlier than 2001-12-14 | R1 | 3688h | 3688h | Rel-6 | RInImp-IfIsMLCR | Samsung | Li Xiao Qiang (xqli@samsung.co.kr) | Patrick | RInImp-IfIsMLCR | 25.888 |  |  |
| 4857 | 1338.4 | FS for the analysis of OFDM for UTRAN enhancement |  | 526d | 2002-06-10 A | 2004-06-14 A | 100% | 2002-06-10 | 2004-06-14 | 526d | start no earlier than 2002-06-10 | R1 | 4208h | 4208h | Rel-6 | RInImp-FSOFDM | Nortel | Sarah Boumendil | Patrick | RInImp-FSOFDM | 25.892 |  |  |
| 4858 | 1338.5 | FS on Uplink Enhancements for Dedicated Transport Channels |  | 396d | 2002-09-06 A | 2004-03-12 A | 100% | 2002-09-06 | 2004-03-12 | 396d | finish no earlier than 2004-03-12 | R1 | 3168h | 3168h | Rel-6 | RInImp-FSUpDTrCh | Nokia | Karri.Ranta-aho@nsn.com | Patrick | RInImp-FSUpDTrCh | 25.896 |  |  |
| 4859 | 1338.6 | FS on Analysis on Higher Chip Rates for UTRA TDD evolutions |  | 528d | 2002-09-06 A | 2004-09-14 A | 100% | 2002-09-06 | 2004-09-14 | 528d | finish no earlier than 2004-09-14 | R1 | 4224h | 4224h | Rel-6 | RInImp-FSVHCRTDD | IPWireless | mbeale@ipwireless.com | Patrick | RInImp-FSVHCRTDD | 25.895 |  |  |
| 4860 | 1338.7 | FS on Low Output Powers for general purpose FDD BSs |  | 128d | 2003-06-13 A | 2004-03-12 A | 100% | 2003-06-13 | 2004-03-12 | 128d | finish no earlier than 2004-03-12 | R3 | 1024h | 1024h | Rel-6 | RInImp-FSLoPw | Telefónica | Ana Burgos (burgos_a@tsm.es) | Juha | RInImp-FSLoPw | 25.807 |  |  |
| 4861 | 1338.8 | FS on Uplink enhancements for UTRA TDD |  | 462d | 2003-06-06 A | 2005-03-14 A | 100% | 2003-06-06 | 2005-03-14 | 462d | finish no earlier than 2005-03-14 | R1 | 3696h | 3696h | Rel-6 | RInImp-FSUpEnhTDD | Interdigital | Marian.Rudolf@InterDigital.com | Patrick | RInImp-FSUpEnhTDD | 25.804 |  |  |
| 4862 | 8.8 | FS on UE antenna efficiency test methods performance requirements (2) |  | 131d | 2002-03-08 A | 2002-09-06 A | 100% | 2002-03-08 | 2002-09-06 | 131d | finish no earlier than 2002-09-06 | R4 | 1048h | 1048h | Rel-6 | RInImp-UEAnTM2 | Allgon | Alf Ahlström (alf.ahlstrom@pwav.com) | Issam | RInImp-UEAnTM2 |  |  |  |
| 4863 | 9.4 | Deleted - FS on the evolution of the UTRAN architecture |  | 592d | 2002-09-09 A | 2004-12-14 A | 100% | 2002-09-09 | 2004-12-14 | 592d | finish no earlier than 2004-12-15 | R3 | 4736h | 4736h | Rel-6 | RANimp-FSEvo | Nokia | woonhee.hwang@nsn.com, Antti.Toskala@nokia.com | Juha | RANimp-FSEvo |  |  | RP-26 |

Notes:
- 4839: -
- 4840: -
- 4841: -
- 4842: -
- 4843: -
- 4844: Introduction of UMTS850 (Band V) in 25.307
- 4845: Introduction of UMTS800 in 25.307
- 4846: Introduction of UMTS1700/2100 (Band IV)
- 4847: -
- 4848: -
- 4849: Approved at RP#25 as RP-040375
- 4850: -
- 4851: -
- 4852: -
- 4853: -
- 4854: -
- 4855: Study finished at RP#25
- 4856: -
- 4857: -
- 4858: -
- 4859: Study finished at RP#25
- 4860: -
- 4861: -
- 4862: The RInImp-UEAnTM FS was re-opened at TSG RP#15 upon request from WG4
- 4863: Study Closed, work will continue within the FS on evolved UTRA and UTRAN

| ID | WBS | Task | Type | Duration | Start | Finish | Complete | Baseline start | Baseline finish | Baseline duration | Constraint | Deadline | Resources | Work | Actual work | Acronym | WI rapporteur name | WI rapporteur e-mail | Release | MCC resp | Acronym_3GU_Export | Impacted TSs and TRs | Created at | TSG stopped |
| --- | --- | --- | --- | --- | --- | --- | --- | --- | --- | --- | --- | --- | --- | --- | --- | --- | --- | --- | --- | --- | --- | --- | --- | --- |
| 4864 | 1339 | **FDD Enhanced Uplink** |  | 915d | 2004-03-15 A | 2007-09-14 A | 100% | 2004-03-15 | 2007-09-14 | 915d |  |  | R2; R1; R3; R4; R5 | 49800h | 49800h | EDCH | Ericsson | Joakim Bergström | Rel-6 | Yong-Jun | EDCH |  |  |  |
| 4865 | 1339.1 | FDD Enhanced Uplink - Stage 2 |  | 197d | 2004-03-15 A | 2004-12-14 A | 100% | 2004-03-15 | 2004-12-14 | 197d | finish no earlier than 2004-12-14 |  | R2 | 1576h | 1576h | EDCH-Stage2 |  |  | Rel-6 | Yong-Jun | EDCH-Stage2 | 25.309 |  |  |
| 4866 | 1339.2 | FDD Enhanced Uplink - Physical Layer |  | 261d | 2004-03-15 A | 2005-03-14 A | 100% | 2004-03-15 | 2005-03-14 | 261d | finish no earlier than 2005-03-14 |  | R1 | 2088h | 2088h | EDCH-Phys | Nokia | Karri.Ranta-aho@nsn.com | Rel-6 | Patrick | EDCH-Phys | 25.211, 25.212, 25.213, 25.214, 25.215 |  |  |
| 4867 | 1339.3 | FDD Enhanced Uplink - Layer 2 and 3 Protocol Aspects |  | 261d | 2004-03-15 A | 2005-03-14 A | 100% | 2004-03-15 | 2005-03-14 | 261d | finish no earlier than 2005-03-14 |  | R2 | 2088h | 2088h | EDCH-L23 | Ericsson | Joakim Bergström | Rel-6 | Yong-Jun | EDCH-L23 | 25.301, 25.302, 25.306, 25.321, 25.331 |  |  |
| 4868 | 1339.4 | FDD Enhanced Uplink - UTRAN Iub/Iur Protocol Aspects |  | 261d | 2004-03-15 A | 2005-03-14 A | 100% | 2004-03-15 | 2005-03-14 | 261d | finish no earlier than 2005-03-14 |  | R3 | 2088h | 2088h | EDCH-IurIub | Nortel | Saso Stojanovski | Rel-6 | Juha | EDCH-IurIub | 25.401, 25.420, 25.423, 25.430, 25.433 |  |  |
| 4869 | 1339.5 | FDD Enhanced Uplink - RF Radio Transmission/ Reception, System Performance Requirements and Conformance Testing |  | 74d | 2004-03-15 A | 2004-06-24 A | 100% | 2004-03-15 | 2004-06-24 | 74d |  |  | R4 | 592h | 592h | EDCH-RF | Ericsson | thomas.unshelm@ericsson.com | Rel-6 | Issam | EDCH-RF | 25.101, 25.104, 25.133, 25.141 |  |  |
| 4870 | 1339.6 | Conformance Test Aspects – FDD Enhanced Uplink |  | 596d | 2005-06-03 A | 2007-09-14 A | 100% | 2005-06-03 | 2007-09-14 | 596d | finish no earlier than 2007-09-14 | 2006-06-02 | R5 | 4768h | 4768h | EDCH_Test | Ericsson | Leif.Mattisson@ericsson.com | Rel-6 | Ingbert | EDCH_Test | 34.108, 34.109, 34.121, 34.123-1, 34.123-2, 34.123-3 | Fri 03/06/05 |  |
| 4871 | 1340 | **Rel-6 RAN improvements** |  | 656d? | 2002-09-09 A | 2005-03-14 A | 100% | 2002-09-09 | 2005-03-14 | 656d? |  |  | RP; S5 | 36720h | 36720h |  |  |  | Rel-6 |  |  |  |  |  |
| 4872 | 9.2 | **RAB support enhancement** |  | 522d? | 2003-03-14 A | 2005-03-14 A | 100% | 2003-03-14 | 2005-03-14 | 522d? |  |  | R2 | 9360h | 9360h |  | Nokia | Jussi Kähtävä (juha.mikola@nokia.com) | Rel-6 | Yong-Jun |  | 25.862 |  |  |
| 4873 | 1340.1.1 | Optimization of downlink channelisation code utilisation |  | 262d | 2004-03-12 A | 2005-03-14 A | 100% | 2004-03-12 | 2005-03-14 | 262d | finish no earlier than 2005-03-14 |  | R1 | 2096h | 2096h | RANimp-RABSE-CodeOptFDD | Nortel | Sarah Boumendil | Rel-6 | Patrick | RANimp-RABSE-CodeOptFDD |  |  |  |
| 4874 | 1340.1.2 | optimization of channelisation code utilisation for 3.84 Mcps TDD |  | 261d | 2004-03-15 A | 2005-03-14 A | 100% | 2004-03-15 | 2005-03-14 | 261d | finish no earlier than 2005-03-15 |  | R1 | 2088h | 2088h | RANimp-RABSE-CodOptTDD | IPWireless | Nicholas Anderson | Rel-6 | Patrick | RANimp-RABSE-CodOptTDD |  |  |  |
| 4875 | 1340.1.3 | HS-DPCCH ACK/NACK Enhancement |  | 65d? | 2004-09-15 A | 2004-12-14 A | 100% | 2004-09-15 | 2004-12-14 | 65d? | finish no earlier than 2004-12-15 |  | R1 | 520h | 520h | RANimp-RABSE-ACKNACK | Nokia | Jussi Kähtävä (juha.mikola@nokia.com) | Rel-6 | Patrick | RANimp-RABSE-ACKNACK | 25.212, 25.214, 24.331, 25.433 |  |  |
| 4876 | 1340.1.4 | Deleted - Iu enhancements for IMS support in RAN |  | 320d? | 2003-03-14 A | 2004-06-03 A | 100% | 2003-03-14 | 2004-06-03 | 320d? | start no earlier than 2003-03-14 |  | R3 | 2560h | 2560h | RANimp-RABSE-IuEnhIMS | Nortel | Philippe.Godin@nortelnetworks.com | Rel-6 | Juha | RANimp-RABSE-IuEnhIMS |  |  | RP-24 |
| 4877 | 1340.1.5 | Deleted - Improvement of RRM across RNS and RNS/BSS | milestone | 0d? | 2003-12-05 A | 2003-12-05 A | 100% | 2003-12-05 | 2003-12-05 | 0d? | finish no earlier than 2003-12-05 |  | R3 |  |  | RANimp-RRM1 | Nokia | antti.toskala@nokia.com | Rel-6 | Juha | RANimp-RRM1 |  |  | RP-23 |
| 4878 | 9.1 | Beamforming Enhancements |  | 66d | 2003-09-19 A | 2003-12-19 A | 100% | 2003-09-19 | 2003-12-19 | 66d | finish no earlier than 2004-03-12 |  | R1 | 528h | 528h | RANimp-BFE | Nokia | Jussi Kähtävä (juha.mikola@nokia.com) | Rel-6 | Patrick | RANimp-BFE | 24.215, 25.423, 25.425, 25.433, 25.435 |  |  |
| 4879 | 1340.3 | **Rel-6 RRM optimization for Iur and Iub** |  | 126d | 2003-09-19 A | 2004-03-12 A | 100% | 2003-09-19 | 2004-03-12 | 126d |  |  | R3 | 2016h | 2016h | RANimp-RRMopt-UEMsD | Ericsson | Gert-Jan.van.Lieshout@eln.ericsson.se | Rel-6 | Juha | RANimp-RRMopt-UEMsD |  |  |  |
| 4880 | 1340.3.1 | Improved access to UE measurement data for CRNC to support TDD RRM |  | 126d | 2003-09-19 A | 2004-03-12 A | 100% | 2003-09-19 | 2004-03-12 | 126d | finish no earlier than 2004-03-15 |  | R3 | 1008h | 1008h |  | Interdigital | jim.miller@interdigital.com | Rel-6 | Juha |  | 25.423 |  | RP-22 |
| 4881 | 1340.4 | **Remote Control of Electrical Tilting Antennas** |  | 395d? | 2003-03-14 A | 2004-09-16 A | 100% | 2003-03-14 | 2004-09-16 | 395d? |  |  | R3; S5 | 10624h | 10624h | RANimp-TiltAnt | Vodafone | Andreas.Hauser@vodafone.com | Rel-6 | Juha | RANimp-TiltAnt |  |  |  |
| 4882 | 1340.4.1 | Tilting Antenna - RAN aspects |  | 393d? | 2003-03-14 A | 2004-09-14 A | 100% | 2003-03-14 | 2004-09-14 | 393d? | finish no earlier than 2004-09-14 |  | R3 | 3144h | 3144h |  | Vodafone | Andreas.Hauser@vodafone.com | Rel-6 | Juha |  | 25.460, 25.461, 25.462, 25.463 |  |  |
| 4883 | 1340.4.2 | OAM&P impacts |  | 145d | 2004-02-27 A | 2004-09-16 A | 100% | 2004-02-27 | 2004-09-16 | 145d | finish no earlier than 2004-09-16 |  | S5 | 1160h | 1160h | RANimp-TiltAnt-OAM | Vodafone | Adrian.Neal@vodafone.com | Rel-6 | Mirko | RANimp-TiltAnt-OAM | 32.804, 32.64x | SP-24 |  |
| 4884 | 1340.5 | Network Assisted Cell Change (NACC) from UTRAN to GERAN - network-side aspects |  | 462d? | 2002-09-09 A | 2004-06-15 A | 100% | 2002-09-09 | 2004-06-15 | 462d? | finish no earlier than 2004-06-15 |  | R3 | 3696h | 3696h | RANimp-NACC | Vodafone | Brendan.McWilliams@gb.vodafone.co.uk | Rel-6 | Juha | RANimp-NACC |  |  |  |
| 4885 | 12 | **Location Services enhancements 2** |  | 1024d? | 2001-01-15 A | 2004-12-16 A | 100% | 2001-01-15 | 2004-12-16 | 1024d? |  |  | S2; S5; N4; R2; R4; R5; OMA | 175184h | 175184h | LCS2 | Nokia | Jan Kåll | Rel-6 | Maurice | LCS2 |  |  |  |
| 4886 | 12.1 | **Improvement on Le interface** |  | 653d? | 2002-06-17 A | 2004-12-15 A | 100% | 2002-06-17 | 2004-12-15 | 653d? |  |  | S2; OMA | 15096h | 15096h |  | Nokia | Jan Kåll | Rel-6 | Maurice |  |  |  |  |
| 4887 | 1341.1.1 | Stage 2 for Improvement on Le interface |  | 331d? | 2002-06-17 A | 2003-09-22 A | 100% | 2002-06-17 | 2003-09-22 | 331d? | start no earlier than 2002-06-17 |  | S2 | 2648h | 2648h |  | Nokia | Jan Kåll | Rel-6 | Maurice |  | 23.002,23.271 |  |  |
| 4888 | 1341.1.2 | Stage 3 - impacts MLP (Mobile Location Protocol) |  | 250d? | 2004-01-01 A | 2004-12-15 A | 100% | 2004-01-01 | 2004-12-15 | 250d? | finish no earlier than 2004-12-15 |  | OMA | 2000h | 2000h |  | OMA | OMA-LIAISON@mail.openmobilealliance.org | Rel-6 |  |  |  |  |  |

Notes:
- 4864: -
- 4865: -
- 4866: -
- 4867: -
- 4868: -
- 4869: -
- 4870: -
- 4871: Generic feature
- 4872: building block without particular end date
- 4873: -
- 4874: WIDS modified in RP#26, RP-040551
- 4875: Approved at RP#25 as RP-040390
- 4876: Closed RP#24 due to the lack of progress
- 4877: abandoned RP-23
- 4878: -
- 4879: -
- 4880: -
- 4881: -
- 4882: Finished at RP#25
- 4883: SP#25 09/2004 completed
- 4884: -
- 4885: -
- 4886: -
- 4887: -
- 4888: -

| ID | WBS | Task | Type | Duration | Start | Finish | Complete | Baseline start | Baseline finish | Baseline duration | Constraint | Resources | Work | Actual work | WI rapporteur name | WI rapporteur e-mail | Release | MCC resp | Acronym | Acronym_3GU_Export | TSG stopped |
| --- | --- | --- | --- | --- | --- | --- | --- | --- | --- | --- | --- | --- | --- | --- | --- | --- | --- | --- | --- | --- | --- |
| 4889 | 12.2 | **Enhanced support for anonymity and user privacy** |  | 638d? | 2002-07-08 A | 2004-12-15 A | 100% | 2002-07-08 | 2004-12-15 | 638d? |  | S2; OMA | 14248h | 14248h | Nokia | Jan Kåll | Rel-6 | Maurice |  |  |  |
| 4890 | 1341.2.1 | Stage 2 for Enhanced support for anonymity and user privacy |  | 255d? | 2002-07-08 A | 2003-06-27 A | 100% | 2002-07-08 | 2003-06-27 | 255d? | finish no earlier than 2003-06-27 | S2 | 2040h | 2040h | Nokia | Jan Kåll | Rel-6 | Maurice |  |  |  |
| 4891 | 1341.2.2 | Stage 3 - impacts MLP and RLP |  | 250d? | 2004-01-01 A | 2004-12-15 A | 100% | 2004-01-01 | 2004-12-15 | 250d? | finish no earlier than 2004-12-15 | OMA | 2000h | 2000h | OMA | OMA-LIAISON@mail.openmobilealliance.org | Rel-6 |  |  |  |  |
| 4892 | 12.3 | **Enhanced inter-GMLC interface** |  | 648d? | 2002-06-24 A | 2004-12-15 A | 100% | 2002-06-24 | 2004-12-15 | 648d? |  | S2; OMA | 14888h | 14888h | Nokia | Jan Kåll | Rel-6 | Maurice |  |  |  |
| 4893 | 1341.3.1 | Stage 2 for Enhanced inter-GMLC interface |  | 315d? | 2002-06-24 A | 2003-09-05 A | 100% | 2002-06-24 | 2003-09-05 | 315d? | finish no earlier than 2003-09-05 | S2 | 2520h | 2520h | Nokia | Jan Kåll | Rel-6 | Maurice |  |  |  |
| 4894 | 1341.3.2 | Stage 3 - definition of RLP and PCP |  | 250d? | 2004-01-01 A | 2004-12-15 A | 100% | 2004-01-01 | 2004-12-15 | 250d? | finish no earlier than 2004-12-15 | OMA | 2000h | 2000h | OMA | OMA-LIAISON@mail.openmobilealliance.org | Rel-6 |  |  |  |  |
| 4895 | 12.4 | **Location Services support for IMS public identities** |  | 473d? | 2003-02-24 A | 2004-12-15 A | 100% | 2003-02-24 | 2004-12-15 | 473d? |  | S2; OMA | 11488h | 11488h | Nokia | Jan Kåll | Rel-6 | Maurice |  |  |  |
| 4896 | 1341.4.1 | Stage 2 for Location Services support for IMS public identities |  | 240d? | 2003-02-24 A | 2004-01-23 A | 100% | 2003-02-24 | 2004-01-23 | 240d? | finish no earlier than 2004-01-23 | S2 | 1920h | 1920h | Nokia | Jan Kåll | Rel-6 | Maurice |  |  |  |
| 4897 | 1341.4.2 | OMA Stage 3 for Location Services support for IMS public identities - impacts MLP, RLP and PCP |  | 250d? | 2004-01-01 A | 2004-12-15 A | 100% | 2004-01-01 | 2004-12-15 | 250d? | finish no earlier than 2004-12-15 | OMA | 2000h | 2000h | OMA | OMA-LIAISON@mail.openmobilealliance.org | Rel-6 |  |  |  |  |
| 4898 | 12.5 | **New area event for location service triggering reports** |  | 663d? | 2002-06-03 A | 2004-12-15 A | 100% | 2002-06-03 | 2004-12-15 | 663d? |  | S2; N4; OMA | 22024h | 22024h | Nokia | Jan Kåll | Rel-6 | Maurice |  |  |  |
| 4899 | 1341.5.1 | Stage 2 for New area event for location service triggering reports |  | 280d? | 2002-06-03 A | 2003-06-27 A | 100% | 2002-06-03 | 2003-06-27 | 280d? | finish no earlier than 2003-06-27 | S2 | 2240h | 2240h | Nokia | Jan Kåll | Rel-6 | Maurice |  |  |  |
| 4900 | 1341.5.2 | Stage 3 for UE-CN signalling |  | 234d? | 2003-10-09 A | 2004-08-31 A | 100% | 2003-10-09 | 2004-08-31 | 234d? | start no earlier than 2003-10-09 | N4 | 1872h | 1872h | Nokia |  | Rel-6 | Kimmo |  |  |  |
| 4901 | 1341.5.3 | Stage 3 for New area event for location service triggering reports - impacts MLP, RLP and PCP |  | 250d? | 2004-01-01 A | 2004-12-15 A | 100% | 2004-01-01 | 2004-12-15 | 250d? | finish no earlier than 2004-12-15 | OMA | 2000h | 2000h | OMA | OMA-LIAISON@mail.openmobilealliance.org | Rel-6 |  |  |  |  |
| 4902 | 12.7 | **UE positioning for Location Services enhancements 2** |  | 957d? | 2001-01-15 A | 2004-09-14 A | 100% | 2001-01-15 | 2004-09-14 | 957d? |  | R2; R4; R5 | 36456h | 36456h |  |  | Rel-6 | Issam | LCS2-UEpos | LCS2-UEpos |  |
| 4903 | 12.8 | Open SMLC-SRNC Interface within the UTRAN to support UTRAN Rel-4 positioning methods |  | 700d? | 2001-01-15 A | 2003-09-19 A | 100% | 2001-01-15 | 2003-09-19 | 700d? | finish no earlier than 2003-09-19 | R2 | 5600h | 5600h | Siemens | Meik.Kottkamp@siemens.com | Rel-6 | Yong-Jun | LCS-Rel4Pos | LCS-Rel4Pos |  |
| 4904 | 1341.6.2 | A-GPS minimum performance specification |  | 333d? | 2003-06-06 A | 2004-09-14 A | 100% | 2003-06-06 | 2004-09-14 | 333d? | finish no earlier than 2004-09-14 | R4; R5 | 5328h | 5328h | AT&T Wireless | donglin.shen@attws.com | Rel-6 | Issam | LCS-UEPos-AGPSPerf | LCS-UEPos-AGPSPerf |  |
| 4905 | 12.7.2 | Deleted - FS on Enhancements to OTDOA Positioning using advanced blanking methods |  | 320d | 2002-07-01 A | 2003-09-19 A | 100% | 2002-07-01 | 2003-09-19 | 320d | finish no earlier than 2003-09-19 | R2 | 2560h | 2560h | Cambridge Positioning Systems | david.bartlett@cursor-system.com | Rel-6 | Yong-Jun | LCS2-UEpos-FSBlank | LCS2-UEpos-FSBlank | RP-38 |
| 4906 | 1341.6.4 | Deleted - UE positioning enhancements - other methods | milestone | 0d? | 2003-09-26 A | 2003-09-26 A | 100% | 2003-09-26 | 2003-09-26 | 0d? | finish no earlier than 2003-09-26 | R2 |  |  | Siemens | Meik.Kottkamp@siemens.com | Rel-6 | Yong-Jun | LCS2-UEpos-enh | LCS2-UEpos-enh | RP-24 |
| 4907 | 1341.7 | LCS charging |  | 455d? | 2003-03-21 A | 2004-12-16 A | 100% | 2003-03-21 | 2004-12-16 | 455d? | start no earlier than 2003-03-21 | S5 | 3640h | 3640h | France Telecom | alain.bibas@orange-ft.com | Rel-6 | Mirko | LCS2-CH | LCS2-CH |  |
| 4908 | 14 | **Rel-6 Security enhancements** |  | 1018d? | 2001-01-03 A | 2004-11-26 A | 100% | 2001-01-03 | 2004-11-26 | 1018d? |  | S3 | 28824h | 28824h | Vodafone | Peter.Howard@vodafone.com | Rel-6 | Mirko | SEC16 | SEC1, Rel-6 |  |
| 4909 | 14.1 | **Enhanced HE control of security (including positive authentication reporting)** |  | 712d | 2001-01-03 A | 2003-09-25 A | 100% | 2001-01-03 | 2003-09-25 | 712d |  | S3 | 14064h | 14064h | Vodafone | Peter.Howard@vodafone.com | Rel-6 | Mirko |  |  |  |
| 4910 | 14.1.1 | Deleted - SEC1 Stage 2 (Enhanced HE control of security) |  | 378d | 2001-01-03 A | 2002-06-14 A | 100% | 2001-01-03 | 2002-06-14 | 378d | finish no earlier than 2002-06-14 | S3 | 3024h | 3024h |  |  | Rel-6 | Mirko |  |  | SP-16 |
| 4911 | 14.1.3 | **Rel-6 Network Domain Security** |  | 334d | 2002-06-17 A | 2003-09-25 A | 100% | 2002-06-17 | 2003-09-25 | 334d |  | S3 | 5344h | 5344h | Telenor | Geir-myrdahl.koien@telenor.com | Rel-6 | Mirko | SEC1-NDS | SEC1-NDS |  |
| 4912 | 14.1.3.1 | Rel-6 IP network layer security (NDS/IP) |  | 334d | 2002-06-17 A | 2003-09-25 A | 100% | 2002-06-17 | 2003-09-25 | 334d | finish no earlier than 2003-09-25 | S3 | 2672h | 2672h |  |  | Rel-6 | Mirko | SEC1-NDS-IP | SEC1-NDS-IP |  |
| 4913 | 1342.2 | Network Domain Security; Authentication Framework (NDS/AF) |  | 521d? | 2002-02-15 A | 2004-02-13 A | 100% | 2002-02-15 | 2004-02-13 | 521d? | finish no earlier than 2004-02-13 | S3 | 4168h | 4168h | Nokia | tommi.viitanen@nokia.com | Rel-6 | Mirko | SEC1-NDS-AF | SEC1-NDS-AF |  |
| 4914 | 1342.3 | Key Management of group keys for Voice Group Call Services |  | 306d | 2003-09-26 A | 2004-11-26 A | 100% | 2003-09-26 | 2004-11-26 | 306d | finish no earlier than 2004-11-26 | S3 | 2448h | 2448h | Vodafone | benno.tietz@vodafone.com | Rel-6 | Mirko | SECGKYV | SECGKYV |  |
| 4915 | 1343 | Network Domain Security; MAP application layer security (NDS/MAPsec) |  | 127d? | 2004-07-06 A | 2004-12-29 A | 100% | 2004-07-06 | 2004-12-29 | 127d? | finish no earlier than 2003-12-26 | S3 | 1016h | 1016h | Vodafone | Peter.Howard@vodafone.com | Rel-6 | Mirko | MAPSEC | MAPSEC |  |

Notes:
- 4889: -
- 4890: - / Impacted TSs and TRs: 23.002,23.271
- 4891: -
- 4892: -
- 4893: - / Impacted TSs and TRs: 23.002,23.271
- 4894: -
- 4895: -
- 4896: - / Impacted TSs and TRs: 23.002,23.271
- 4897: -
- 4898: -
- 4899: - / Impacted TSs and TRs: 23.002,23.271
- 4900: Current stage 3 fullfills stage 2
- 4901: -
- 4902: -
- 4903: - / Impacted TSs and TRs: 25.305, 25.401, 25.450, 25.452, 25.453
- 4904: RP#25 completed (FDD) / Impacted TSs and TRs: new 25.171, 34.171 (testing)
- 4905: RP#38 Work stopped / Impacted TSs and TRs: new TR 25.894
- 4906: RP#24 Work stopped
- 4907: SP#26 completed / Impacted TSs and TRs: new TS 32.271
- 4908: SP#9 approved WID. Acronym changed from "SEC1, Rel-6"
- 4909: SP#9 approved WID S3-000490 (Enhanced home control of security by HE) / Impacted TSs and TRs: 33.102
- 4910: Marked as stopped 12/2008
- 4911: SP#9 approved WID S3-000606 (Network Domain Security) / Impacted TSs and TRs: 33.102, 33.103, 33.105
- 4912: SP#9 approved WID S3-000626 (Access security for IP-based services) / Impacted TSs and TRs: 33.210
- 4913: SP#19 approved WID / Impacted TSs and TRs: 33.810
- 4914: - / Impacted TSs and TRs: 42.068, 43.068, 44.068, 42.069, 43.069, 44.069, 31.102, 24.008, 48.008, 42.009, 43.020, New TSs (55.236, 55.205) MILENAGE algorithms
- 4915: SP#19 approved WID. Marked as closed 12/2008 (was marked 20% complete) / Impacted TSs and TRs: 33.200

| ID | WBS | Task | Type | Duration | Start | Finish | Complete | Baseline start | Baseline finish | Baseline duration | Constraint | Resources | Work | Actual work | Acronym | Release | MCC resp | Acronym_3GU_Export | Impacted TSs and TRs | WI rapporteur name | WI rapporteur e-mail | TSG stopped |
| --- | --- | --- | --- | --- | --- | --- | --- | --- | --- | --- | --- | --- | --- | --- | --- | --- | --- | --- | --- | --- | --- | --- |
| 4916 | 16 | **IMS Phase 2** |  | 1840d? | 2000-08-28 A | 2007-09-14 A | 100% | 2000-08-28 | 2007-09-14 | 1840d? |  | S1; S2; S3; S5; NP; R5 | 210576h | 210576h | IMS2 | Rel-6 | Alain | IMS2 |  |  |  |  |
| 4917 | 1344.1 | Enhancements to the Cx and Sh interfaces |  | 323d? | 2003-06-06 A | 2004-08-31 A | 100% | 2003-06-06 | 2004-08-31 | 323d? | finish no earlier than 2004-08-31 | N4 | 2584h | 2584h | IMS2-CCR | Rel-6 | Kimmo | IMS2-CCR |  |  |  |  |
| 4918 | 1344.2 | Conformance Test Aspects – IMS Call Control Rel-6 enhancements |  | 396d? | 2006-03-10 A | 2007-09-14 A | 100% | 2006-03-10 | 2007-09-14 | 396d? | finish no earlier than 2007-09-14 | R5 | 3168h | 3168h | IMS2_CCR_Test | Rel-6 | Ingbert | IMS2_CCR_Test | 34.229-1, 34.229-2, 34.229-3, 34.108 | Ericsson | Jacob.John@motorola.com, Leif.Mattisson@ericsson.com |  |
| 4919 | 16.12 | **IMS Group Management** |  | 715d? | 2002-03-14 A | 2004-12-08 A | 100% | 2002-03-14 | 2004-12-08 | 715d? |  | S1 | 12680h | 12680h | IMSGM | Rel-6 | Alain | IMSGM |  | Nokia | juha.kalliokulju@nokia.com |  |
| 4920 | 16.12.1 | Stage 1 - TS on IMS group management |  | 193d | 2002-03-14 A | 2002-12-09 A | 100% | 2002-03-14 | 2002-12-09 | 193d | finish no earlier than 2002-12-09 | S1 | 1544h | 1544h |  | Rel-6 | Alain |  |  | Nokia | juha.kalliokulju@nokia.com |  |
| 4921 | 1344.3.2 | Stage 2 for IMS Group Management |  | 158d? | 2003-05-26 A | 2003-12-31 A | 100% | 2003-05-26 | 2003-12-31 | 158d? | finish no earlier than 2003-12-31 | S2 | 1264h | 1264h |  | Rel-6 | Maurice |  | 23.228 |  |  |  |
| 4922 | 1344.3.3 | Stage 3 for IMS Group management (e.g. chat) |  | 519d? | 2002-12-13 A | 2004-12-08 A | 100% | 2002-12-13 | 2004-12-08 | 519d? | finish no earlier than 2004-12-08 | N1 | 4152h | 4152h |  | Rel-6 | Frederic |  |  | Lucent | Keith Drage (drage@alcatel-lucent.com) |  |
| 4923 | 1344.4 | **IMS Conferencing** |  | 548d? | 2002-11-04 A | 2004-12-08 A | 100% | 2002-11-04 | 2004-12-08 | 548d? |  | N1 | 10960h | 10960h |  | Rel-6 | Frederic |  |  |  |  |  |
| 4924 | 1344.4.1 | Stage 2 for IMS Conferencing |  | 303d? | 2002-11-04 A | 2003-12-31 A | 100% | 2002-11-04 | 2003-12-31 | 303d? | finish no earlier than 2003-12-31 | S2 | 2424h | 2424h |  | Rel-6 | Maurice |  | 23.228 |  |  |  |
| 4925 | 1344.4.2 | Stage 3 for IMS Conferencing |  | 519d? | 2002-12-13 A | 2004-12-08 A | 100% | 2002-12-13 | 2004-12-08 | 519d? | finish no earlier than 2004-12-08 | N1 | 4152h | 4152h |  | Rel-6 | Frederic |  |  | Lucent | Keith Drage (drage@alcatel-lucent.com) |  |
| 4926 | 16.11 | **IMS Messaging** |  | 992d? | 2002-03-14 A | 2005-12-30 A | 100% | 2002-03-14 | 2005-12-30 | 992d? |  | S1 | 23912h | 23912h | IMSM | Rel-6 | Alain | IMSM |  | Nokia | juha.kalliokulju@nokia.com |  |
| 4927 | 16.11.1 | TR on support of messaging in the IMS |  | 193d | 2002-03-14 A | 2002-12-09 A | 100% | 2002-03-14 | 2002-12-09 | 193d | finish no earlier than 2002-12-09 | S1 | 1544h | 1544h | IMSM-TR | Rel-6 | Alain | IMSM-TR | New 22.940 | Nokia | juha.kalliokulju@nokia.com |  |
| 4928 | 1344.5.2 | Stage 1 22.340 |  | 23d? | 2002-11-11 A | 2002-12-11 A | 100% | 2002-11-11 | 2002-12-11 | 23d? | finish no earlier than 2002-12-11 | S1 | 184h | 184h | IMSM-TS | Rel-6 | Alain | IMSM-TS | 22.340 | Nokia | juha.kalliokulju@nokia.com |  |
| 4929 | 1344.5.3 | CRs to 22.140 & 22.228 |  | 263d? | 2002-03-14 A | 2003-03-17 A | 100% | 2002-03-14 | 2003-03-17 | 263d? | finish no earlier than 2003-03-17 | S1 | 2104h | 2104h | IMSM-CR | Rel-6 | Alain | IMSM-CR | 22.140,22.228 | Nokia | juha.kalliokulju@nokia.com |  |
| 4930 | 16.11.3 | Stage 2 for IMS Messaging |  | 477d | 2002-11-04 A | 2004-08-31 A | 100% | 2002-11-04 | 2004-08-31 | 477d | finish no earlier than 2004-08-31 | S2 | 3816h | 3816h |  | Rel-6 | Maurice |  | 23.228 |  |  |  |
| 4931 | 1344.5.5 | Stage 3 for IMS Messaging |  | 519d? | 2002-12-13 A | 2004-12-08 A | 100% | 2002-12-13 | 2004-12-08 | 519d? | finish no earlier than 2004-12-08 | N1 | 4152h | 4152h |  | Rel-6 | Frederic |  |  | Lucent | Keith Drage (drage@alcatel-lucent.com) |  |
| 4932 | 1344.5.6 | SIP/SIMPLE Instant messaging |  | 522d? | 2004-01-01 A | 2005-12-30 A | 100% | 2004-01-01 | 2005-12-30 | 522d? | finish no earlier than 2005-06-30 | OMA | 4176h | 4176h |  | Rel-6 |  |  |  |  | OMA-LIAISON@mail.openmobilealliance.org |  |
| 4933 | 1344.6 | **Additional SIP Capabilities support not covered by Rel-5** |  | 680d? | 2002-11-11 A | 2005-06-17 A | 100% | 2002-11-11 | 2005-06-17 | 680d? |  | N1 | 13392h | 13392h |  | Rel-6 | Frederic |  |  |  |  |  |
| 4934 | 1344.6.1 | Stage 2 for add SIP cap (e.g. forking) |  | 335d? | 2002-11-11 A | 2004-02-20 A | 100% | 2002-11-11 | 2004-02-20 | 335d? | finish no earlier than 2004-02-20 | S2 | 2680h | 2680h |  | Rel-6 | Maurice |  | 23.228 |  |  |  |
| 4935 | 1344.6.2 | Stage 3 for Additional SIP Capabilities |  | 454d? | 2002-12-13 A | 2004-09-08 A | 100% | 2002-12-13 | 2004-09-08 | 454d? | finish no earlier than 2004-09-08 | N1 | 3632h | 3632h |  | Rel-6 | Frederic |  |  | Lucent | Keith Drage (drage@alcatel-lucent.com) |  |
| 4936 | 1344.6.3 | Procedured associated with IMS-ALG |  | 205d? | 2004-09-06 A | 2005-06-17 A | 100% | 2004-09-06 | 2005-06-17 | 205d? | start no earlier than 2004-09-06 | N1 | 1640h | 1640h |  | Rel-6 | Frederic |  |  |  |  |  |
| 4937 | 1344.7 | Review additional SIP Capabilities against IMS |  | 454d? | 2002-12-13 A | 2004-09-08 A | 100% | 2002-12-13 | 2004-09-08 | 454d? | finish no earlier than 2004-09-08 | N1 | 3632h | 3632h |  | Rel-6 | Frederic |  |  | Lucent | Keith Drage (drage@alcatel-lucent.com) |  |
| 4938 | 16.5 | **Interworking between IMS and IP networks** |  | 1118d? | 2000-08-28 A | 2004-12-08 A | 100% | 2000-08-28 | 2004-12-08 | 1118d? |  | N3 | 31712h | 31712h | IMS-CCR-IWIP | Rel-6 | Gwiho | IMS-CCR-IWIP | 23.821, 29.061, 29.162 | BT | nigel.holland@bt.com |  |
| 4939 | 16.5.1 | Interworking for 3GPP_SIP and IETF_SIP |  | 730d | 2000-08-28 A | 2003-06-13 A | 100% | 2000-08-28 | 2003-06-13 | 730d | finish no earlier than 2003-06-13 | N3 | 5840h | 5840h |  | Rel-6 | Gwiho |  | New 29.962 | Siemens | Thomas.Belling@nsn.com |  |
| 4940 | 16.5.2 | Interworking for IPv6 to IPv4 |  | 1118d | 2000-08-28 A | 2004-12-08 A | 100% | 2000-08-28 | 2004-12-08 | 1118d | finish no earlier than 2004-12-08 | N3 | 8944h | 8944h |  | Rel-6 | Gwiho |  | 29.163 |  |  |  |
| 4941 | 1344.8.3 | Interworking for IPv6 to IPv4 (SIP / SDP aspects) |  | 87d? | 2004-05-11 A | 2004-09-08 A | 100% | 2004-05-11 | 2004-09-08 | 87d? | finish no earlier than 2004-09-08 | N1 | 696h | 696h |  | Rel-6 | Frederic |  |  |  |  |  |
| 4942 | 16.8.1 | stage 3 of interworking with non-IMS IP networks |  | 911d | 2001-03-14 A | 2004-09-08 A | 100% | 2001-03-14 | 2004-09-08 | 911d | finish no earlier than 2004-09-08 | N1 | 7288h | 7288h |  | Rel-6 | Frederic |  |  |  |  |  |
| 4943 | 16.6.1 | Interworking between IMS and CS networks |  | 929d? | 2000-08-28 A | 2004-03-18 A | 100% | 2000-08-28 | 2004-03-18 | 929d? | finish no earlier than 2004-03-18 | N3 | 7432h | 7432h | IMS-CCR-IWCS | Rel-6 | Gwiho | IMS-CCR-IWCS | 29.163, 29.061, 24.228, and New CN4 specification | Vodafone | Brendan.McWilliams@gb.vodafone.co.uk |  |
| 4944 | 16.10 | Mn interface (IM-MGW to MGCF) enhancements (CN4 Part) |  | 418d | 2001-08-07 A | 2004-09-01 A | 100% | 2001-08-07 | 2004-09-01 | 418d | finish no earlier than 2004-09-01 | N4 | 3344h | 3344h | IMS-CCR-Mn | Rel-6 | Kimmo | IMS-CCR-Mn |  |  |  |  |
| 4945 | 1344.11 | Study of subscriber and operators relationship in IMS and related ISIM requirements for Rel 6” |  | 20d? | 2002-11-15 A | 2002-12-12 A | 100% | 2002-11-15 | 2002-12-12 | 20d? | finish no earlier than 2002-12-12 | S1 | 160h | 160h |  | Rel-6 | Alain |  |  | Nokia | juha.kalliokulju@nokia.com |  |
| 4946 | 1344.12 | Lawful Interception in Rel-6 architecture |  | 269d? | 2002-12-09 A | 2003-12-18 A | 100% | 2002-12-09 | 2003-12-18 | 269d? | finish no earlier than 2003-12-18 | S3 | 2152h | 2152h | SEC1-LI | Rel-6 | Mirko | SEC1-LI, Rel-6 | 33.106, 33.107, 33.108 | Reg TP, Nortel | berthold.wilhelm@regtp.de, Ron Ryan |  |
| 4947 | 1344.13 | IMS Subscription and access scenarios |  | 130d? | 2002-12-16 A | 2003-06-13 A | 100% | 2002-12-16 | 2003-06-13 | 130d? | start no earlier than 2002-12-16 | S1 | 1040h | 1040h |  | Rel-6 | Alain |  | 22.800 | TeliaSonera | FRANK, Robert |  |
| 4948 | 1344.14 | IMS charging |  | 455d? | 2003-03-21 A | 2004-12-16 A | 100% | 2003-03-21 | 2004-12-16 | 455d? | finish no earlier than 2004-12-16 | S5 | 3640h | 3640h | IMS2-CH | Rel-6 | Mirko | IMS2-CH | 32.260 | Ericsson | Patrik TEPPO |  |
| 4949 | 1344.15 | IMS Management objects |  | 306d? | 2004-09-03 A | 2005-11-04 A | 100% | 2004-09-03 | 2005-11-04 | 306d? | finish no earlier than 2005-03-04 | N1 | 2448h | 2448h |  | Rel-6 | Frederic |  | 24.167 |  |  |  |
| 4950 | 1344.16 | Deleted - Stage 2 of IMS Phase 2 | milestone | 0d? | 2003-09-19 A | 2003-09-19 A | 100% | 2003-09-19 | 2003-09-19 | 0d? | finish no earlier than 2003-09-19 | S2 |  |  |  | Rel-6 | Maurice |  |  |  |  | SP-21 |

Notes:
- 4916: -
- 4917: Shared public user identities need to be solved. If email approval CR is accepted. Work 100% done.
- 4918: -
- 4919: -
- 4920: -
- 4921: -
- 4922: Depends on CN decision on CPCP in Rel-6. Complete, if unresolved IETF dependencies are dropped (-> LS to CN plenary)
- 4923: -
- 4924: -
- 4925: Depends on CN decision on IETF dependenciES in CP-150Rel-6. Higher figure if CPCP is dropped (-> LS to CN plenary)
- 4926: -
- 4927: -
- 4928: -
- 4929: -
- 4930: -
- 4931: -
- 4932: Updated according to SP-040232
- 4933: -
- 4934: -
- 4935: -
- 4936: -
- 4937: -
- 4938: [DAB 14.02.02] - end date pushed back to March 2003
- 4939: [DAB - 20.08.03] - CN Part of TR Complete @ CN#20
- 4940: -
- 4941: -
- 4942: -
- 4943: [DAB - 25.05.04] - CN3 consider this work to be complete
- 4944: TISPAN issue is open
- 4945: -
- 4946: Acronym changed from "SEC1-LI, Rel6"
- 4947: -
- 4948: SP#26 12/2004 completed
- 4949: -
- 4950: -

| ID | WBS | Task | Type | Duration | Start | Finish | Complete | Baseline start | Baseline finish | Baseline duration | Constraint | Resources | Work | Actual work | Acronym | WI rapporteur name | WI rapporteur e-mail | Release | MCC resp | Acronym_3GU_Export | Impacted TSs and TRs | Created at | TSG stopped |
| --- | --- | --- | --- | --- | --- | --- | --- | --- | --- | --- | --- | --- | --- | --- | --- | --- | --- | --- | --- | --- | --- | --- | --- |
| 4951 | 1345 | **3GPP Enablers for services like Push to Talk over Cellular (PoC)** |  | 459d? | 2003-09-08 A | 2005-06-09 A | 100% | 2003-09-08 | 2005-06-09 | 459d? |  | S2; S4; S5 | 18040h | 18040h | PoC | Ericsson | Shabnam Sultana | Rel-6 | Maurice | PoC |  |  |  |
| 4952 | 1345.1 | Feasibility Study on 3GPP Enablers for services like Push to Talk over Cellular (PoC) |  | 322d? | 2003-09-08 A | 2004-11-30 A | 100% | 2003-09-08 | 2004-11-30 | 322d? | finish no earlier than 2004-11-30 | S2 | 2576h | 2576h |  | Ericsson | Shabnam Sultana | Rel-6 | Maurice |  | 23.979 | SP-24 |  |
| 4953 | 1345.2 | Dependencies on OMA PoC |  | 303d? | 2004-01-01 A | 2005-02-28 A | 100% | 2004-01-01 | 2005-02-28 | 303d? | finish no earlier than 2004-12-30 | OMA | 2424h | 2424h |  |  | OMA-LIAISON@mail.openmobilealliance.org | Rel-6 |  |  |  | SP-24 |  |
| 4954 | 1345.3 | Selection of one or more PoC codec(s) for PoC |  | 69d? | 2004-09-13 A | 2004-12-16 A | 100% | 2004-09-13 | 2004-12-16 | 69d? | start no earlier than 2004-09-13 | S4 | 552h | 552h |  |  |  | Rel-6 | Paolo |  | 26.235, 26.236 | SP-25 |  |
| 4955 | 1345.4 | PoC charging |  | 184d? | 2004-09-27 A | 2005-06-09 A | 100% | 2004-09-27 | 2005-06-09 | 184d? | finish no earlier than 2005-06-09 | S5 | 1472h | 1472h | PoC-CH | Siemens | Gerald.Goermer@nsn.com | Rel-6 | Mirko | PoC-CH | 32.272 |  |  |
| 4956 | 1346 | Study on Interworking aspects and migration scenarios for IPv4 based IMS Implementations |  | 210d? | 2003-09-08 A | 2004-06-25 A | 100% | 2003-09-08 | 2004-06-25 | 210d? | finish no earlier than 2004-06-25 | S2 | 1680h | 1680h | IPv4IMS | Siemens | Alexander Milinski | Rel-6 | Maurice | IPv4IMS | 23.981 |  |  |
| 4957 | 16.3 | **Interoperability and Commonality between IMS using different IP-connectivity Networks** |  | 325d? | 2002-09-16 A | 2003-12-12 A | 100% | 2002-09-16 | 2003-12-12 | 325d? |  | S2 | 9176h | 9176h | IMSCOOP |  |  | Rel-6 | Maurice | IMSCOOP | 23.864 |  |  |
| 4958 | 16.3.1 | Stage 2 for Interoperability |  | 272d | 2002-09-16 A | 2003-09-30 A | 100% | 2002-09-16 | 2003-09-30 | 272d | finish no earlier than 2003-09-30 | S2 | 2176h | 2176h |  | Nokia | balazs.bertenyi@nsn.com | Rel-6 | Maurice |  | 23.864 |  |  |
| 4959 | 1347.2 | Stage 2 for commonality |  | 265d? | 2002-09-16 A | 2003-09-19 A | 100% | 2002-09-16 | 2003-09-19 | 265d? | start no earlier than 2002-09-16 | S2 | 2120h | 2120h |  | Nokia | balazs.bertenyi@nsn.com | Rel-6 | Maurice |  | 23.864 |  |  |
| 4960 | 16.3.2 | Stage 3 for Interoperability and Commonality between IMS using different IP-connectivity Networks |  | 305d | 2002-10-14 A | 2003-12-12 A | 100% | 2002-10-14 | 2003-12-12 | 305d | finish no earlier than 2003-12-12 | N1 | 2440h | 2440h |  | Lucent | Keith Drage (drage@alcatel-lucent.com) | Rel-6 | Frederic |  |  |  |  |
| 4961 | 17 | **Support of Push Services** |  | 823d | 2001-01-03 A | 2004-02-27 A | 100% | 2001-01-03 | 2004-02-27 | 823d |  | S1 | 11390.6h | 11390.6h | PUSH | NTT Comware | Yoshinori Kitada | Rel-6 | Alain | PUSH | 23.976 |  |  |
| 4962 | 17.1 | Stage 1 for Support of Push Services |  | 378d | 2001-01-03 A | 2002-06-14 A | 100% | 2001-01-03 | 2002-06-14 | 378d | finish no earlier than 2002-06-14 | S1 | 3024h | 3024h |  |  |  | Rel-6 | Alain |  |  |  |  |
| 4963 | 17.3 | TR 23.976 on Push Architecture |  | 340d | 2002-11-11 A | 2004-02-27 A | 100% | 2002-11-11 | 2004-02-27 | 340d | finish no earlier than 2004-02-27 | S2 | 2720h | 2720h |  | Research In Motion | Nick Alfano | Rel-6 | Maurice |  | 23.976 |  |  |
| 4964 | 18 | **Rel-6 Multimedia Messaging (MMS) enhancements** |  | 865d? | 2002-08-15 A | 2005-12-07 A | 100% | 2002-08-15 | 2005-12-07 | 865d? |  | T2; S1; S4; S5; OMA | 59616h | 59616h | MMS6 | Siemens | Josef.Laumen@SAL.SIEMENS.DE | Rel-6 | Kimmo | MMS6 |  |  |  |
| 4965 | 18.1 | **Definition of service requirements for MMS6** |  | 286d? | 2002-11-15 A | 2003-12-19 A | 100% | 2002-11-15 | 2003-12-19 | 286d? |  | S1 | 4576h | 4576h | MMS6-SR |  |  | Rel-6 | Alain | MMS6-SR | 22.140 |  |  |
| 4966 | 1349.1.1 | Definition of service requirements charging |  | 286d? | 2002-11-15 A | 2003-12-19 A | 100% | 2002-11-15 | 2003-12-19 | 286d? | finish no earlier than 2003-12-20 | S1 | 2288h | 2288h |  | Siemens | Josef.Laumen@SAL.SIEMENS.DE | Rel-6 | Alain |  | 22.140 |  |  |
| 4967 | 18.2 | Technical realization of MMS6 |  | 591d | 2002-09-06 A | 2004-12-10 A | 100% | 2002-09-06 | 2004-12-10 | 591d | finish no earlier than 2004-12-10 | T2 | 4728h | 4728h |  | Siemens | Josef.Laumen@SAL.SIEMENS.DE | Rel-6 | Kimmo |  | 23.140 |  |  |
| 4968 | 18.3 | OMA dependencies |  | 446d | 2003-08-15 A | 2005-04-29 A | 100% | 2003-08-15 | 2005-04-29 | 446d | finish no earlier than 2004-12-10 | OMA | 3568h | 3568h |  |  |  | Rel-6 | Kimmo |  | OMA specs |  |  |
| 4969 | 18.4 | MMS formats and codecs for MMS6 |  | 865d | 2002-08-15 A | 2005-12-07 A | 100% | 2002-08-15 | 2005-12-07 | 865d | finish no earlier than 2005-12-07 | S4 | 6920h | 6920h | MMS6-Codec | Nokia | roberto.castagno@nokia.com | Rel-6 | Paolo | MMS6-Codec | 26.140, 26.936 |  |  |
| 4970 | 1349.5 | Handling of private addressing schemes in MMS |  | 263d | 2003-12-10 A | 2004-12-10 A | 100% | 2003-12-10 | 2004-12-10 | 263d | finish no earlier than 2004-12-10 | T2 | 2104h | 2104h |  | T-Mobile | Steffen.Habermann@T-MOBILE.DE | Rel-6 | Kimmo |  | 23.140 |  |  |
| 4971 | 1349.6 | MMS charging |  | 390d? | 2003-03-21 A | 2004-09-16 A | 100% | 2003-03-21 | 2004-09-16 | 390d? | start no earlier than 2003-03-21 | S5 | 3120h | 3120h | MMS6-CH |  |  | Rel-6 | Mirko | MMS6-CH | 32.270 |  |  |
| 4972 | 1349.7 | Deleted - FS Multiple MMS Relay/Server Architecture | milestone | 0d | 2004-12-10 A | 2004-12-10 A | 100% | 2004-12-10 | 2004-12-10 | 0d | finish no earlier than 2004-12-10 | T2 |  |  |  | Telefónica Móviles | Juan Gorospe (gorospe_j@tsm.es) | Rel-6 | Kimmo |  | probably Annex to 23.140 |  | TP-26 |
| 4973 | 19 | **Rel-6 MExE enhancements** |  | 326d | 2002-03-08 A | 2003-06-06 A | 100% | 2002-03-08 | 2003-06-06 | 326d |  | T2 | 7328h | 7328h | MEXE6 |  |  | Rel-6 | Kimmo | MEXE6 |  |  |  |
| 4974 | 19.1 | MExE Rel-6 Improvements and Investigations |  | 264d | 2002-03-08 A | 2003-03-12 A | 100% | 2002-03-08 | 2003-03-12 | 264d | finish no earlier than 2003-03-12 | T2 | 2112h | 2112h | MEXE6-ENHANC | TTPCom | Lars Brenk ( (lsb_ttpcom@HOTMAIL.COM) | Rel-6 | Kimmo | MEXE6-ENHANC |  |  |  |
| 4975 | 19.2 | MExE Run-Time Independent Framework Feasibility Study |  | 326d | 2002-03-08 A | 2003-06-06 A | 100% | 2002-03-08 | 2003-06-06 | 326d | finish no earlier than 2003-06-06 | T2 | 2608h | 2608h | MEXE6-RTIF | Nokia Siemens Networks | balazs.bertenyi@nokia.com | Rel-6 | Kimmo | MEXE6-RTIF | 22.857 |  |  |
| 4976 | 21 | Subscription Management |  | 650d | 2002-09-20 A | 2005-03-17 A | 100% | 2002-09-20 | 2005-03-17 | 650d | finish no earlier than 2005-03-17 | S5 | 5200h | 5200h | SuM | T-Mobile | istvan.aba@t-mobile.at | Rel-6 | Mirko | SuM | 32.140/1, 32.171/2/5, 32.803 |  |  |

Notes:
- 4951: -
- 4952: -
- 4953: Updated according to SP-040232
- 4954: Completed
- 4955: SP#28 06/2005 completed
- 4956: -
- 4957: -
- 4958: No contributions assumed that no more will be done in 3GPP hence work may need to be done in 3GPP2
- 4959: -
- 4960: -
- 4961: Changed from FS to actual support of Push
- 4962: -
- 4963: -
- 4964: -
- 4965: -
- 4966: -
- 4967: -
- 4968: -
- 4969: -
- 4970: -
- 4971: SP#25 09/2004 completed
- 4972: originally it was intended to create a FS TR but most likely the work will become an Annex of 23.140
- 4973: -
- 4974: -
- 4975: -
- 4976: SP#27 03/2005 completed

| ID | WBS | Task | Duration | Start | Finish | Complete | Baseline start | Baseline finish | Baseline duration | Constraint | Resources | Work | Actual work | Acronym | WI rapporteur name | WI rapporteur e-mail | Release | MCC resp | Acronym_3GU_Export |
| --- | --- | --- | --- | --- | --- | --- | --- | --- | --- | --- | --- | --- | --- | --- | --- | --- | --- | --- | --- |
| 4977 | 22 | **Presence Capability** | 1233d? | 2001-03-19 A | 2005-12-07 A | 100% | 2001-03-19 | 2005-12-07 | 1233d? |  | S1; S2; S3; S4; N1; N3; N4; OMA | 111784h | 111784h | PRESNC | Motorola | Mark Cataldo | Rel-6 | Alain | PRESNC |
| 4978 | 22.1 | Stage 1 for Presence Capability | 610d | 2001-03-19 A | 2003-07-18 A | 100% | 2001-03-19 | 2003-07-18 | 610d | finish no earlier than 2003-07-18 | S1 | 4880h | 4880h |  | Motorola | Mark Cataldo | Rel-6 | Alain |  |
| 4979 | 22.2 | Stage 2 for Presence Capability | 268d | 2001-09-12 A | 2002-09-20 A | 100% | 2001-09-12 | 2002-09-20 | 268d | finish no earlier than 2002-09-20 | S2 | 2144h | 2144h |  | Nokia | balazs.bertenyi@nsn.com | Rel-6 | Maurice |  |
| 4980 | 22.3 | Stage 3 for Presence Capability | 703d | 2002-04-01 A | 2004-12-08 A | 100% | 2002-04-01 | 2004-12-08 | 703d | finish no earlier than 2004-12-08 | N1; N4 | 11248h | 11248h |  | Lucent | Keith Drage (drage@alcatel-lucent.com) | Rel-6 | Frederic |  |
| 4981 | 1352.4 | Stage 3 (CN3 Part Pk interface) | 770d? | 2002-04-01 A | 2005-03-11 A | 100% | 2002-04-01 | 2005-03-11 | 770d? | finish no earlier than 2005-03-11 | N3 | 6160h | 6160h |  | Lucent | Keith Drage (drage@alcatel-lucent.com) | Rel-6 | Gwiho |  |
| 4982 | 1352.5 | Media Codecs and Formats for IMS Messaging and Presence | 650d? | 2003-06-12 A | 2005-12-07 A | 100% | 2003-06-12 | 2005-12-07 | 650d? | finish no earlier than 2005-12-07 | S4 | 5200h | 5200h | PRESNC-COFIMP | Nokia | harri.honko@nokia.com | Rel-6 | Paolo | PRESNC-COFIMP |
| 4983 | 22.4 | Security aspects of Presence Capability | 79d | 2002-08-26 A | 2002-12-12 A | 100% | 2002-08-26 | 2002-12-12 | 79d | finish no earlier than 2002-12-12 | S3 | 632h | 632h |  | Ericsson | krister.boman@erv.ericsson.se | Rel-6 | Mirko |  |
| 4984 | 1352.7 | SIMPLE Presence | 326d? | 2004-01-01 A | 2005-03-31 A | 100% | 2004-01-01 | 2005-03-31 | 326d? | finish no earlier than 2004-12-30 | OMA | 2608h | 2608h |  |  | OMA-LIAISON@mail.openmobilealliance.org | Rel-6 |  |  |
| 4985 | 25 | **Enhanced A/Gb feasibility study** | 51d? | 2002-08-30 A | 2002-11-08 A | 100% | 2002-08-30 | 2002-11-08 | 51d? |  | GP | 3264h | 3264h | AGbEnFS | Vodafone | jose-luis.carrizo@vodafone.co.uk | Rel-6 | Paolo | AGbEnFS |
| 4986 | 25.1 | **Feasibility study on A/Gb enhancements** | 51d? | 2002-08-30 A | 2002-11-08 A | 100% | 2002-08-30 | 2002-11-08 | 51d? |  | G2 | 2856h | 2856h | AGbEnFS-FS | Vodafone | jose-luis.carrizo@vodafone.co.uk | Rel-6 | Gert | AGbEnFS-FS |
| 4987 | 25.1.1 | Requirements for the support of conversational services | 51d | 2002-08-30 A | 2002-11-08 A | 100% | 2002-08-30 | 2002-11-08 | 51d | finish no earlier than 2002-11-08 | GP | 408h | 408h |  |  |  | Rel-6 | Paolo |  |
| 4988 | 1353.1.2 | Identification of the different building blocks for the provision of conversational services on the existing A/Gb protocol stack | 51d? | 2002-08-30 A | 2002-11-08 A | 100% | 2002-08-30 | 2002-11-08 | 51d? | finish no earlier than 2002-11-08 | GP | 408h | 408h |  |  |  | Rel-6 | Paolo |  |
| 4989 | 1353.1.3 | Outline of impact and feasibility of these building blocks and their different solutions | 51d? | 2002-08-30 A | 2002-11-08 A | 100% | 2002-08-30 | 2002-11-08 | 51d? | finish no earlier than 2002-11-08 | GP | 408h | 408h |  |  |  | Rel-6 | Paolo |  |
| 4990 | 25.1.4 | Impact on 3GPP architecture and requirement to co-ordinatge with other TSGs (CN, SA) | 51d | 2002-08-30 A | 2002-11-08 A | 100% | 2002-08-30 | 2002-11-08 | 51d | finish no earlier than 2002-11-08 | GP | 408h | 408h |  |  |  | Rel-6 | Paolo |  |
| 4991 | 25.1.5 | Standardisation effort | 51d | 2002-08-30 A | 2002-11-08 A | 100% | 2002-08-30 | 2002-11-08 | 51d | finish no earlier than 2002-11-08 | GP | 408h | 408h |  |  |  | Rel-6 | Paolo |  |
| 4992 | 25.1.6 | Dependency to other features of Enhanced A/Gb feasibility study | 51d | 2002-08-30 A | 2002-11-08 A | 100% | 2002-08-30 | 2002-11-08 | 51d | finish no earlier than 2002-11-08 | GP | 408h | 408h |  |  |  | Rel-6 | Paolo |  |
| 4993 | 26 | **Flexible Layer One for GERAN** | 1171d | 2000-01-03 A | 2004-06-25 A | 100% | 2000-01-03 | 2004-06-25 | 1171d |  | GP; S3 | 86648h | 86648h | FLOGER | Nokia | benoist.sebire@nokia.com | Rel-6 | Paolo | FLOGER |
| 4994 | 26.1 | **Realisation of a Flexible Layer One** | 1126d | 2000-01-03 A | 2004-04-23 A | 100% | 2000-01-03 | 2004-04-23 | 1126d |  | GP | 42816h | 42816h | FLOGER-Real | Nokia | benoist.sebire@nokia.com | Rel-6 | Paolo | FLOGER-Real |
| 4995 | 26.1.1 | Technical Report on Realisation of a Flexible Layer One | 471d | 2002-04-19 A | 2004-02-06 A | 100% | 2002-04-19 | 2004-02-06 | 471d | finish no earlier than 2004-02-06 | GP | 3768h | 3768h |  | Nokia | benoist.sebire@nokia.com | Rel-6 | Paolo |  |
| 4996 | 26.1.2 | Architecture in 45.001 and 43.051 | 526d | 2002-04-19 A | 2004-04-23 A | 100% | 2002-04-19 | 2004-04-23 | 526d | finish no earlier than 2004-04-23 | G1 | 4208h | 4208h |  | Nokia | benoist.sebire@nokia.com | Rel-6 | Paolo |  |
| 4997 | 26.1.3 | Multiplexing in 45.002 | 526d | 2002-04-19 A | 2004-04-23 A | 100% | 2002-04-19 | 2004-04-23 | 526d | finish no earlier than 2004-04-23 | G1 | 4208h | 4208h |  | Nokia | benoist.sebire@nokia.com | Rel-6 | Paolo |  |
| 4998 | 26.1.4 | Channel Coding in 45.003 for Realisation of a Flexible Layer One | 526d | 2002-04-19 A | 2004-04-23 A | 100% | 2002-04-19 | 2004-04-23 | 526d | finish no earlier than 2004-04-23 | G1 | 4208h | 4208h |  | Nokia | benoist.sebire@nokia.com | Rel-6 | Paolo |  |
| 4999 | 26.1.5 | Performance Requirements in 45.005 for Realisation of a Flexible Layer One | 1126d | 2000-01-03 A | 2004-04-23 A | 100% | 2000-01-03 | 2004-04-23 | 1126d | finish no earlier than 2004-04-23 | G1 | 9000h | 9000h |  | Nokia | benoist.sebire@nokia.com | Rel-6 | Paolo |  |
| 5000 | 26.1.6 | Radio subsystem link control in 45.008 for Realisation of a Flexible Layer One | 526d | 2002-04-19 A | 2004-04-23 A | 100% | 2002-04-19 | 2004-04-23 | 526d | finish no earlier than 2004-04-23 | G1 | 4208h | 4208h |  | Nokia | benoist.sebire@nokia.com | Rel-6 | Paolo |  |
| 5001 | 26.1.7 | Requirements in 44.004 | 526d | 2002-04-19 A | 2004-04-23 A | 100% | 2002-04-19 | 2004-04-23 | 526d | finish no earlier than 2004-04-23 | G2 | 4208h | 4208h |  | Nokia | benoist.sebire@nokia.com | Rel-6 | Gert |  |

Notes:
- 4977: merged "Presence Service Enhancements" (UID31028, PRES1) to this feature as no answer was provided on why Presence and Presence Encmts had same target completion date
- 4978: TP#16 moved Stage 1 to Rel-6 TS 22.141 (existed already in Rel-5) / Impacted TSs and TRs: 22.141
- 4979: - / Impacted TSs and TRs: 23.002, 24.229, New 23.141
- 4980: Dependency to 2 IETF drafts, no known work at the moment / Impacted TSs and TRs: New N1 (24.141, 24.841), N4 (29.002, 29.228, 29.230, 29.328)
- 4981: - / Impacted TSs and TRs: 29.061, 29.161
- 4982: - / Impacted TSs and TRs: 26.141, 26.936
- 4983: SP#17 approved WID S3-020429
- 4984: SP#24 OMA LS_in update in SP-040232 OMA dependencies on 3GPP deliverables
- 4985: - / Impacted TSs and TRs: None
- 4986: - / Impacted TSs and TRs: None
- 4987: - / Impacted TSs and TRs: None
- 4988: - / Impacted TSs and TRs: None
- 4989: - / Impacted TSs and TRs: None
- 4990: - / Impacted TSs and TRs: None
- 4991: - / Impacted TSs and TRs: None
- 4992: - / Impacted TSs and TRs: None
- 4993: -
- 4994: -
- 4995: -
- 4996: -
- 4997: -
- 4998: -
- 4999: -
- 5000: -
- 5001: -

| ID | WBS | Task | Type | Duration | Start | Finish | Complete | Baseline start | Baseline finish | Baseline duration | Constraint | Resources | Work | Actual work | Acronym | WI rapporteur name | WI rapporteur e-mail | Release | MCC resp | Acronym_3GU_Export | Impacted TSs and TRs | TSG stopped |
| --- | --- | --- | --- | --- | --- | --- | --- | --- | --- | --- | --- | --- | --- | --- | --- | --- | --- | --- | --- | --- | --- | --- |
| 5002 | 26.2 | **Signalling and protocol support for a Flexible Layer One** |  | 571d | 2002-04-19 A | 2004-06-25 A | 100% | 2002-04-19 | 2004-06-25 | 571d |  | G2 | 13704h | 13704h | FLOGER-SigPro | Nokia | benoist.sebire@nokia.com | Rel-6 | Gert | FLOGER-SigPro |  |  |
| 5003 | 26.2.1 | Modifications to RLC/MAC in 44.060 and 44.160 |  | 571d | 2002-04-19 A | 2004-06-25 A | 100% | 2002-04-19 | 2004-06-25 | 571d | finish no earlier than 2004-06-25 | G2 | 4568h | 4568h |  | Nokia | benoist.sebire@nokia.com | Rel-6 | Gert |  |  |  |
| 5004 | 26.2.2 | Modifications to RRC in 44.118 and 44.018 |  | 571d | 2002-04-19 A | 2004-06-25 A | 100% | 2002-04-19 | 2004-06-25 | 571d | finish no earlier than 2004-06-25 | G2 | 4568h | 4568h |  | Nokia | benoist.sebire@nokia.com | Rel-6 | Gert |  |  |  |
| 5005 | 26.3 | **Security for a Flexible Layer One** |  | 356d | 2002-04-19 A | 2003-08-29 A | 100% | 2002-04-19 | 2003-08-29 | 356d |  | S3; G2 | 11392h | 11392h | FLOGER-SecFLO | Nokia | benoist.sebire@nokia.com | Rel-6 | Mirko | FLOGER-SecFLO |  |  |
| 5006 | 26.3.1 | Ciphering in 44.060, 44.160, 44.018, 44.118 |  | 356d | 2002-04-19 A | 2003-08-29 A | 100% | 2002-04-19 | 2003-08-29 | 356d | finish no earlier than 2003-08-29 | S3; G2 | 5696h | 5696h |  | Nokia | benoist.sebire@nokia.com | Rel-6 | Mirko |  | 44.060, 44.160, 44.018, 44.118 |  |
| 5007 | 26.4 | **Deleted - GERAN MS Conformance test for the Flexible Layer One - DELETE** |  | 0d | 2004-02-06 A | 2004-02-06 A | 100% | 2004-02-06 | 2004-02-06 | 0d |  | G4; G5 |  |  | FLOGER-Msconf | Nokia | benoist.sebire@nokia.com | Rel-6 | Paolo | FLOGER-Msconf |  | GP-27 |
| 5008 | 26.4.1 | Deleted at TSG #27 - MS Test in 51.010 | milestone | 0d | 2004-02-06 A | 2004-02-06 A | 100% | 2004-02-06 | 2004-02-06 | 0d | finish no earlier than 2004-02-06 | G4; G5 |  |  |  | Nokia | benoist.sebire@nokia.com | Rel-6 | Paolo |  |  | GP-22 |
| 5009 | 26.5 | **Deleted - GERAN BTS Conformance test for the Flexible Layer One - DELETE** |  | 0d | 2004-02-06 A | 2004-02-06 A | 100% | 2004-02-06 | 2004-02-06 | 0d |  | G3new |  |  | FLOGER-BTSconf | Nokia | benoist.sebire@nokia.com | Rel-6 | Ingbert | FLOGER-BTSconf |  | GP-27 |
| 5010 | 26.5.1 | Deleted at TGS #27 - BTS Test in 51.021 - DELETE | milestone | 0d | 2004-02-06 A | 2004-02-06 A | 100% | 2004-02-06 | 2004-02-06 | 0d | finish no earlier than 2004-02-06 | G3new |  |  |  | Nokia | benoist.sebire@nokia.com | Rel-6 | Ingbert |  |  | GP-22 |
| 5011 | 27 | Uplink TDOA feasibility study |  | 151d | 2001-11-30 A | 2002-06-28 A | 100% | 2001-11-30 | 2002-06-28 | 151d | finish no earlier than 2002-06-28 | GP | 1208h | 1208h | TDOAF | TruePosition | Bob Gross (rlgross@trueposition.com) | Rel-6 | Paolo | TDOAF | 45.811 |  |
| 5012 | 28 | **Multimedia Broadcast and Multicast Service** |  | 1781d? | 2001-05-11 A | 2008-03-07 A | 100% | 2001-05-11 | 2008-03-07 | 1781d? |  | S1; S2; S3; S4; S5; N1; N3; R2; R4; R5; T1; GP; G2; G3new | 391176h | 391176h | MBMS |  |  | Rel-6 | Alain | MBMS |  |  |
| 5013 | 28.1 | Stage 1 for Multimedia Broadcast and Multicast Service |  | 232d | 2001-05-11 A | 2002-04-01 A | 100% | 2001-05-11 | 2002-04-01 | 232d | finish no earlier than 2002-04-01 | S1 | 1856h | 1856h |  |  |  | Rel-6 | Alain |  | 22.146, 22.101 |  |
| 5014 | 28.2 | **Stage 2 for Multimedia Broadcast and Multicast Service** |  | 648d | 2001-09-24 A | 2004-03-17 A | 100% | 2001-09-24 | 2004-03-17 | 648d |  | S2 | 10408h | 10408h |  |  |  | Rel-6 | Maurice |  |  |  |
| 5015 | 28.2.1 | TR on MBMS Architectural Study |  | 240d | 2001-09-24 A | 2002-08-23 A | 100% | 2001-09-24 | 2002-08-23 | 240d | finish no earlier than 2002-08-23 | S2 | 1920h | 1920h |  |  |  | Rel-6 | Maurice |  | 23.846 |  |
| 5016 | 28.2.2 | Stage 2 MBMS Specification Work |  | 413d | 2002-08-19 A | 2004-03-17 A | 100% | 2002-08-19 | 2004-03-17 | 413d | finish no earlier than 2004-03-17 | S2 | 3304h | 3304h |  |  |  | Rel-6 | Maurice |  | 23.246 |  |
| 5017 | 28.4 | Support of the MBMS in CN protocols |  | 647d | 2002-06-18 A | 2004-12-08 A | 100% | 2002-06-18 | 2004-12-08 | 647d | finish no earlier than 2004-12-08 | N1 | 5176h | 5176h |  |  |  | Rel-6 | Frederic |  |  |  |
| 5018 | 1356.4 | Gmb interface for MBMS (CN3 part) |  | 334d | 2003-08-29 A | 2004-12-08 A | 100% | 2003-08-29 | 2004-12-08 | 334d | finish no earlier than 2004-12-08 | N3 | 2672h | 2672h |  |  |  | Rel-6 | Gwiho |  | 29.061 |  |
| 5019 | 28.5 | Security aspects of MBMS |  | 710d | 2002-07-01 A | 2005-03-18 A | 100% | 2002-07-01 | 2005-03-18 | 710d | finish no earlier than 2005-03-18 | S3 | 5680h | 5680h |  |  | adrian.escott@three.co.uk | Rel-6 | Mirko |  | New 33.246 |  |
| 5020 | 1356.6 | MBMS Charging |  | 108d? | 2005-01-11 A | 2005-06-09 A | 100% | 2005-01-11 | 2005-06-09 | 108d? | start no earlier than 2005-01-11 | S5 | 864h | 864h | MBMS-CH |  |  | Rel-6 | Mirko | MBMS-CH | 32.273 |  |
| 5021 | 28.1 | **MBMS User Services** |  | 743d? | 2003-05-13 A | 2006-03-16 A | 100% | 2003-05-13 | 2006-03-16 | 743d? |  | S1; S4 | 19520h | 19520h |  |  |  | Rel-6 | Alain |  |  |  |
| 5022 | 28.1 | Stage 1 for MBMS User Services |  | 233d | 2003-05-13 A | 2004-04-01 A | 100% | 2003-05-13 | 2004-04-01 | 233d | start no earlier than 2003-05-13 | S1 | 1864h | 1864h |  |  |  | Rel-6 | Alain |  | 22.246 |  |
| 5023 | 1356.7.2 | Definition of MBMS user services, media codecs, formats and transport/application protocols using MBMS |  | 721d? | 2003-06-12 A | 2006-03-16 A | 100% | 2003-06-12 | 2006-03-16 | 721d? | finish no earlier than 2006-03-16 | S4 | 5768h | 5768h | MBMS-TSMBMS | Nokia | igor.curcio@nokia.com | Rel-6 | Paolo | MBMS-TSMBMS | 26.346, 26.936, 26.946 |  |
| 5024 | 28.3 | **Introduction of MBMS in RAN** |  | 967d? | 2002-01-01 A | 2005-09-14 A | 100% | 2002-01-01 | 2005-09-14 | 967d? |  | R2; R4 | 23728h | 23728h | MBMS-RAN | Nokia | juho.pirskanen@nokia.com | Rel-6 | Yong-Jun | MBMS-RAN |  |  |
| 5025 | 1356.8.1 | Introduction of MBMS in RAN (physical & upper layers, access network interfaces) |  | 771d? | 2002-01-01 A | 2004-12-14 A | 100% | 2002-01-01 | 2004-12-14 | 771d? | finish no earlier than 2004-12-14 | R2 | 6168h | 6168h |  | Nokia | juho.pirskanen@nokia.com | Rel-6 | Yong-Jun |  | 25.346, 25.304, 25.321, 25.322, 25.323 |  |
| 5026 | 1356.8.2 | UE Performance Requirements for MBMS |  | 261d? | 2004-09-15 A | 2005-09-14 A | 100% | 2004-09-15 | 2005-09-14 | 261d? | finish no earlier than 2005-09-15 | R4 | 2088h | 2088h | MBMS-RAN-RF | Ericsson | Torgny.Palenius@ericsson.com | Rel-6 | Issam | MBMS-RAN-RF | 25.101, 25.133 |  |

Notes:
- 5002: -
- 5003: -
- 5004: -
- 5005: -
- 5006: -
- 5007: -
- 5008: -
- 5009: -
- 5010: -
- 5011: -
- 5012: SP#13 Title renamed
- 5013: -
- 5014: -
- 5015: -
- 5016: -
- 5017: -
- 5018: -
- 5019: SP#17 approved WID S3-020433
- 5020: SP#28 completed
- 5021: -
- 5022: -
- 5023: -
- 5024: -
- 5025: -
- 5026: RP#25 approved WID RP-040370

| ID | WBS | Task | Type | Duration | Start | Finish | Complete | Baseline start | Baseline finish | Baseline duration | Constraint | Deadline | Resources | Work | Actual work | Acronym | Release | MCC resp | Acronym_3GU_Export | Impacted TSs and TRs | WI rapporteur name | WI rapporteur e-mail | Created at | TSG stopped |
| --- | --- | --- | --- | --- | --- | --- | --- | --- | --- | --- | --- | --- | --- | --- | --- | --- | --- | --- | --- | --- | --- | --- | --- | --- |
| 5027 | 1356.9 | **MBMS UE Conformance Testing** |  | 521d? | 2006-03-10 A | 2008-03-07 A | 100% | 2006-03-10 | 2008-03-07 | 521d? |  |  | R5; T1 | 34400h | 34400h | MBMS-UEConTest | Rel-6 | Ingbert | MBMS-UEConTest |  |  |  |  |  |
| 5028 | 16.5.1 | RF/RRM Conformance Test Aspects – MBMS (FDD) |  | 461d | 2006-06-02 A | 2008-03-07 A | 100% | 2006-06-02 | 2008-03-07 | 461d | finish no earlier than 2008-03-07 | 2006-06-02 | R5; T1 | 7376h | 7376h | MBMS-RAN-RF_Test | Rel-6 | Ingbert | MBMS-RAN-RF_Test | 34.108, 34.109, 34.121-1, 34.121-2 | Ericsson | leif.mattisson@ericsson.com | Fri 11/03/05 |  |
| 5029 | 1356.9.2 | Conformance Test Aspects - MBMS for 3.84 Mcps and 7.68 Mcps TDD |  | 318d? | 2006-09-20 A | 2007-12-07 A | 100% | 2006-09-20 | 2007-12-07 | 318d? | finish no earlier than 2007-12-07 |  | R5; T1 | 5088h | 5088h | MBMS-UEConTest_TDH | Rel-6 | Ingbert | MBMS-UEConTest_TDH | 34.108, 34.122, 34.123-1, 34.123-2, 34.123-3 | IPWireless | Timothy Speight (tspeight@ipwireless.com) |  |  |
| 5030 | 1356.9.3 | Signalling Conformance Test Aspects – MBMS for LCR TDD |  | 318d? | 2006-09-20 A | 2007-12-07 A | 100% | 2006-09-20 | 2007-12-07 | 318d? | finish no earlier than 2007-12-07 |  | R5; T1 | 5088h | 5088h | MBMS-UEConTest_SIGTDL | Rel-6 | Ingbert | MBMS-UEConTest_SIGTDL | 34.108, 34.123-1, 34.123-2, 34.123-3 | Datang | zhaojian@datangmobile.cn |  |  |
| 5031 | 1356.9.4 | Conformance Test Aspects – MBMS |  | 396d? | 2006-03-10 A | 2007-09-14 A | 100% | 2006-03-10 | 2007-09-14 | 396d? | finish no earlier than 2007-09-14 |  | R5; T1 | 6336h | 6336h | MBMS_Test | Rel-6 | Ingbert | MBMS_Test | 34.108, 34.123-1, 34.123-2, 34.123-3 | Qualcomm | Shubhang Vora (svora@qualcomm.com) |  |  |
| 5032 | 16.5.1 | Conformance Test Aspects - 1.28 Mcps TDD MBMS RF/RRM |  | 136d | 2007-06-01 A | 2007-12-07 A | 100% | 2007-06-01 | 2007-12-07 | 136d | finish no earlier than 2007-12-07 | 2006-06-02 | R5; T1 | 2176h | 2176h | MBMS-UEConTest_RFTDL | Rel-6 | Ingbert | MBMS-UEConTest_RFTDL | 34.108, 34.109, 34.122 | Datang | chenxiaozhong@datangmobile.cn | Fri 11/03/05 |  |
| 5033 | 28.6 | **Support of MBMS in GERAN** |  | 892d? | 2001-08-30 A | 2005-01-28 A | 100% | 2001-08-30 | 2005-01-28 | 892d? |  |  | GP; G2; G3new | 87400h | 87400h | MBMS-GERAN | Rel-6 | Paolo | MBMS-GERAN |  |  |  |  |  |
| 5034 | 28.6.1 | MBMS Impact on the logical and physical channels |  | 631d | 2002-08-30 A | 2005-01-28 A | 100% | 2002-08-30 | 2005-01-28 | 631d | finish no earlier than 2005-01-28 |  | GP | 5048h | 5048h |  | Rel-6 | Paolo |  |  |  |  |  |  |
| 5035 | 28.6.4 | MBMS Re-synchronisation at cell change |  | 631d | 2002-08-30 A | 2005-01-28 A | 100% | 2002-08-30 | 2005-01-28 | 631d | finish no earlier than 2005-01-28 |  | G2 | 5048h | 5048h |  | Rel-6 | Gert |  |  |  |  |  |  |
| 5036 | 1356.10.3 | Simultaneous support of MBMS services |  | 631d? | 2002-08-30 A | 2005-01-28 A | 100% | 2002-08-30 | 2005-01-28 | 631d? | finish no earlier than 2005-01-28 |  | GP | 5048h | 5048h |  | Rel-6 | Paolo |  |  |  |  |  |  |
| 5037 | 1356.10.4 | Simultaneous support of MBMS and non-MBMS services |  | 892d? | 2001-08-30 A | 2005-01-28 A | 100% | 2001-08-30 | 2005-01-28 | 892d? | finish no earlier than 2005-01-28 |  | GP | 7136h | 7136h |  | Rel-6 | Paolo |  |  |  |  |  |  |
| 5038 | 1356.10.5 | MBMS Resynchronization at cell change |  | 892d? | 2001-08-30 A | 2005-01-28 A | 100% | 2001-08-30 | 2005-01-28 | 892d? | finish no earlier than 2005-01-28 |  | GP | 7136h | 7136h |  | Rel-6 | Paolo |  |  |  |  |  |  |
| 5039 | 28.6.5 | MBMS Decision making process between point-to-point or point-to-multipoint configurations |  | 631d | 2002-08-30 A | 2005-01-28 A | 100% | 2002-08-30 | 2005-01-28 | 631d | finish no earlier than 2005-01-28 |  | GP | 5048h | 5048h |  | Rel-6 | Paolo |  |  |  |  |  |  |
| 5040 | 28.6.6 | MBMS channel allocations procedures to multiple MSs |  | 631d | 2002-08-30 A | 2005-01-28 A | 100% | 2002-08-30 | 2005-01-28 | 631d | finish no earlier than 2005-01-28 |  | GP | 5048h | 5048h |  | Rel-6 | Paolo |  |  |  |  |  |  |
| 5041 | 28.6.7 | MBMS Changes to the Gb interface |  | 631d | 2002-08-30 A | 2005-01-28 A | 100% | 2002-08-30 | 2005-01-28 | 631d | finish no earlier than 2005-01-28 |  | GP | 5048h | 5048h |  | Rel-6 | Paolo |  |  |  |  |  |  |
| 5042 | 28.6.8 | GERAN specific changes to the Iu-ps interface for MBMS |  | 631d | 2002-08-30 A | 2005-01-28 A | 100% | 2002-08-30 | 2005-01-28 | 631d | finish no earlier than 2005-01-28 |  | GP | 5048h | 5048h |  | Rel-6 | Paolo |  |  |  |  |  |  |
| 5043 | 28.6.9 | Interaction between MBMS and Iu-flex |  | 631d | 2002-08-30 A | 2005-01-28 A | 100% | 2002-08-30 | 2005-01-28 | 631d | finish no earlier than 2005-01-28 |  | GP | 5048h | 5048h |  | Rel-6 | Paolo |  |  |  |  |  |  |
| 5044 | 28.6.10 | MBMS Security aspects |  | 631d | 2002-08-30 A | 2005-01-28 A | 100% | 2002-08-30 | 2005-01-28 | 631d | finish no earlier than 2005-01-28 |  | GP | 5048h | 5048h |  | Rel-6 | Paolo |  |  |  |  |  |  |
| 5045 | 1356.10.12 | MBMS-GERAN - MS conformance tests |  | 786d? | 2002-01-25 A | 2005-01-28 A | 100% | 2002-01-25 | 2005-01-28 | 786d? | finish no earlier than 2005-01-28 |  | G3new | 6288h | 6288h |  | Rel-6 | Ingbert |  |  |  |  |  |  |
| 5046 | 1356.10.13 | Deleted - MS conformance tests - G5 | milestone | 0d? | 2003-06-27 A | 2003-06-27 A | 100% | 2003-06-27 | 2003-06-27 | 0d? | start no earlier than 2003-06-27 |  | G5 |  |  |  | Rel-6 | Paolo |  |  |  |  |  | GP-19 |
| 5047 | 29 | **Speech Recognition and Speech Enabled Services** |  | 1105d? | 2001-10-08 A | 2005-12-30 A | 100% | 2001-10-08 | 2005-12-30 | 1105d? |  |  | S1; S2; S4; OMA | 46696h | 46696h | SRSES | Rel-6 | Alain | SRSES |  |  |  |  |  |
| 5048 | 29.1 | Speech Enabled Services Based on Distributed Speech Recognition (DSR) |  | 115d | 2001-10-08 A | 2002-03-15 A | 100% | 2001-10-08 | 2002-03-15 | 115d | finish no earlier than 2002-03-15 |  | S1 | 920h | 920h | DSR | Rel-6 | Alain | DSR | 22.977, 22.941, 23.207, 22.243 | Qualcomm | Dwilliams@qualcomm.com |  |  |
| 5049 | 29.2 | TR on Architectural impacts |  | 212d | 2003-05-12 A | 2004-03-02 A | 100% | 2003-05-12 | 2004-03-02 | 212d | finish no earlier than 2004-03-02 |  | S2 | 1696h | 1696h |  | Rel-6 | Maurice |  | 23.877 |  |  |  |  |
| 5050 | 1357.3 | Codec Work to Support Speech Recognition Framework for Automated Voice Services |  | 568d? | 2002-10-15 A | 2004-12-16 A | 100% | 2002-10-15 | 2004-12-16 | 568d? | finish no earlier than 2004-12-16 |  | S4 | 4544h | 4544h | SRSES-Codec | Rel-6 | Paolo | SRSES-Codec | 26.235, 26.236, 26.243, 26.177, 26.943 | Motorola | David Pearce (bdp003@motorola.com) |  |  |
| 5051 | 1357.4 | Multimodal support |  | 522d? | 2004-01-01 A | 2005-12-30 A | 100% | 2004-01-01 | 2005-12-30 | 522d? | finish no earlier than 2005-06-30 |  | OMA | 4176h | 4176h |  | Rel-6 | Paolo |  |  |  | OMA-LIAISON@mail.openmobilealliance.org | SP-24 |  |
| 5052 | 1357.5 | Deleted - SES codec negotiation at Session Description Protocol (SDP) | milestone | 0d? | 2003-06-04 A | 2003-06-04 A | 100% | 2003-06-04 | 2003-06-04 | 0d? | start no earlier than 2003-06-04 |  | N1 |  |  |  | Rel-6 | Frederic |  |  |  |  |  | NP-23 |

Notes:
- 5027: -
- 5028: -
- 5029: -
- 5030: -
- 5031: -
- 5032: -
- 5033: -
- 5034: -
- 5035: -
- 5036: -
- 5037: -
- 5038: -
- 5039: -
- 5040: -
- 5041: -
- 5042: -
- 5043: -
- 5044: -
- 5045: -
- 5046: -
- 5047: -
- 5048: -
- 5049: -
- 5050: -
- 5051: -
- 5052: Abandoned NP-23

| ID | WBS | Task | Type | Duration | Start | Finish | Complete | Baseline start | Baseline finish | Baseline duration | Constraint | Resources | Work | Actual work | Acronym | Release | MCC resp | Acronym_3GU_Export | WI rapporteur name | WI rapporteur e-mail | Created at | TSG stopped | Special Focus Doc |
| --- | --- | --- | --- | --- | --- | --- | --- | --- | --- | --- | --- | --- | --- | --- | --- | --- | --- | --- | --- | --- | --- | --- | --- |
| 5053 | 30 | **Generic User Profile Rel-6** |  | 889d | 2001-10-08 A | 2005-03-03 A | 100% | 2001-10-08 | 2005-03-03 | 889d |  | S1; S3; N4 | 38519.8h | 38519.8h | GUP | Rel-6 | Alain | GUP |  |  |  |  |  |
| 5054 | 30.1 | Stage 1 - Requirements for Generic User Profile |  | 430d | 2001-10-08 A | 2003-05-30 A | 100% | 2001-10-08 | 2003-05-30 | 430d | finish no earlier than 2002-12-09 | S1 | 3440h | 3440h |  | Rel-6 | Alain |  | T-Mobile | kurt.bischinger@t-mobile.at |  |  |  |
| 5055 | 30.3 | Stage 2 - Architecture |  | 355d | 2002-01-28 A | 2003-06-06 A | 100% | 2002-01-28 | 2003-06-06 | 355d | finish no earlier than 2003-06-06 | S2 | 2840h | 2840h |  | Rel-6 | Maurice |  | Nokia | harri.o.koskinen@nokia.com |  |  |  |
| 5056 | 30.2 | Stage 2 - Data Description Method |  | 586d | 2002-12-05 A | 2005-03-03 A | 100% | 2002-12-05 | 2005-03-03 | 586d | finish no earlier than 2005-03-03 | N4 | 4688h | 4688h |  | Rel-6 | Kimmo |  | T-Mobile | kurt.bischinger@t-mobile.at |  |  |  |
| 5057 | 30.5 | Stage 3 - Network |  | 468.98d | 2003-05-19 A | 2005-03-03 A | 100% | 2003-05-19 | 2005-03-03 | 468.98d | finish no earlier than 2005-03-03 | N4 | 3751.83h | 3751.83h |  | Rel-6 | Kimmo |  |  |  |  |  |  |
| 5058 | 30.6 | Security aspects of GUP |  | 308d | 2002-07-16 A | 2003-09-18 A | 100% | 2002-07-16 | 2003-09-18 | 308d | finish no earlier than 2003-09-18 | S3 | 2464h | 2464h |  | Rel-6 | Mirko |  | Lucent | Bradley Owen (bvowen@lucent.com) |  |  |  |
| 5059 | 31 | **Digital Rights Management** |  | 690d? | 2001-10-08 A | 2004-05-28 A | 100% | 2001-10-08 | 2004-05-28 | 690d? |  | S1; OMA | 15672h | 15672h | DRM | Rel-6 | Alain | DRM |  |  |  |  |  |
| 5060 | 31.1 | Requirements for Digital Rights Management |  | 179d | 2001-10-08 A | 2002-06-13 A | 100% | 2001-10-08 | 2002-06-13 | 179d | finish no earlier than 2002-06-13 | S1 | 1432h | 1432h |  | Rel-6 | Alain |  | Openwave | nicholas.wood@openwave.com |  |  |  |
| 5061 | 1359.2 | Stage 2 for Digital Rights Management |  | 107d? | 2004-01-01 A | 2004-05-28 A | 100% | 2004-01-01 | 2004-05-28 | 107d? | finish no earlier than 2004-05-28 | OMA | 856h | 856h |  | Rel-6 |  |  |  | OMA-LIAISON@mail.openmobilealliance.org | SP-24 |  |  |
| 5062 | 1359.3 | Stage 3 for Digital Rights Management |  | 107d? | 2004-01-01 A | 2004-05-28 A | 100% | 2004-01-01 | 2004-05-28 | 107d? | finish no earlier than 2004-05-28 | OMA | 856h | 856h |  | Rel-6 |  |  |  | OMA-LIAISON@mail.openmobilealliance.org | SP-24 |  |  |
| 5063 | 31.3 | Security for Digital Rights Management |  | 186d | 2002-06-17 A | 2003-03-03 A | 100% | 2002-06-17 | 2003-03-03 | 186d | finish no earlier than 2003-03-03 | OMA | 1488h | 1488h |  | Rel-6 |  |  |  |  |  |  |  |
| 5064 | 1359.5 | Deleted - Monitoring of Stages 2 and 3 progress (actual work to be done by OMA) | milestone | 0d? | 2003-03-21 A | 2003-03-21 A | 100% | 2003-03-21 | 2003-03-21 | 0d? | start no earlier than 2002-08-19 | S1 |  |  |  | Rel-6 | Alain |  |  |  |  | SP-19 |  |
| 5065 | 32 | **WLAN-UMTS Interworking Rel-6** |  | 1495d? | 2000-01-03 A | 2005-09-22 A | 100% | 2000-01-03 | 2005-09-22 | 1495d? |  | S1; S2; S3; S5; N1; N3; N4; T3 | 129192h | 129192h | WLAN | Rel-6 | Alain | WLAN | Telenor | frederic.paint@telenor.com |  |  | WLAN |
| 5066 | 32.1 | Technical Report on WLAN-UMTS Interworking |  | 901d? | 2000-01-03 A | 2003-06-13 A | 100% | 2000-01-03 | 2003-06-13 | 901d? | finish no earlier than 2003-06-13 | S1 | 7200h | 7200h | WLAN-TR | Rel-6 | Alain | WLAN-TR | T-mobile | Mark.Younge@t-mobile.com |  |  | WLAN |
| 5067 | 1360.2 | Stage 1 for WLAN-UMTS Interworking Rel-6 |  | 375d? | 2003-01-06 A | 2004-06-11 A | 100% | 2003-01-06 | 2004-06-11 | 375d? |  | S1 | 920h | 920h | WLAN-TS | Rel-6 | Alain | WLAN-TS | Telenor | frederic.paint@telenor.com | SP-24 |  | WLAN |
| 5068 | 32.2 | Architecture Definition for scenarii 2 and 3 |  | 571d | 2002-03-25 A | 2004-05-31 A | 100% | 2002-03-25 | 2004-05-31 | 571d | finish no earlier than 2004-05-31 | S2 | 4568h | 4568h |  | Rel-6 | Maurice |  |  |  |  |  | WLAN |
| 5069 | 32.3 | Security aspects of WLAN-UMTS Interworking |  | 125d | 2002-09-30 A | 2003-03-21 A | 100% | 2002-09-30 | 2003-03-21 | 125d | finish no earlier than 2003-03-21 | S3 | 1000h | 1000h |  | Rel-6 | Mirko |  | Ericsson, BT | luis.lopez-soria@ece.ericsson.se, colin.blanchard@bt.com |  |  | WLAN |
| 5070 | 1360.5 | Stage 3 - CN4 aspects |  | 334d? | 2003-05-23 A | 2004-09-01 A | 100% | 2003-05-23 | 2004-09-01 | 334d? | finish no earlier than 2004-09-01 | N4 | 2672h | 2672h | WLAN-IW | Rel-6 | Kimmo | WLAN-IW | Nokia | raquel.rodriguez@nokia.com |  |  | WLAN |
| 5071 | 1360.6 | Stage 3 - CN3 aspects (Wi Interface for Scenario 3) |  | 355d? | 2003-05-23 A | 2004-09-30 A | 100% | 2003-05-23 | 2004-09-30 | 355d? | start no earlier than 2003-05-23 | N3 | 2840h | 2840h |  | Rel-6 | Gwiho |  |  |  | SP-24 |  | WLAN |
| 5072 | 1360.7 | Stage 3 for scenario 2 |  | 339d? | 2003-05-23 A | 2004-09-08 A | 100% | 2003-05-23 | 2004-09-08 | 339d? | finish no earlier than 2004-09-08 | N1 | 2712h | 2712h |  | Rel-6 | Frederic |  |  |  |  |  | WLAN |
| 5073 | 1360.8 | Stage 3 for scenario 3 |  | 404d? | 2003-05-23 A | 2004-12-08 A | 100% | 2003-05-23 | 2004-12-08 | 404d? | finish no earlier than 2004-12-08 | N1 | 3232h | 3232h |  | Rel-6 | Frederic |  |  |  | SP-24 |  | WLAN |
| 5074 | 1360.9 | WLAN charging |  | 655d? | 2003-03-21 A | 2005-09-22 A | 100% | 2003-03-21 | 2005-09-22 | 655d? | finish no earlier than 2005-09-22 | S5 | 5240h | 5240h | WLAN-CH | Rel-6 | Mirko | WLAN-CH | Nokia | Benni ALEXANDER |  |  | WLAN |
| 5075 | 1360.10 | USIM enhancements for WLAN Interworking |  | 391d? | 2003-09-05 A | 2005-03-04 A | 100% | 2003-09-05 | 2005-03-04 | 391d? | finish no earlier than 2005-03-04 | T3 | 3128h | 3128h |  | Rel-6 | Xavier |  | Axalto | Jabellan@axalto.com |  |  | WLAN |
| 5076 | 33 | **Priority Service** |  | 347d? | 2002-05-30 A | 2003-09-26 A | 100% | 2002-05-30 | 2003-09-26 | 347d? |  | S1 | 6464h | 6464h | PRIOR1 | Rel-6 | Alain | PRIOR1 | Telcordia | James Garrahan (jgarraha@telcordia.com) |  |  | Public Safety (I-A) |
| 5077 | 33.1 | Feasibility Study on Priority Service |  | 1d | 2002-06-14 A | 2002-06-14 A | 100% | 2002-06-14 | 2002-06-14 | 1d | finish no earlier than 2002-06-14 | S1 | 8h | 8h | PRIOR-FS | Rel-6 | Alain | PRIOR-FS | Telcordia | James Garrahan (jgarraha@telcordia.com) |  |  | Public Safety (I-A) |
| 5078 | 33.2 | Stage 1 - Requirements for Priority Service |  | 340d | 2002-05-30 A | 2003-09-17 A | 100% | 2002-05-30 | 2003-09-17 | 340d | finish no earlier than 2003-09-17 | S1 | 2720h | 2720h | PRIOR-SR | Rel-6 | Alain | PRIOR-SR | Telcordia | James Garrahan (jgarraha@telcordia.com) |  |  | Public Safety (I-A) |
| 5079 | 1361.3 | Priority service implementation guide |  | 131d? | 2003-03-28 A | 2003-09-26 A | 100% | 2003-03-28 | 2003-09-26 | 131d? | finish no earlier than 2003-09-26 | S1 | 1048h | 1048h |  | Rel-6 | Alain |  | Telcordia | James Garrahan (jgarraha@telcordia.com) |  |  | Public Safety (I-A) |

Notes:
- 5053: -
- 5054: - / Impacted TSs and TRs: 22.240, 22.228
- 5055: - / Impacted TSs and TRs: 23.240
- 5056: TR approved in CN#26 / Impacted TSs and TRs: 23.241
- 5057: - / Impacted TSs and TRs: 29.240
- 5058: SP#19 approved WID / Impacted TSs and TRs: 33.102, 33.203, 33.210
- 5059: Foreseen start and completion dates introduced by MCC (no indication at all on the WID)
- 5060: -
- 5061: -
- 5062: -
- 5063: SA3 acknowledge role in WI at SA3#20. Active contribution S3#24, S3#25. S3 WID approved SP#17
- 5064: Replaced by UID 60005 and 60006
- 5065: -
- 5066: - / Impacted TSs and TRs: 22.934
- 5067: - / Impacted TSs and TRs: 22.101, 22.105
- 5068: - / Impacted TSs and TRs: 23.234
- 5069: SP#17 approved WID S3-020451 / Impacted TSs and TRs: 21.133, 33.106, 33.107, 33.108, 33.200, 33.203, 33.210, New 33.234
- 5070: WID approved at CN#19 / Impacted TSs and TRs: 29.234, 29.061
- 5071: - / Impacted TSs and TRs: 29.161
- 5072: -
- 5073: -
- 5074: - / Impacted TSs and TRs: 32.252
- 5075: - / Impacted TSs and TRs: 31.102
- 5076: -
- 5077: - / Impacted TSs and TRs: 22.950
- 5078: -
- 5079: - / Impacted TSs and TRs: 22.952

| ID | WBS | Task | Type | Duration | Start | Finish | Complete | Baseline start | Baseline finish | Baseline duration | Constraint | Deadline | Resources | Work | Actual work | Acronym | WI rapporteur name | WI rapporteur e-mail | Release | MCC resp | Acronym_3GU_Export | Created at | TSG stopped |
| --- | --- | --- | --- | --- | --- | --- | --- | --- | --- | --- | --- | --- | --- | --- | --- | --- | --- | --- | --- | --- | --- | --- | --- |
| 5080 | 34 | **Network Sharing** |  | 820d? | 2003-01-20 A | 2006-03-10 A | 100% | 2003-01-20 | 2006-03-10 | 820d? |  |  | S1; S2; N1; R2; R5 | 44936h | 44936h | NTShar | T-Mobile | michele.zarri@t-mobile.co.uk | Rel-6 | Alain | NTShar |  |  |
| 5081 | 34.1 | Technical Report on Network Sharing |  | 240d? | 2003-01-20 A | 2003-12-19 A | 100% | 2003-01-20 | 2003-12-19 | 240d? |  |  | S1 | 1920h | 1920h | NTShar-TR | T-Mobile | michele.zarri@t-mobile.co.uk | Rel-6 | Alain | NTShar-TR |  |  |
| 5082 | 1362.2 | Stage 1 - CRs to implement Network Sharing |  | 240d? | 2003-01-20 A | 2003-12-19 A | 100% | 2003-01-20 | 2003-12-19 | 240d? | finish no earlier than 2003-12-19 |  | S1 | 1920h | 1920h | NTSharCR | T-Mobile | michele.zarri@t-mobile.co.uk | Rel-6 | Alain | NTSharCR |  |  |
| 5083 | 1362.3 | Stage 2 for Network Sharing |  | 372d? | 2003-02-27 A | 2004-07-30 A | 100% | 2003-02-27 | 2004-07-30 | 372d? | finish no earlier than 2004-07-30 |  | S2 | 2976h | 2976h |  | T-Mobile | michele.zarri@t-mobile.co.uk | Rel-6 | Maurice |  |  |  |
| 5084 | 1362.4 | Network sharing - stage 3 |  | 404d? | 2003-05-23 A | 2004-12-08 A | 100% | 2003-05-23 | 2004-12-08 | 404d? | finish no earlier than 2004-12-08 |  | N1 | 3232h | 3232h |  | T-Mobile | michele.zarri@t-mobile.co.uk | Rel-6 | Frederic |  |  |  |
| 5085 | 1362.5 | Enhancement of the support of network sharing in the UTRAN | milestone | 0d | 2003-09-19 A | 2003-09-19 A | 100% | 2003-09-19 | 2003-09-19 | 0d |  |  | R2 |  |  | NTShar-UTRANEnh | TeliaSonera | Anders.Dahlen@TeliaSonera.com | Rel-6 | Yong-Jun | NTShar-UTRANEnh |  |  |
| 5086 | 16.5.1 | Conformance Test Aspects – Network Sharing |  | 261d | 2005-03-11 A | 2006-03-10 A | 100% | 2005-03-11 | 2006-03-10 | 261d | finish no earlier than 2006-03-10 | 2006-03-10 | R5 | 2088h | 2088h | NTShar-UTRANEnh_Test | TeliaSonera | Niklas.Wiren@TeliaSonera.com | Rel-6 | Ingbert | NTShar-UTRANEnh_Test | Fri 11/03/05 |  |
| 5087 | 35 | **QoS Improvements** |  | 628d? | 2002-07-15 A | 2004-12-08 A | 100% | 2002-07-15 | 2004-12-08 | 628d? |  |  | S2; N3 | 18152h | 18152h | QoS1 | Nokia |  | Rel-6 | Maurice | QoS1 |  |  |
| 5088 | 35.1 | FS on Dynamic Policy control enhancements for end-to-end QoS |  | 465d | 2002-07-15 A | 2004-04-23 A | 100% | 2002-07-15 | 2004-04-23 | 465d | finish no earlier than 2004-04-23 |  | S2 | 3720h | 3720h |  | Nortel | Claire Mousset | Rel-6 | Maurice |  |  |  |
| 5089 | 1363.2 | Definition of the Gq interface |  | 214d? | 2003-07-01 A | 2004-04-23 A | 100% | 2003-07-01 | 2004-04-23 | 214d? | finish no earlier than 2004-04-23 |  | S2 | 1712h | 1712h |  |  | Janne Rinne | Rel-6 | Maurice |  |  |  |
| 5090 | 1363.3 | Gq interface specification for Dynamic Policy control enhancements – Stage 3 |  | 334d | 2003-08-29 A | 2004-12-08 A | 100% | 2003-08-29 | 2004-12-08 | 334d | finish no earlier than 2004-12-08 |  | N3 | 2672h | 2672h |  | Nokia | Anna.Sillanpaai@nokia.com | Rel-6 | Gwiho |  |  |  |
| 5091 | 36 | **Subscriber certificates** |  | 728d? | 2002-02-25 A | 2004-12-08 A | 100% | 2002-02-25 | 2004-12-08 | 728d? |  |  | S3; S2; N1; N4; T3; OMA | 44512h | 44512h | SEC1-SC | Nokia | valtteri.niemi@nokia.com | Rel-6 | Mirko | SEC1-SC |  |  |
| 5092 | 36.1 | Stage 1 of Subscriber certificates |  | 144d | 2002-02-25 A | 2002-09-12 A | 100% | 2002-02-25 | 2002-09-12 | 144d | finish no earlier than 2002-09-12 |  | S3 | 1152h | 1152h |  | Nokia | valtteri.niemi@nokia.com | Rel-6 | Mirko |  |  |  |
| 5093 | 36.2 | Architecture review |  | 24d | 2002-10-14 A | 2002-11-14 A | 100% | 2002-10-14 | 2002-11-14 | 24d | finish no earlier than 2002-11-14 |  | S2 | 192h | 192h |  | Nokia |  | Rel-6 | Maurice |  |  |  |
| 5094 | 1364.3 | Stage 3 for Subscriber certificates |  | 313d? | 2003-09-19 A | 2004-11-30 A | 100% | 2003-09-19 | 2004-11-30 | 313d? | finish no earlier than 2004-11-30 |  | N4; T3 | 5008h | 5008h |  | Nokia | Lauri Laitinen | Rel-6 | Kimmo |  |  |  |
| 5095 | 1364.4 | Stage 3 Ua & Ub interfaces |  | 288d? | 2003-11-03 A | 2004-12-08 A | 100% | 2003-11-03 | 2004-12-08 | 288d? | finish no earlier than 2004-12-08 |  | N1 | 2304h | 2304h |  | Nokia |  | Rel-6 | Frederic |  |  |  |
| 5096 | 1364.5 | OMA dependencies on Subscriber certificates |  | 114d? | 2004-01-01 A | 2004-06-08 A | 100% | 2004-01-01 | 2004-06-08 | 114d? | finish no earlier than 2004-06-08 |  | OMA | 912h | 912h |  | Nokia | OMA-LIAISON@mail.openmobilealliance.org | Rel-6 |  |  | SP-24 |  |
| 5097 | 1365 | **Rel-6 Open Service Access (OSA) enhancements** |  | 616d? | 2002-10-31 A | 2005-03-10 A | 100% | 2002-10-31 | 2005-03-10 | 616d? |  |  | N5 | 22576h | 22576h | OSA3 | Alcatel | Chelo.Abarca@alcatel.fr | Rel-6 | Kimmo | OSA3 |  |  |
| 5098 | 1365.1 | Scope of the Open Service Access Release 6 |  | 66d? | 2003-03-28 A | 2003-06-27 A | 100% | 2003-03-28 | 2003-06-27 | 66d? | finish no earlier than 2003-06-27 |  | S1 | 528h | 528h |  |  |  | Rel-6 | Alain |  |  |  |
| 5099 | 1365.2 | OSA Stage 2 |  | 150d? | 2004-08-13 A | 2005-03-10 A | 100% | 2004-08-13 | 2005-03-10 | 150d? | finish no earlier than 2005-03-10 |  | N5 | 1200h | 1200h |  |  |  | Rel-6 | Kimmo |  |  |  |
| 5100 | 1365.3 | Multi Media Messaging function |  | 487d? | 2002-10-31 A | 2004-09-10 A | 100% | 2002-10-31 | 2004-09-10 | 487d? | finish no earlier than 2004-09-10 |  | N5 | 3896h | 3896h |  |  |  | Rel-6 | Kimmo |  |  |  |
| 5101 | 1365.4 | Policy management extensions |  | 292d? | 2002-10-31 A | 2003-12-12 A | 100% | 2002-10-31 | 2003-12-12 | 292d? | finish no earlier than 2003-12-12 |  | N5 | 2336h | 2336h |  |  |  | Rel-6 | Kimmo |  |  |  |
| 5102 | 1365.5 | TS on Presence and Availability Management (from the PRESNC WI) |  | 367d? | 2002-10-31 A | 2004-03-26 A | 100% | 2002-10-31 | 2004-03-26 | 367d? | finish no earlier than 2004-03-26 |  | N5 | 2936h | 2936h |  |  |  | Rel-6 | Kimmo |  |  |  |
| 5103 | 1365.6 | OSA interfaces at different levels of abstractions (Parlay X, Web services) |  | 305d? | 2003-07-14 A | 2004-09-10 A | 100% | 2003-07-14 | 2004-09-10 | 305d? | finish no earlier than 2004-09-10 |  | N5 | 2440h | 2440h |  |  |  | Rel-6 | Kimmo |  |  |  |
| 5104 | 1365.7 | Introduction of migration support mechanism |  | 290d? | 2002-10-31 A | 2003-12-10 A | 100% | 2002-10-31 | 2003-12-10 | 290d? | finish no earlier than 2003-12-12 |  | N5 | 2320h | 2320h |  |  |  | Rel-6 | Kimmo |  |  |  |
| 5105 | 1365.8 | Framework Function for Federation |  | 225d? | 2003-02-03 A | 2003-12-12 A | 100% | 2003-02-03 | 2003-12-12 | 225d? | finish no earlier than 2003-12-12 |  | N5 | 1800h | 1800h |  |  |  | Rel-6 | Kimmo |  |  |  |
| 5106 | 1365.9 | OMA potential overlaps with 3GPP OSA Stage 3 (Web services) |  | 196d? | 2003-12-18 A | 2004-09-16 A | 100% | 2003-12-18 | 2004-09-16 | 196d? | start no earlier than 2003-12-18 |  | OMA | 1568h | 1568h |  |  |  | Rel-6 |  |  | SP-24 |  |
| 5107 | 1365.10 | Deleted - TR on Presence and Availability Management (from the PRESNC WI) | milestone | 0d? | 2004-09-17 A | 2004-09-17 A | 100% | 2004-09-17 | 2004-09-17 | 0d? | start no earlier than 2004-09-17 |  | N5 |  |  |  |  |  | Rel-6 | Kimmo |  |  | NP-24 |

Notes:
- 5080: -
- 5081: - / Impacted TSs and TRs: 22.951
- 5082: - / Impacted TSs and TRs: 22.011, 22.101, 22.115, 22.129
- 5083: - / Impacted TSs and TRs: 23.002, 23.060, 23.221, 23.236, new TS 23.251, TR 23.851
- 5084: - / Impacted TSs and TRs: 23.008, 23.122, 24.007, 24.008, 29.018
- 5085: - / Impacted TSs and TRs: 25.401, 25.413, 25.331, 25.304
- 5086: - / Impacted TSs and TRs: 34.108, 34.123-1, 34.123-2, 34.123-3
- 5087: - / Impacted TSs and TRs: 23.107, 23.207, 23.221
- 5088: - / Impacted TSs and TRs: 23.917 withdrawn (Contents all in 23.207)
- 5089: - / Impacted TSs and TRs: 23.207
- 5090: [DAB - 25.05.04] - Delayed to Sept - possibly Dec 2004 / Impacted TSs and TRs: 29.207, 29.208, 29.209
- 5091: SP#14 approved WID
- 5092: - / Impacted TSs and TRs: New (33.220, 33.221, 33.222, 33.246, 33.919)
- 5093: -
- 5094: Finished in CN4#26 / Impacted TSs and TRs: 23.003, 23.008, 29.109, 29.230, T3 31.102, 31.103, 31.111
- 5095: - / Impacted TSs and TRs: 24.109
- 5096: Updated according to SP-040420
- 5097: CN#25: Updated WID NP-040351 replaces NP-040144. / Impacted TSs and TRs: 22.127, 23.198, 29.198, 29.199, 29.998
- 5098: -
- 5099: Inherited by CN5 from SA2 at TSG#25 Sep 2004. SA2's 23.127 (OSA/VHE Stage 2) replaced from Rel-6 onwards by a new CN5 TS 23.198 (Stage 2 OSA-only). / Impacted TSs and TRs: 23.198 OSA Stage 2-ONLY replaces 23.127 (OSA/VHE) from Rel-6 onwards
- 5100: - / Impacted TSs and TRs: 29.198-15
- 5101: - / Impacted TSs and TRs: 29.198, 29.998
- 5102: N5#26: Split WI into TS & TR. / Impacted TSs and TRs: 29.198-14
- 5103: - / Impacted TSs and TRs: 29.199
- 5104: - / Impacted TSs and TRs: 29.198, 29.998
- 5105: - / Impacted TSs and TRs: 29.198, 29.998
- 5106: TSG#25 Approved CN5 29.199 Parlay X Web services. Ongoing 3GPP/OMA co-ordination to avoid OMA producing conflicting/OVERLAPING specs (NP-040283/SP-040493).
- 5107: N5#26:TR Completion 09/04; consistent with CN1 delayed Rel-6 completion.

| ID | WBS | Task | Duration | Start | Finish | Complete | Baseline start | Baseline finish | Baseline duration | Constraint | Resources | Work | Actual work | Acronym | WI rapporteur name | WI rapporteur e-mail | Release | MCC resp | Acronym_3GU_Export | TSG stopped |
| --- | --- | --- | --- | --- | --- | --- | --- | --- | --- | --- | --- | --- | --- | --- | --- | --- | --- | --- | --- | --- |
| 5108 | 39 | **Addition of frequency bands to GSM (TAPS)** | 676d | 2002-06-28 A | 2005-01-28 A | 100% | 2002-06-28 | 2005-01-28 | 676d |  | GP | 16640h | 16640h | TAPS | Nokia | Torben Themsen | Rel-6 | Paolo | TAPS |  |
| 5109 | 39.1 | **Addition of frequency bands to GSM – Changes to core specs** | 26d | 2002-11-15 A | 2002-12-20 A | 100% | 2002-11-15 | 2002-12-20 | 26d |  | G1 | 416h | 416h | TAPS-Specs | Nokia | Torben Themsen | Rel-6 | Paolo | TAPS-Specs |  |
| 5110 | 39.1.1 | Changes to core specs | 26d | 2002-11-15 A | 2002-12-20 A | 100% | 2002-11-15 | 2002-12-20 | 26d | finish no earlier than 2002-12-20 | G1 | 208h | 208h |  | Nokia | Torben Themsen | Rel-6 | Paolo |  |  |
| 5111 | 39.2 | **Deleted - Addition of frequency bands to GSM – Changes for conformance tests** | 676d | 2002-06-28 A | 2005-01-28 A | 100% | 2002-06-28 | 2005-01-28 | 676d |  | G4 | 10816h | 10816h | TAPS-Conf | Nokia | Torben Themsen | Rel-6 | Paolo | TAPS-Conf | GP-23 |
| 5112 | 39.2.1 | Deleted - 51.010-1 Add testing | 676d | 2002-06-28 A | 2005-01-28 A | 100% | 2002-06-28 | 2005-01-28 | 676d | finish no earlier than 2005-01-28 | G4 | 5408h | 5408h |  | Nokia | Torben Themsen | Rel-6 | Paolo |  | GP-23 |
| 5113 | 40 | **Seamless support of streaming services in A/Gb mode** | 1426d? | 2000-01-03 A | 2005-06-17 A | 100% | 2000-01-03 | 2005-06-17 | 1426d? |  | GP; S3 | 70312h | 70312h | SSStrea | Vodafone | José Luis Carrizo Martínez | Rel-6 | Paolo | SSStrea |  |
| 5114 | 40.1 | **Identification of requirements for streaming** | 46d? | 2003-06-27 A | 2003-08-29 A | 100% | 2003-06-27 | 2003-08-29 | 46d? |  | G1 | 736h | 736h |  | Vodafone | José Luis Carrizo Martínez | Rel-6 | Paolo |  |  |
| 5115 | 1367.1.1 | Requirements for streaming | 46d? | 2003-06-27 A | 2003-08-29 A | 100% | 2003-06-27 | 2003-08-29 | 46d? | finish no earlier than 2003-08-29 | G1 | 368h | 368h |  | Vodafone | José Luis Carrizo Martínez | Rel-6 | Paolo |  |  |
| 5116 | 40.2 | **Performance study of cell change mechanisms** | 956d? | 2000-01-03 A | 2003-08-29 A | 100% | 2000-01-03 | 2003-08-29 | 956d? |  | G1 | 30568h | 30568h |  | Vodafone | José Luis Carrizo Martínez | Rel-6 | Paolo |  |  |
| 5117 | 1367.2.1 | Performance of NACC | 956d? | 2000-01-03 A | 2003-08-29 A | 100% | 2000-01-03 | 2003-08-29 | 956d? | finish no earlier than 2003-08-29 | G1 | 7640h | 7640h |  | Vodafone | José Luis Carrizo Martínez | Rel-6 | Paolo |  |  |
| 5118 | 1367.2.2 | Performance of cell change in DTM for the PS domain | 956d? | 2000-01-03 A | 2003-08-29 A | 100% | 2000-01-03 | 2003-08-29 | 956d? | finish no earlier than 2003-08-29 | G1 | 7640h | 7640h |  | Vodafone | José Luis Carrizo Martínez | Rel-6 | Paolo |  |  |
| 5119 | 1367.2.3 | Handover for Seamless support of streaming services in A/Gb mode | 956d? | 2000-01-03 A | 2003-08-29 A | 100% | 2000-01-03 | 2003-08-29 | 956d? | finish no earlier than 2003-08-29 | G1 | 7640h | 7640h |  | Vodafone | José Luis Carrizo Martínez | Rel-6 | Paolo |  |  |
| 5120 | 40.3 | **Reduction of service interruption times and packet loss during mobility procedures** | 516d? | 2003-06-27 A | 2005-06-17 A | 100% | 2003-06-27 | 2005-06-17 | 516d? |  | G2 | 10800h | 10800h |  | Vodafone | José Luis Carrizo Martínez | Rel-6 | Gert |  |  |
| 5121 | 1367.3.1 | optimizations of existing mechanisms/procedures | 106d? | 2003-06-27 A | 2003-11-21 A | 100% | 2003-06-27 | 2003-11-21 | 106d? | finish no earlier than 2003-11-21 | G2 | 848h | 848h |  | Vodafone | José Luis Carrizo Martínez | Rel-6 | Gert |  |  |
| 5122 | 1367.3.2 | Inter-system NACC | 106d? | 2003-06-27 A | 2003-11-21 A | 100% | 2003-06-27 | 2003-11-21 | 106d? | finish no earlier than 2003-11-21 | G2 | 848h | 848h |  | Vodafone | José Luis Carrizo Martínez | Rel-6 | Gert |  |  |
| 5123 | 1367.3.3 | PS Handover (within GERAN and between GERAN and UTRAN) | 516d? | 2003-06-27 A | 2005-06-17 A | 100% | 2003-06-27 | 2005-06-17 | 516d? | finish no earlier than 2003-11-21 | G2 | 4128h | 4128h |  | Vodafone | José Luis Carrizo Martínez | Rel-6 | Gert |  |  |
| 5124 | 1367.3.4 | Dependency to other features of Reduction of service interruption times and packet loss during mobility procedures | 106d? | 2003-06-27 A | 2003-11-21 A | 100% | 2003-06-27 | 2003-11-21 | 106d? | finish no earlier than 2003-11-21 | G2 | 848h | 848h |  | Vodafone | José Luis Carrizo Martínez | Rel-6 | Gert |  |  |
| 5125 | 40.5 | **Deleted - MS conformance testing for Seamless support of streaming services in A/Gb mode** | 31d? | 2003-12-19 A | 2004-01-30 A | 100% | 2003-12-19 | 2004-01-30 | 31d? |  | G3new | 496h | 496h |  | Vodafone | José Luis Carrizo Martínez | Rel-6 | Ingbert |  | GP-27 |
| 5126 | 1367.4.1 | Deleted - MS conformance tests for Seamless support of streaming services in A/Gb mode | 31d? | 2003-12-19 A | 2004-01-30 A | 100% | 2003-12-19 | 2004-01-30 | 31d? | finish no earlier than 2004-01-30 | G4; G5 | 496h | 496h |  | Vodafone | José Luis Carrizo Martínez | Rel-6 | Ingbert |  | GP-27 |
| 5127 | 1367.5 | GERAN A/Gb mode security enhancements | 612d? | 2002-09-26 A | 2005-01-28 A | 100% | 2002-09-26 | 2005-01-28 | 612d? | finish no earlier than 2005-01-28 | S3 | 4896h | 4896h |  | Vodafone | peter.howard@vodafone.com | Rel-6 | Mirko |  |  |
| 5128 | 41 | Performance characterisation of default codecs for PS conversational multimedia application | 455d | 2002-09-13 A | 2004-06-10 A | 100% | 2002-09-13 | 2004-06-10 | 455d | finish no earlier than 2004-06-10 | S4 | 3640h | 3640h | CODCAR | Nokia | pasi.s.ojala@nokia.com | Rel-6 | Paolo | CODCAR |  |
| 5129 | 43 | Study on Privacy Capability | 83d | 2003-11-10 A | 2004-03-03 A | 100% | 2003-11-10 | 2004-03-03 | 83d | start no earlier than 2003-11-10 | S1 | 664h | 664h | PrivCap | Lucent | Michael Boote (mboote@alcatel-lucent.com) | Rel-6 | Alain | PrivCap |  |
| 5130 | 44 | **Rel-6 Operations, Administration, Maintenance and Provisioning (OAM&P)** | 652d? | 2002-09-12 A | 2005-03-11 A | 100% | 2002-09-12 | 2005-03-11 | 652d? |  | S5 | 42635.5h | 42635.5h | OAM6 |  |  | Rel-6 | Mirko | OAM6 |  |
| 5131 | 44.1 | Principles, high level Requirements and Architecture | 526d | 2002-09-12 A | 2004-09-16 A | 100% | 2002-09-12 | 2004-09-16 | 526d | finish no earlier than 2004-09-16 | S5 | 4208h | 4208h |  | Motorola |  | Rel-6 | Mirko |  |  |
| 5132 | 44.2 | Performance Management | 591d | 2002-09-12 A | 2004-12-16 A | 100% | 2002-09-12 | 2004-12-16 | 591d | finish no earlier than 2004-12-16 | S5 | 4728h | 4728h |  | Nortel |  | Rel-6 | Mirko |  |  |
| 5133 | 44.4 | Network Infrastructure Management | 591d | 2002-09-12 A | 2004-12-16 A | 100% | 2002-09-12 | 2004-12-16 | 591d | finish no earlier than 2004-12-16 | S5 | 4728h | 4728h |  | Ericsson | thomas.tovinger@ericsson.com | Rel-6 | Mirko |  |  |

Notes:
- 5108: -
- 5109: -
- 5110: -
- 5111: -
- 5112: -
- 5113: -
- 5114: -
- 5115: -
- 5116: -
- 5117: -
- 5118: -
- 5119: -
- 5120: Completed at GERP#17
- 5121: -
- 5122: -
- 5123: -
- 5124: -
- 5125: Marked as stopped 10/2009
- 5126: Marked as stopped 10/2009
- 5127: SP#19 approved WID / Impacted TSs and TRs: 33.102
- 5128: - / Impacted TSs and TRs: 26.935
- 5129: - / Impacted TSs and TRs: 22.949
- 5130: SP#26: Updated WID SP-040766 was SP-020445. Completion delayed 12/04->03/05 due to OAM-Trace in CN1/4.
- 5131: SP#25 09/2004 completed / Impacted TSs and TRs: 32.101, 32.102
- 5132: SP#26 12/2004 completed / Impacted TSs and TRs: 32.401, 32.403, 52.402, 32.411, 32.412, 32.413, 32.432, 32.435, 32.436
- 5133: SP#26 12/2004 completed / Impacted TSs and TRs: 32.150/1/2, 32.805, 32.111-5, 32.313/4, 32.331/2/3/4/5, 32.341/2/3/4, 32.351/2/3/4, 32.361/2/3/4, 32.371/2/3/4, 32.804, 32.675, 32.690, 32.695, 32.71/2/3/4/5, 32.741/2/3/4/5

| ID | WBS | Task | Duration | Start | Finish | Complete | Baseline start | Baseline finish | Baseline duration | Constraint | Resources | Work | Actual work | Acronym | WI rapporteur name | WI rapporteur e-mail | Release | MCC resp | Acronym_3GU_Export | Impacted TSs and TRs | Created at | TSG stopped |
| --- | --- | --- | --- | --- | --- | --- | --- | --- | --- | --- | --- | --- | --- | --- | --- | --- | --- | --- | --- | --- | --- | --- |
| 5134 | 44.5 | **Rel-6 Trace Management** | 646d? | 2002-09-20 A | 2005-03-11 A | 100% | 2002-09-20 | 2005-03-11 | 646d? |  | S5; N4; R3 | 23877.9h | 23877.9h | OAM-Trace | Nokia | kari.t.ronka@nokia.com | Rel-6 | Mirko | OAM-Trace |  |  |  |
| 5135 | 1370.4.1 | Subscriber and UE trace management | 585d | 2002-09-20 A | 2004-12-16 A | 100% | 2002-09-20 | 2004-12-16 | 585d | finish no earlier than 2004-12-16 | S5 | 4680h | 4680h |  | Nokia | kari.t.ronka@nokia.com | Rel-6 | Mirko |  | 32.421, 32.422, 32.423, 52.008 |  |  |
| 5136 | 1370.4.2 | Subscriber and equipment trace in UTRAN | 268d? | 2003-06-06 A | 2004-06-15 A | 100% | 2003-06-06 | 2004-06-15 | 268d? | finish no earlier than 2004-06-15 | R3 | 2144h | 2144h | OAM-Trace-RAN | Nortel | Yann Sehedi (sehedic@nortelnetworks.com) | Rel-6 | Juha | OAM-Trace-RAN | 25.413, 25.420, 25.423 |  |  |
| 5137 | 1370.4.3 | Trace Management, Stage3 | 193.74d? | 2004-06-09 A | 2005-03-11 A | 100% | 2004-06-09 | 2005-03-11 | 193.74d? | finish no earlier than 2005-03-11 | N4 | 1549.92h | 1549.92h |  | Nokia | seppo.kauntola@nokia.com | Rel-6 | Kimmo |  | 23.205, 29.232, 29.060, 29.002, 29.228 |  |  |
| 5138 | 1371 | **Rel-6 Charging Management** | 666d? | 2002-11-21 A | 2005-06-09 A | 100% | 2002-11-21 | 2005-06-09 | 666d? |  | S5; S2; N3 | 67152h | 67152h | CH | T-Mobile | karl-heinz.nenner@t-mobile.de | Rel-6 | Mirko | CH |  |  |  |
| 5139 | 1371.1 | Charging architecture and principles | 390d? | 2003-03-21 A | 2004-09-16 A | 100% | 2003-03-21 | 2004-09-16 | 390d? | start no earlier than 2003-03-21 | S5 | 3120h | 3120h |  |  |  | Rel-6 | Mirko |  | 32.240 |  |  |
| 5140 | 1371.2 | Charging Data Record (CDR) file format and transfer | 260d? | 2003-03-21 A | 2004-03-18 A | 100% | 2003-03-21 | 2004-03-18 | 260d? | start no earlier than 2003-03-21 | S5 | 2080h | 2080h |  |  |  | Rel-6 | Mirko |  | 32.297 |  |  |
| 5141 | 1371.3 | CDR parameter description | 580d? | 2003-03-21 A | 2005-06-09 A | 100% | 2003-03-21 | 2005-06-09 | 580d? | finish no earlier than 2005-06-09 | S5 | 4640h | 4640h |  |  |  | Rel-6 | Mirko |  | 32.298 |  |  |
| 5142 | 1371.4 | Diameter charging applications | 390d? | 2003-03-21 A | 2004-09-16 A | 100% | 2003-03-21 | 2004-09-16 | 390d? | start no earlier than 2003-03-21 | S5 | 3120h | 3120h |  |  |  | Rel-6 | Mirko |  | 32.299 |  |  |
| 5143 | 1371.5 | Online Charging System (OCS) architecture study | 130d? | 2003-03-21 A | 2003-09-18 A | 100% | 2003-03-21 | 2003-09-18 | 130d? | start no earlier than 2003-03-21 | S5 | 1040h | 1040h |  |  |  | Rel-6 | Mirko |  | 32.815 |  |  |
| 5144 | 1371.6 | OCS: Applications and interfaces | 455d? | 2003-03-21 A | 2004-12-16 A | 100% | 2003-03-21 | 2004-12-16 | 455d? | start no earlier than 2003-03-21 | S5 | 3640h | 3640h |  |  |  | Rel-6 | Mirko |  | 32.296 |  |  |
| 5145 | 1371.7 | **Charging Management for Bearer level** | 390d? | 2003-03-21 A | 2004-09-16 A | 100% | 2003-03-21 | 2004-09-16 | 390d? |  | S5 | 11440h | 11440h | CH-BC | Nokia | Benni ALEXANDER | Rel-6 | Mirko | CH-BC |  |  |  |
| 5146 | 1371.7.1 | CS domain charging | 260d? | 2003-03-21 A | 2004-03-18 A | 100% | 2003-03-21 | 2004-03-18 | 260d? | start no earlier than 2003-03-21 | S5 | 2080h | 2080h |  |  |  | Rel-6 | Mirko |  | 32.250 |  |  |
| 5147 | 1371.7.2 | PS domain charging | 390d? | 2003-03-21 A | 2004-09-16 A | 100% | 2003-03-21 | 2004-09-16 | 390d? | start no earlier than 2003-03-21 | S5 | 3120h | 3120h |  |  |  | Rel-6 | Mirko |  | 32.251 |  |  |
| 5148 | 1371.7.3 | CDR transfer | 390d? | 2003-03-21 A | 2004-09-16 A | 100% | 2003-03-21 | 2004-09-16 | 390d? | start no earlier than 2003-03-21 | S5 | 3120h | 3120h |  |  |  | Rel-6 | Mirko |  | 32.295 |  |  |
| 5149 | 1371.8 | Charging Management for the Service domain | 580d? | 2003-03-21 A | 2005-06-09 A | 100% | 2003-03-21 | 2005-06-09 | 580d? | finish no earlier than 2005-06-09 | S5 | 4640h | 4640h |  | Siemens | Gerald.Goermer@nsn.com | Rel-6 | Mirko |  | 32.252, 32.270, 32.271, 32.272 |  |  |
| 5150 | 1371.9 | **Overall architectural aspects of IP flow based bearer level charging** | 602d? | 2002-11-21 A | 2005-03-11 A | 100% | 2002-11-21 | 2005-03-11 | 602d? |  | S2; N3 | 17448h | 17448h | CH-FBC |  |  | Rel-6 | Maurice | CH-FBC | 23.125 |  |  |
| 5151 | 1371.9.1 | Overall definition of FBC architecture | 334d? | 2002-11-21 A | 2004-03-02 A | 100% | 2002-11-21 | 2004-03-02 | 334d? | start no earlier than 2002-11-21 | S2 | 2672h | 2672h |  |  |  | Rel-6 | Maurice |  |  | SP-24 |  |
| 5152 | 1371.9.2 | Study on providing policy control with FBC | 130d? | 2004-02-02 A | 2004-07-30 A | 100% | 2004-02-02 | 2004-07-30 | 130d? | start no earlier than 2004-02-01 | S2 | 1040h | 1040h |  |  |  | Rel-6 | Maurice |  |  | SP-24 |  |
| 5153 | 1371.9.3 | Gx interface for flow based charging | 223d? | 2004-02-02 A | 2004-12-08 A | 100% | 2004-02-02 | 2004-12-08 | 223d? | start no earlier than 2004-02-01 | N3 | 1784h | 1784h |  | Nokia | juha.a.rasanen@nokia.com | Rel-6 | Gwiho |  | 29.210 | SP-25 |  |
| 5154 | 1371.9.4 | Rx interface for flow based charging | 290d? | 2004-02-02 A | 2005-03-11 A | 100% | 2004-02-02 | 2005-03-11 | 290d? | finish no earlier than 2005-03-11 | N3 | 2320h | 2320h |  | Nortel | Javier Gonzalez Gallego | Rel-6 | Gwiho |  | 29.209 | SP-25 |  |
| 5155 | 13 | **Rel-6 UICC/USIM enhancements and interworking** | 1164d? | 2000-09-25 A | 2005-03-10 A | 100% | 2000-09-25 | 2005-03-10 | 1164d? |  | T3 | 43088h | 43088h | USAT1 |  |  | Rel-6 | Xavier | USAT1 |  |  |  |
| 5156 | 13.1 | **UICC API** | 777d | 2002-03-20 A | 2005-03-10 A | 100% | 2002-03-20 | 2005-03-10 | 777d |  | T3 | 15024h | 15024h | USAT1-API |  |  | Rel-6 | Xavier | USAT1-API |  |  |  |
| 5157 | 13.1.1 | Rel-6 Java API Test specification | 59d | 2002-03-20 A | 2002-06-10 A | 100% | 2002-03-20 | 2002-06-10 | 59d | finish no earlier than 2002-09-20 | T3 | 472h | 472h |  | Microelectrónica Española | Mario Pérez | Rel-6 | Xavier |  |  |  |  |
| 5158 | 1372.1.2 | 2G/3G Java Card™ API based applet interworking | 255d | 2003-03-17 A | 2004-03-05 A | 100% | 2003-03-17 | 2004-03-05 | 255d | finish no earlier than 2004-02-19 | T3 | 2040h | 2040h |  | Oberthur Card Systems | Stéphane Andrau | Rel-6 | Xavier |  |  |  |  |
| 5159 | 1372.1.3 | (U)SIM API for Java Card Testing | 519d | 2003-03-17 A | 2005-03-10 A | 100% | 2003-03-17 | 2005-03-10 | 519d | finish no earlier than 2005-03-10 | T3 | 4152h | 4152h |  | Axalto | Christophe Begassat (cbegassat@axalto.com) | Rel-6 | Xavier |  | 31.213 |  |  |
| 5160 | 13.1.2 | Deleted - Java API Test specification (TS 43.019 Rel-5) | 268d | 2002-05-30 A | 2003-06-09 A | 100% | 2002-05-30 | 2003-06-09 | 268d | finish no earlier than 2003-09-17 | T3 | 2144h | 2144h |  | Microelectrónica Española | Mario Pérez | Rel-6 | Xavier |  |  |  | TP-20 |

Notes:
- 5134: SP#26 12/2004 SA5 completed 12/04. Signalling Based Trace Activation for IMS (SIP) moved to Rel-7. Reason: CN1 cannot complete 24.229 trace without IETF dependency => estimate 05/2005.
- 5135: SP#26 12/2004 completed
- 5136: -
- 5137: -
- 5138: SP#28 Target 09/2005 for WLAN Charging 32.252
- 5139: SP#25 09/2004 completed
- 5140: SP#23 03/2004 completed
- 5141: SP#28 06/2005 completed
- 5142: SP#25 09/2004 completed
- 5143: SP#21 09/2003 completed
- 5144: SP#26 12/2004 completed
- 5145: SP#28 Target 09/2005 for WLAN Charging 32.252
- 5146: SP#23 03/2004 completed
- 5147: SP#25 09/2004 completed
- 5148: SP#25 09/2004 completed
- 5149: SP#26: Updated WID SP-040778 was SP-030050. Target completion 06/2005. Consisting of MMS-CH, LCS-CH, WLAN-CH, POC-CH, MBMS-CH
- 5150: -
- 5151: -
- 5152: -
- 5153: -
- 5154: -
- 5155: -
- 5156: 8/3/2001: test spec is based on R99 core spec, so deleted from Workplan
- 5157: -
- 5158: -
- 5159: -
- 5160: MOVED to Rel-5 WP

| ID | WBS | Task | Type | Duration | Start | Finish | Complete | Remaining | Baseline start | Baseline finish | Baseline duration | Total slack | Constraint | Resources | Work | Actual work | Acronym | WI rapporteur name | WI rapporteur e-mail | Release | MCC resp | Acronym_3GU_Export | TSG stopped |
| --- | --- | --- | --- | --- | --- | --- | --- | --- | --- | --- | --- | --- | --- | --- | --- | --- | --- | --- | --- | --- | --- | --- | --- |
| 5161 | 1372.2 | **Rel-6 USIM toolkit enhancements** |  | 1160d? | 2000-09-25 A | 2005-03-04 A | 100% |  | 2000-09-25 | 2005-03-04 | 1160d? |  |  | T3 | 21848h | 21848h | USAT1-API-MULTOS | Aspects Software | Neil Livingston | Rel-6 | Xavier | USAT1-API-MULTOS |  |
| 5162 | 1372.2.1 | **C SIM API** |  | 525d | 2000-09-25 A | 2002-09-27 A | 100% |  | 2000-09-25 | 2002-09-27 | 525d |  |  | T3 | 9960h | 9960h |  | Aspects Software | Neil Livingston | Rel-6 | Xavier |  |  |
| 5163 | 1372.2.1.1 | Specification of C SIM API |  | 525d | 2000-09-25 A | 2002-09-27 A | 100% |  | 2000-09-25 | 2002-09-27 | 525d |  | finish no earlier than 2002-09-27 | T3 | 4200h | 4200h |  | Aspects Software | Neil Livingston | Rel-6 | Xavier |  |  |
| 5164 | 1372.2.1.2 | Test specification for C SIM API |  | 195d | 2001-01-01 A | 2001-09-28 A | 100% |  | 2001-01-01 | 2001-09-28 | 195d |  | finish no earlier than 2001-09-28 | T3 | 1560h | 1560h |  | Aspects Software | Neil Livingston | Rel-6 | Xavier |  |  |
| 5165 | 1372.2.2 | USIM application toolkit Conformance Test Specification for Mobile Equipments |  | 326d? | 2003-12-05 A | 2005-03-04 A | 100% |  | 2003-12-05 | 2005-03-04 | 326d? |  | start no earlier than 2003-12-05 | T3 | 2608h | 2608h |  | Gemplus | Eric.laffont@gemplus.com | Rel-6 | Xavier |  |  |
| 5166 | 1373 | **Packet Switched Streaming Services Rel-6** |  | 798d? | 2002-11-18 A | 2005-12-07 A | 100% |  | 2002-11-18 | 2005-12-07 | 798d? |  |  | S4; S1 | 19688h | 19688h | PSSrel6 | Ericsson | olle.franceschi@ericsson.com | Rel-6 | Paolo | PSSrel6 |  |
| 5167 | 1373.1 | Stage 1 for Packet Switched Streaming Services Rel-6 |  | 86d? | 2002-11-18 A | 2003-03-17 A | 100% |  | 2002-11-18 | 2003-03-17 | 86d? |  | finish no earlier than 2003-03-17 | S1 | 688h | 688h |  | Ericsson |  | Rel-6 | Alain |  |  |
| 5168 | 1373.2 | Stage 3 for Packet Switched Streaming Services Rel-6 |  | 779d? | 2002-12-13 A | 2005-12-07 A | 100% |  | 2002-12-13 | 2005-12-07 | 779d? |  | finish no earlier than 2005-12-07 | S4 | 6232h | 6232h | PSSrel6-Stage3 | Ericsson | olle.franceschi@ericsson.com | Rel-6 | Paolo | PSSrel6-Stage3 |  |
| 5169 | 1374 | AMR-WB extension for high audio quality |  | 779d | 2002-12-13 A | 2005-12-07 A | 100% |  | 2002-12-13 | 2005-12-07 | 779d |  | finish no earlier than 2005-12-07 | S4 | 6232h | 6232h | AMRWB+ | Nokia | janne.m.vainio@nokia.com | Rel-6 | Paolo | AMRWB+ |  |
| 5170 | 1375 | Codec Enhancements for Packet Switched Conversational Multimedia Applications |  | 198d? | 2004-03-16 A | 2004-12-16 A | 100% |  | 2004-03-16 | 2004-12-16 | 198d? |  | finish no earlier than 2004-12-16 | S4 | 1584h | 1584h | CEPSCM | Nokia | miska.hannuksela@nokia.com | Rel-6 | Paolo | CEPSCM |  |
| 5171 | 1376 | 3G-324M Improvements |  | 198d? | 2004-03-16 A | 2004-12-16 A | 100% |  | 2004-03-16 | 2004-12-16 | 198d? |  | finish no earlier than 2004-12-16 | S4 | 1584h | 1584h | 3G-324MI | Ericsson | bo.burman@ericsson.com | Rel-6 | Paolo | 3G-324MI |  |
| 5172 | 1377 | Single Antenna Receiver Interference Cancellation (SAIC) |  | 420.92d? | 2002-11-15 A | 2004-06-25 A | 100% |  | 2002-11-15 | 2004-06-25 | 420.92d? |  | finish no earlier than 2004-08-27 | GP; G1 | 6734.72h | 6734.72h | SAIC | Cingular | Marc Grant | Rel-6 | Paolo | SAIC |  |
| 5173 | 1378 | **Enhancement of dialled service for CAMEL** |  | 199d | 2003-03-28 A | 2003-12-31 A | 100% |  | 2003-03-28 | 2003-12-31 | 199d |  |  | S1; N2; N4 | 7960h | 7960h | EDCAMEL | Samsung | craig.bishop@samsung.com | Rel-6 | Alain | EDCAMEL |  |
| 5174 | 1378.1 | Stages 2 and 3 for Enhancement of dialled service for CAMEL |  | 199d | 2003-03-28 A | 2003-12-31 A | 100% |  | 2003-03-28 | 2003-12-31 | 199d |  | finish no earlier than 2003-09-19 | N2; N4 | 3184h | 3184h |  | Samsung | Richard Brook | Rel-6 | Kimmo |  |  |
| 5175 | 1379 | Study on Bandwidth and resource savings in CS networks |  | 273d? | 2003-06-01 A | 2004-06-16 A | 100% |  | 2003-06-01 | 2004-06-16 | 273d? |  | finish no earlier than 2004-06-16 | S2 | 2184h | 2184h | BARS |  |  | Rel-6 | Maurice | BARS |  |
| 5176 | 1380 | **Multiple TBF in A/Gb mode** |  | 736d? | 2002-04-05 A | 2005-01-28 A | 100% |  | 2002-04-05 | 2005-01-28 | 736d? |  |  | GP; G2 | 35200h | 35200h | MULTBF | Ericsson | gunnar.mildh@era.ericsson.se | Rel-6 | Paolo | MULTBF |  |
| 5177 | 1380.1 | **Multiple TBF in A/Gb mode - Core** |  | 366d? | 2002-04-05 A | 2003-08-29 A | 100% |  | 2002-04-05 | 2003-08-29 | 366d? |  |  | GP; G2 | 23424h | 23424h | MULTBF-Agbmode | Ericsson | gunnar.mildh@era.ericsson.se | Rel-6 | Paolo | MULTBF-Agbmode |  |
| 5178 | 1380.1.1 | Multiple TBF Concept paper |  | 366d? | 2002-04-05 A | 2003-08-29 A | 100% |  | 2002-04-05 | 2003-08-29 | 366d? |  | finish no earlier than 2003-08-29 | GP; G2 | 5856h | 5856h |  |  |  | Rel-6 | Paolo |  |  |
| 5179 | 1380.1.2 | Multiple TBF Stage 2 (43.064) CRs |  | 366d? | 2002-04-05 A | 2003-08-29 A | 100% |  | 2002-04-05 | 2003-08-29 | 366d? |  | finish no earlier than 2003-08-29 | GP; G2 | 5856h | 5856h |  |  |  | Rel-6 | Paolo |  |  |
| 5180 | 1380.1.3 | Multiple TBF Stage 3 (44.060) CRs |  | 366d? | 2002-04-05 A | 2003-08-29 A | 100% |  | 2002-04-05 | 2003-08-29 | 366d? |  | finish no earlier than 2003-08-29 | GP; G2 | 5856h | 5856h |  |  |  | Rel-6 | Paolo |  |  |
| 5181 | 1380.2 | Deleted - Multiple TBF in A/Gb mode – MS testing | milestone | 0d? | 2005-01-28 A | 2005-01-28 A | 100% |  | 2005-01-28 | 2005-01-28 | 0d? |  | start no earlier than 2005-01-28 | G3new |  |  | MULTBF-Testing | Ericsson | gunnar.mildh@era.ericsson.se | Rel-6 | Paolo | MULTBF-Testing | GP-27 |
| 5182 | 1381 | **Alignment between the test-regimes for GERAN capable MS** |  | 526d? | 2003-08-29 A | 2005-09-02 | 99% | 0d? | 2003-08-29 | 2005-09-02 | 526d? | 0d |  | G3new | 4208h | 4208h | ALTERE | Ericsson | anthony.toubassi@sonyericsson.com | Rel-6 | Ingbert | ALTERE |  |
| 5183 | 1381.1 | Determine the controversial test cases in the different test regimes and align them with 3GPP GERAN test specifications. Such test cases to be added to TS 51.010. |  | 526d? | 2003-08-29 A | 2005-09-02 A | 100% |  | 2003-08-29 | 2005-09-02 | 526d? |  | finish no earlier than 2005-09-02 | G3new | 4208h | 4208h | ALTERE-TC |  |  | Rel-6 | Ingbert | ALTERE-TC |  |
| 5184 | 1382 | Addition of U-TDOA in the CS domain |  | 111d? | 2003-11-21 A | 2004-04-23 A | 100% |  | 2003-11-21 | 2004-04-23 | 111d? |  | finish no earlier than 2004-04-23 | GP | 888h | 888h | UTDOACS | TruePosition | Bob Gross, Rhys Robinson (rlgross@trueposition.com) | Rel-6 | Paolo | UTDOACS |  |
| 5185 | 1383 | Addition of U-TDOA in the PS domain |  | 361d? | 2003-06-27 A | 2004-11-12 A | 100% |  | 2003-06-27 | 2004-11-12 | 361d? |  | finish no earlier than 2004-11-12 | GP | 2888h | 2888h | UTDOAPS | TruePosition | Bob Gross, Rhys Robinson (rlgross@trueposition.com) | Rel-6 | Paolo | UTDOAPS |  |

Notes:
- 5161: -
- 5162: - / Impacted TSs and TRs: 31.101, 31.102, 31.103, 31.111, 31.113, new 31.115, 31.116
- 5163: -
- 5164: -
- 5165: - / Impacted TSs and TRs: 31.124
- 5166: -
- 5167: 2nd resp SA4 / Impacted TSs and TRs: 22.233
- 5168: TR tbc by Sept. 05 / Impacted TSs and TRs: 26.233, 26.234, 26.244, 26.245, 26.246, 26.401, 26.402, 26.403, 26.404, 26.405, 26.406, 26.410, 26.411, 26.412, 26.273, 26.290, 26.304, 26.412, 26.274, 26.936
- 5169: TR tbc by Sept. 05 / Impacted TSs and TRs: 26.290, 26.304, 26.273, 26.274, 26.412, 26.936
- 5170: - / Impacted TSs and TRs: 26.235, 26.236
- 5171: - / Impacted TSs and TRs: 26.111, 26.911
- 5172: - / Impacted TSs and TRs: 45.903
- 5173: - / Impacted TSs and TRs: 22.078
- 5174: - / Impacted TSs and TRs: 23.008, 23.016, 23.018, 23.078, 29.002, 29.078
- 5175: - / Impacted TSs and TRs: 23.977
- 5176: GP#17 Nov 2003 Moved from Rel-5 UID_50058 MULTBF (Only Multiple TBF Concept paper produced in Rel-5)
- 5177: -
- 5178: -
- 5179: -
- 5180: -
- 5181: -
- 5182: -
- 5183: -
- 5184: Completed, except for potential LMU performance specs
- 5185: -

| ID | WBS | Task | Type | Duration | Start | Finish | Complete | Baseline start | Baseline finish | Baseline duration | Constraint | Resources | Work | Actual work | Acronym | WI rapporteur name | WI rapporteur e-mail | Release | MCC resp | Acronym_3GU_Export | TSG stopped | Impacted TSs and TRs | Created at |
| --- | --- | --- | --- | --- | --- | --- | --- | --- | --- | --- | --- | --- | --- | --- | --- | --- | --- | --- | --- | --- | --- | --- | --- |
| 5186 | 1384 | **Downlink Advanced Receiver Performance** |  | 466d? | 2003-11-21 A | 2005-09-02 A | 100% | 2003-11-21 | 2005-09-02 | 466d? |  | GP | 19160h | 19160h | DARP | Nokia | tommy.bysted@nokia.com | Rel-6 | Paolo | DARP |  |  |  |
| 5187 | 1384.1 | DARP test scenarios |  | 201d? | 2003-11-21 A | 2004-08-27 A | 100% | 2003-11-21 | 2004-08-27 | 201d? | finish no earlier than 2004-08-27 | GP | 1608h | 1608h | DARP-TS | Nokia | tommy.bysted@nokia.com | Rel-6 | Paolo | DARP-TS |  |  |  |
| 5188 | 1384.2 | **DARP for GMSK modulated voice services** |  | 201d? | 2004-02-06 A | 2004-11-12 A | 100% | 2004-02-06 | 2004-11-12 | 201d? |  | GP | 4824h | 4824h | DARP-GMSK | Nokia | tommy.bysted@nokia.com | Rel-6 | Paolo | DARP-GMSK |  |  |  |
| 5189 | 1384.2.1 | Performance requirements in 45.005 for DARP for GMSK modulated voice services |  | 201d? | 2004-02-06 A | 2004-11-12 A | 100% | 2004-02-06 | 2004-11-12 | 201d? | finish no earlier than 2004-11-12 | GP | 1608h | 1608h | DARP-GMSK-Perf |  |  | Rel-6 | Paolo | DARP-GMSK-Perf |  |  |  |
| 5190 | 1384.2.2 | Radio subsystem link control in 45.008 for DARP for GMSK modulated voice services |  | 201d? | 2004-02-06 A | 2004-11-12 A | 100% | 2004-02-06 | 2004-11-12 | 201d? | finish no earlier than 2004-11-12 | GP | 1608h | 1608h | DARP-GMSK-LC |  |  | Rel-6 | Paolo | DARP-GMSK-LC |  |  |  |
| 5191 | 1384.3 | **DARP for GPRS and EGPRS MCS1-MCS4** |  | 201d? | 2004-02-06 A | 2004-11-12 A | 100% | 2004-02-06 | 2004-11-12 | 201d? |  | GP | 4824h | 4824h | DARP-GPRSE | Nokia | tommy.bysted@nokia.com | Rel-6 | Paolo | DARP-GPRSE |  |  |  |
| 5192 | 1384.3.1 | Performance requirements in 45.005 for DARP for GPRS and EGPRS MCS1-MCS4 |  | 201d? | 2004-02-06 A | 2004-11-12 A | 100% | 2004-02-06 | 2004-11-12 | 201d? | finish no earlier than 2004-11-12 | GP | 1608h | 1608h | DARP-GPRSE-Perf |  |  | Rel-6 | Paolo | DARP-GPRSE-Perf |  |  |  |
| 5193 | 1384.3.2 | Radio subsystem link control in 45.008 for DARP for GPRS and EGPRS MCS1-MCS4 |  | 201d? | 2004-02-06 A | 2004-11-12 A | 100% | 2004-02-06 | 2004-11-12 | 201d? | finish no earlier than 2004-11-12 | GP | 1608h | 1608h | DARP-GPRSE-LC |  |  | Rel-6 | Paolo | DARP-GPRSE-LC |  |  |  |
| 5194 | 1384.4 | DARP Capability signalling |  | 256d? | 2003-11-21 A | 2004-11-12 A | 100% | 2003-11-21 | 2004-11-12 | 256d? | finish no earlier than 2004-11-12 | GP | 2048h | 2048h | DARP-CAPSIG | Nokia | tommy.bysted@nokia.com | Rel-6 | Paolo | DARP-CAPSIG |  |  |  |
| 5195 | 1384.5 | GERAN MS Conformance test for DARP |  | 266d? | 2004-08-27 A | 2005-09-02 A | 100% | 2004-08-27 | 2005-09-02 | 266d? | finish no earlier than 2005-06-24 | G3new | 2128h | 2128h | ARP-ConfTest | Nokia | tommy.bysted@nokia.com | Rel-6 | Ingbert | ARP-ConfTest |  |  |  |
| 5196 | 1385 | **Reduction of PS service interruption in Dual Transfer Mode** |  | 416d? | 2003-11-21 A | 2005-06-24 A | 100% | 2003-11-21 | 2005-06-24 | 416d? |  | G2 | 8360h | 8360h | PSintDTM | Siemens | toby.proctor@roke.co.uk | Rel-6 | Gert | PSintDTM |  |  |  |
| 5197 | 1385.1 | Use case and requirement definition |  | 111d? | 2003-11-21 A | 2004-04-23 A | 100% | 2003-11-21 | 2004-04-23 | 111d? | finish no earlier than 2004-04-23 | G2 | 888h | 888h | PSintDTM-Req | Siemens | toby.proctor@roke.co.uk | Rel-6 | Gert | PSintDTM-Req |  |  |  |
| 5198 | 1385.2 | Performance Study of Current Procedures |  | 111d? | 2003-11-21 A | 2004-04-23 A | 100% | 2003-11-21 | 2004-04-23 | 111d? | start no earlier than 2003-11-21 | G2 | 888h | 888h | PSintDTM-Perf | Siemens | toby.proctor@roke.co.uk | Rel-6 | Gert | PSintDTM-Perf |  |  |  |
| 5199 | 1385.3 | Reduction of service interruption times and packet loss during Dual Transfer Mode and mobility procedures |  | 146d? | 2004-04-23 A | 2004-11-12 A | 100% | 2004-04-23 | 2004-11-12 | 146d? | finish no earlier than 2004-11-12 | G2 | 1168h | 1168h | PSintDTM-Reduct | Siemens | toby.proctor@roke.co.uk | Rel-6 | Gert | PSintDTM-Reduct |  |  |  |
| 5200 | 1385.4 | Deleted - MS Conformance testing - Reduction of PS service interruption in DTM |  | 261d? | 2004-06-25 A | 2005-06-24 A | 100% | 2004-06-25 | 2005-06-24 | 261d? | finish no earlier than 2005-06-24 | G3new | 2088h | 2088h | PSintDTM-ConfMS |  |  | Rel-6 | Ingbert | PSintDTM-ConfMS | GP-25 |  |  |
| 5201 | 1385.5 | Deleted - BTS Conformance testing - Reduction of PS service interruption in DTM | milestone | 0d? | 2005-06-24 A | 2005-06-24 A | 100% | 2005-06-24 | 2005-06-24 | 0d? | finish no earlier than 2005-06-24 | G3new |  |  | PSintDTM-ConfBTS |  |  | Rel-6 | Ingbert | PSintDTM-ConfBTS | GP-25 |  |  |
| 5202 | 1386 | CAMEL prepay interworking with SCUDIF |  | 216.3d | 2003-12-08 A | 2004-10-05 A | 100% | 2003-12-08 | 2004-10-05 | 216.3d |  | N4; N3; S1 | 5191.2h | 5191.2h | SCCAMEL | Nokia | Keijo.Palviainen@Nokia.Com | Rel-6 | Kimmo | SCCAMEL |  | 22.078, 23.078, 29.078, 29.002, 23.172 |  |
| 5203 | 1387 | **Circuit Switched Video and Voice Service Improvements** |  | 430d? | 2004-01-12 A | 2005-09-02 A | 100% | 2004-01-12 | 2005-09-02 | 430d? |  | S2; N1 | 12696h | 12696h | CS_VSS | Vodafone | John Watson | Rel-6 | Alain | CS_VSS |  |  |  |
| 5204 | 1387.1 | Deleted - Stage 1 - Requirements |  | 199d | 2004-01-12 A | 2004-10-14 A | 100% | 2004-01-12 | 2004-10-14 | 199d | finish no earlier than 2004-10-14 | S1 | 1592h | 1592h |  | Vodafone | John Watson | Rel-6 | Alain |  | SP-26 | 22.101 |  |
| 5205 | 1387.2 | Stage 2 Study on architecture alternatives |  | 244d? | 2004-01-12 A | 2004-12-16 A | 100% | 2004-01-12 | 2004-12-16 | 244d? | finish no earlier than 2004-08-13 | S2 | 1952h | 1952h |  | Vodafone | chris.pudney@vodafone.com | Rel-6 | Maurice |  |  | 23.903 | SP-24 |
| 5206 | 1387.3 | Deleted - Stage 2 description on Redial |  | 164d? | 2004-05-03 A | 2004-12-16 A | 100% | 2004-05-03 | 2004-12-16 | 164d? | finish no earlier than 2004-12-16 | S2 | 1312h | 1312h |  | Vodafone | chris.pudney@vodafone.com | Rel-6 | Maurice |  | SP-26 |  | SP-24 |
| 5207 | 1387.4 | Switching between voice and video call - Redial solution |  | 120d? | 2005-01-03 A | 2005-06-17 A | 100% | 2005-01-03 | 2005-06-17 | 120d? | start no earlier than 2005-01-03 | N1 | 960h | 960h |  | Vodafone |  | Rel-6 | Frederic |  |  | 23.009, 24.008 |  |
| 5208 | 1387.5 | Deleted - CS_VSS - GERAN2 Part | milestone | 0d | 2005-09-02 A | 2005-09-02 A | 100% | 2005-09-02 | 2005-09-02 | 0d | start no earlier than 2005-09-02 | G2 |  |  |  | Vodafone |  | Rel-6 | Gert |  | GP-26 |  |  |
| 5209 | 1387.6 | Deleted - CS_VSS - CN3 Part | milestone | 0d? | 2004-10-14 A | 2004-10-14 A | 100% | 2004-10-14 | 2004-10-14 | 0d? | start no earlier than 2004-10-14 | N3 |  |  |  | Vodafone |  | Rel-6 | Gwiho |  | TP-26 |  |  |
| 5210 | 1388 | Reorganisation of CS Data Specifications |  | 14d? | 2004-11-19 A | 2004-12-08 A | 100% | 2004-11-19 | 2004-12-08 | 14d? | finish no earlier than 2004-12-24 | N3 | 112h | 112h | CSData | Siemens | Thomas.Belling@nsn.com | Rel-6 | Gwiho | CS Data |  | 23.910, 29.007, New 23.202 |  |

Notes:
- 5186: -
- 5187: -
- 5188: -
- 5189: -
- 5190: -
- 5191: -
- 5192: -
- 5193: -
- 5194: -
- 5195: -
- 5196: -
- 5197: -
- 5198: -
- 5199: -
- 5200: -
- 5201: -
- 5202: -
- 5203: -
- 5204: -
- 5205: -
- 5206: -
- 5207: -
- 5208: -
- 5209: -
- 5210: Created at TSG#27 as 100 % complete

| ID | WBS | Task | Type | Duration | Start | Finish | Complete | Baseline start | Baseline finish | Baseline duration | Constraint | Resources | Work | Actual work | Acronym | WI rapporteur name | Release | MCC resp | Acronym_3GU_Export | Impacted TSs and TRs | WI rapporteur e-mail | TSG stopped |
| --- | --- | --- | --- | --- | --- | --- | --- | --- | --- | --- | --- | --- | --- | --- | --- | --- | --- | --- | --- | --- | --- | --- |
| 5211 | 1389 | **Generic Access to A/Gb Interface (GAAI)** |  | 411d? | 2004-06-25 A | 2006-01-20 A | 100% | 2004-06-25 | 2006-01-20 | 411d? |  | GP | 9160h | 9160h | GAAI | Motorola | Rel-6 | Paolo | GAAI |  |  |  |
| 5212 | 1389.1 | FS on GAAI |  | 46d? | 2004-06-25 A | 2004-08-27 A | 100% | 2004-06-25 | 2004-08-27 | 46d? | finish no earlier than 2004-08-27 | GP | 368h | 368h | GAAG | Motorola | Rel-6 | Paolo | GAAG | 43.901 |  |  |
| 5213 | 1389.2 | GAAI – Stage 2 |  | 161d? | 2004-08-27 A | 2005-04-08 A | 100% | 2004-08-27 | 2005-04-08 | 161d? | finish no earlier than 2005-04-08 | GP | 1288h | 1288h | GAAI-Stage2 | Ericsson | Rel-6 | Paolo | GAAI-Stage2 | 43.318 | jari.vikberg@ericsson.com |  |
| 5214 | 1389.3 | GAAI – Stage 3 |  | 161d? | 2004-08-27 A | 2005-04-08 A | 100% | 2004-08-27 | 2005-04-08 | 161d? | finish no earlier than 2005-04-08 | GP | 1288h | 1288h | GAAI-Stage3 |  | Rel-6 | Paolo | GAAI-Stage3 | 44.318 |  |  |
| 5215 | 1389.4 | MS Conformance Test for GAAI |  | 366d? | 2004-08-27 A | 2006-01-20 A | 100% | 2004-08-27 | 2006-01-20 | 366d? | finish no earlier than 2006-01-20 | GP | 2928h | 2928h | GAAI-CT |  | Rel-6 | Ingbert | GAAI-CT |  |  |  |
| 5216 | 1390 | **Support of PS Handover for GERAN A/Gb mode** |  | 473d? | 2003-11-03 A | 2005-08-24 A | 100% | 2003-11-03 | 2005-08-24 | 473d? |  | GP; G2 | 30272h | 30272h | SPSHAGB | Ericsson | Rel-6 | Paolo | SPSHAGB |  | gunnar.hedby@ericsson.com |  |
| 5217 | 1390.1 | Stage 2 for Support of PS Handover for GERAN A/Gb mode |  | 473d? | 2003-11-03 A | 2005-08-24 A | 100% | 2003-11-03 | 2005-08-24 | 473d? | finish no earlier than 2005-09-02 | GP; G2 | 7568h | 7568h | SPSHAGB-Stage2 | Ericsson | Rel-6 | Paolo | SPSHAGB-Stage2 | 43.129 | gunnar.hedby@ericsson.com |  |
| 5218 | 1390.2 | PS handover for Support of PS Handover for GERAN A/Gb mode |  | 473d? | 2003-11-03 A | 2005-08-24 A | 100% | 2003-11-03 | 2005-08-24 | 473d? | finish no earlier than 2005-09-02 | GP; G2 | 7568h | 7568h | SPSHAGB-PSHO | Ericsson | Rel-6 | Paolo | SPSHAGB-PSHO |  | gunnar.hedby@ericsson.com |  |
| 5219 | 1390.3 | Definition of radio resource management functionality for Support of PS Handover for GERAN A/Gb mode |  | 473d? | 2003-11-03 A | 2005-08-24 A | 100% | 2003-11-03 | 2005-08-24 | 473d? | finish no earlier than 2005-09-02 | GP; G2 | 7568h | 7568h | SPSHAGB-RRM | Ericsson | Rel-6 | Paolo | SPSHAGB-RRM |  | gunnar.hedby@ericsson.com |  |
| 5220 | 1391 | Study on (U)SIM Security Reuse by Peripheral Devices on Local Interfaces |  | 127d? | 2003-07-03 A | 2003-12-26 A | 100% | 2003-07-03 | 2003-12-26 | 127d? | finish no earlier than 2003-12-26 | S3 | 1016h | 1016h |  | Toshiba | Rel-6 | Mirko |  | 33.817 | Raziq Yaqub (ryaqub@tari.toshiba.com) |  |
| 5221 | 1392 | Study on Security for early IMS |  | 127d? | 2004-10-01 A | 2005-03-28 A | 100% | 2004-10-01 | 2005-03-28 | 127d? | finish no earlier than 2003-12-26 | S3 | 1016h | 1016h | SEC-IMS | Vodafone | Rel-6 | Mirko | SEC-IMS | 33.978 | Peter.Howard@vodafone.com |  |
| 5222 | 1393 | (Small) Technical Enhancements and Improvements for Rel-6 | milestone | 0d? | 2006-06-02 A | 2006-06-02 A | 100% | 2006-06-02 | 2006-06-02 | 0d? |  | SP; CP; RP; GP |  |  | TEI6 |  | Rel-6 | all | TEI6 |  |  |  |
| 5223 | 1394 | Test - (Small) Technical Enhancements and Improvements for Rel-6 |  | 503d? | 2006-06-02 A | 2008-05-06 A | 100% | 2006-06-02 | 2008-05-06 | 503d? | start no earlier than 2006-06-02 | R5; T1 | 8048h | 8048h | TEI6_Test |  | Rel-6 | Ingbert | TEI6_Test | 34.108,34.121-1/2,34.122,34.123-1/2/3 |  |  |
| 5224 | 1395 | Deleted - Study of Feature Interactions Requirements | milestone | 0d? | 2004-09-16 A | 2004-09-16 A | 100% | 2004-09-16 | 2004-09-16 | 0d? | finish no earlier than 2004-10-01 | S1 |  |  | FINTER |  | Rel-6 | Alain | FINTER |  |  | SP-25 |
| 5225 | 1396 | Deleted EVGCS - Enhancements of VGCS in public networks for communication of public authority officials |  | 7d? | 2005-08-25 A | 2005-09-02 A | 100% | 2005-08-25 | 2005-09-02 | 7d? | start no earlier than 2005-08-24 | GP; G2 | 112h | 112h |  | Siemens | Rel-6 | Paolo |  | 44.018, 44.068, 48.008 | kenneth.isaacs@roke.co.uk | GP-26 |
| 5226 | 1397 | **Deleted SCSAGB - Support of Conversational Services in A/Gb mode via the PS domain** |  | 64d? | 2003-11-21 A | 2004-02-19 A | 100% | 2003-11-21 | 2004-02-19 | 64d? |  | GP; N1 | 2048h | 2048h |  | Ericsson | Rel-6 | Paolo |  |  | David Bladsjö (david.bladsjo@ericsson.com) | GP-18 |
| 5227 | 1397.1 | Deleted - Creation of a TR | milestone | 0d? | 2003-11-21 A | 2003-11-21 A | 100% | 2003-11-21 | 2003-11-21 | 0d? | start no earlier than 2003-11-21 | GP |  |  | SCSAGB-TR | Ericsson | Rel-6 | Paolo | SCSAGB-TR |  | David Bladsjö (david.bladsjo@ericsson.com) | GP-17 |
| 5228 | 1397.2 | Deleted - Stage 2 | milestone | 0d? | 2003-11-21 A | 2003-11-21 A | 100% | 2003-11-21 | 2003-11-21 | 0d? | finish no earlier than 2003-11-21 | GP |  |  | SCSAGB-Stage2 | Ericsson | Rel-6 | Paolo | SCSAGB-Stage2 |  | David Bladsjö (david.bladsjo@ericsson.com) | GP-17 |
| 5229 | 1397.3 | Deleted - Radio Channel Support | milestone | 0d? | 2003-11-21 A | 2003-11-21 A | 100% | 2003-11-21 | 2003-11-21 | 0d? | finish no earlier than 2003-11-21 | GP |  |  | SCSAGB-RCS | Ericsson | Rel-6 | Paolo | SCSAGB-RCS |  | David Bladsjö (david.bladsjo@ericsson.com) | GP-17 |
| 5230 | 1397.4 | Deleted SCSAGB-RRM - Definition of radio resource management functionality | milestone | 0d? | 2003-11-21 A | 2003-11-21 A | 100% | 2003-11-21 | 2003-11-21 | 0d? | finish no earlier than 2003-11-21 | GP |  |  |  | Ericsson | Rel-6 | Paolo |  |  | David Bladsjö (david.bladsjo@ericsson.com) | GP-17 |
| 5231 | 1397.5 | Deleted - replaced by 50561 - PS Handover |  | 64d | 2003-11-24 A | 2004-02-19 A | 100% | 2003-11-24 | 2004-02-19 | 64d | start no earlier than 2003-11-21 | GP; N1 | 1024h | 1024h | SCSAGB-PSH | Ericsson | Rel-6 | Paolo | SCSAGB-PSH |  | David Bladsjö (david.bladsjo@ericsson.com) | GP-18 |
| 5232 | 1397.6 | Deleted SCSAGB-FLO - Modifications to FLO | milestone | 0d? | 2003-11-21 A | 2003-11-21 A | 100% | 2003-11-21 | 2003-11-21 | 0d? | finish no earlier than 2003-11-21 | GP |  |  |  | Ericsson | Rel-6 | Paolo |  |  | David Bladsjö (david.bladsjo@ericsson.com) | RP-29 |
| 5233 | 1398 | Deleted - Rel-6 Evolutions of the transport in the UTRAN (ETRAN) | milestone | 0d | 2003-12-31 A | 2003-12-31 A | 100% | 2003-12-31 | 2003-12-31 | 0d | start no earlier than 2003-12-31 | RP |  |  |  | Alcatel | Rel-6 | Issam |  |  | Francois Courau | RP-22 |
| 5234 | 1399 | Release 5 Features |  | 325d? | 2000-01-03 A | 2001-03-29 A | 100% | 2000-01-03 | 2001-03-29 | 325d? |  | NP; GP; RP; SP; TP | 13000h | 13000h |  |  | Rel-5 | All |  |  |  |  |
| 5235 | 75 | IP transport in the UTRAN |  | 445d | 2000-07-17 A | 2002-03-29 A | 100% | 2000-07-17 | 2002-03-29 | 445d | finish no earlier than 2002-03-29 | R3 | 3560h | 3560h | ETRAN-IPtrans | Alcatel | Rel-5 | Juha | ETRAN-IPtrans |  | Nicolas Drevon |  |
| 5236 | 76 | Feasibility study on SS7 signalling transportation in the core network with SCCP-User Adaptation (SUA) |  | 205d | 2001-03-12 A | 2001-12-21 A | 100% | 2001-03-12 | 2001-12-21 | 205d | finish no earlier than 2001-12-21 | N4 | 1640h | 1640h | FS_SS7IP |  | Rel-5 | Kimmo | FS_SS7IP | 29.903 |  |  |

Notes:
- 5211: -
- 5212: Feasibility Study
- 5213: -
- 5214: -
- 5215: Marked as closed 12/2008 (was marked 90% complete)
- 5216: Replaces SCSAGB- Originally Started Nov 2003 as GP-030443
- 5217: Replaces SCSAGB-Stage2
- 5218: Replaces SCSAGB-PSH
- 5219: Replaces SCSAGB-RRM
- 5220: SP#20 approved WID
- 5221: SP#24 approved WID. SP#46 withdrawn TR 33.978 from Rel-8 onwards
- 5222: "Joker" WI, to be used for a Rel 6 CR not related to any feature and with very limited impact on the system. Moved in from Stoyan/Testing WP
- 5223: "Joker" WI, to be used for small modifications applicable to Rel 4 conformance testing
- 5224: SP#25 stopped
- 5225: GP#26 moved to Rel-7 as UID_11045 Enhancements of VGCS in public networks for communication of public authority officials
- 5226: -
- 5227: -
- 5228: Started
- 5229: Not started
- 5230: Not started
- 5231: Started
- 5232: Not started
- 5233: Generic feature ETRAN
- 5234: -
- 5235: -
- 5236: -

| ID | WBS | Task | Duration | Start | Finish | Complete | Baseline start | Baseline finish | Baseline duration | Constraint | Deadline | Resources | Work | Actual work | Acronym | WI rapporteur name | WI rapporteur e-mail | Release | MCC resp | Acronym_3GU_Export | Impacted TSs and TRs | Created at | TSG stopped |
| --- | --- | --- | --- | --- | --- | --- | --- | --- | --- | --- | --- | --- | --- | --- | --- | --- | --- | --- | --- | --- | --- | --- | --- |
| 5237 | 77 | **High Speed Downlink Packet Access** | 1550d? | 2001-04-02 A | 2007-03-09 A | 100% | 2001-04-02 | 2007-03-09 | 1550d? |  |  | R2; R5 | 43888h | 43888h | HSDPA | Motorola | Ravi Kuchibhotla | Rel-5 | Yong-Jun | HSDPA |  |  |  |
| 5238 | 77.1 | Physical Layer for High Speed Downlink Packet Access | 257d | 2001-04-05 A | 2002-03-29 A | 100% | 2001-04-05 | 2002-03-29 | 257d | finish no earlier than 2002-03-29 |  | R1 | 2056h | 2056h | HSDPA-Phys | Motorola | Amitabha Ghosh (qa0047@email.mot.com) | Rel-5 | Patrick | HSDPA-Phys |  |  |  |
| 5239 | 77.2 | Layer 2 and 3 aspects | 257d | 2001-04-05 A | 2002-03-29 A | 100% | 2001-04-05 | 2002-03-29 | 257d | finish no earlier than 2002-03-29 |  | R2 | 2056h | 2056h | HSDPA-L23 | Motorola | Ravi Kuchibhotla | Rel-5 | Yong-Jun | HSDPA-L23 |  |  |  |
| 5240 | 77.3 | Iub/Iur protocol aspects - for High Speed Downlink Packet Access | 260d | 2001-04-02 A | 2002-03-29 A | 100% | 2001-04-02 | 2002-03-29 | 260d | finish no earlier than 2002-03-29 |  | R3 | 2080h | 2080h | HSDPA-IubIur | Motorola | Mike Diesen | Rel-5 | Juha | HSDPA-IubIur |  |  |  |
| 5241 | 77.4 | RF Radio Transmission/ Reception, System Performance Requirements and Conformance Testing | 565d | 2001-04-09 A | 2003-06-06 A | 100% | 2001-04-09 | 2003-06-06 | 565d | finish no earlier than 2003-06-06 |  | R4 | 4520h | 4520h | HSDPA-RF | Motorola | Howard Benn | Rel-5 | Issam | HSDPA-RF |  |  |  |
| 5242 | 1402.5 | Conformance Testing of HSDPA | 786d | 2003-09-19 A | 2006-09-22 A | 100% | 2003-09-19 | 2006-09-22 | 786d | finish no earlier than 2006-09-22 |  | R5 | 6288h | 6288h | HSDPA_Test | Motorola | carolyn.taylor@motorola.com | Rel-5 | Ingbert | HSDPA_Test | 34.108, 34.121, 34.122, 34.123-1, 34.123-2, 34.123-3 | 19/9/2003 |  |
| 5243 | 1402.6 | Conformance Testing of HCR TDD HSDPA | 261d? | 2006-03-10 A | 2007-03-09 A | 100% | 2006-03-10 | 2007-03-09 | 261d? | finish no earlier than 2007-03-09 |  | R5 | 2088h | 2088h | HSDPA_HCRTDD_Test | IPWireless | drichards@ipwireless.com | Rel-5 | Ingbert | HSDPA_HCRTDD_Test | 34.108, 34.122, 34.123-1, 34.123-2, 34.123-3 |  |  |
| 5244 | 78 | **Rel-5 Improvements of Radio Interface** | 535d | 2000-08-14 A | 2002-08-30 A | 100% | 2000-08-14 | 2002-08-30 | 535d |  |  | RP | 30376h | 30376h |  |  |  | Rel-5 |  |  |  |  |  |
| 5245 | 78.1 | **Base station classification for TDD** | 480d | 2000-08-14 A | 2002-06-14 A | 100% | 2000-08-14 | 2002-06-14 | 480d |  |  | R4 | 9208h | 9208h | RInImp-BSClass | Nokia | antti.toskala@nokia.com | Rel-5 | Issam | RInImp-BSClass |  |  |  |
| 5246 | 78.1.1 | TDD Base station classification | 410d | 2000-08-14 A | 2002-03-08 A | 100% | 2000-08-14 | 2002-03-08 | 410d | finish no earlier than 2002-03-08 |  | R4 | 3280h | 3280h | RInImp-BSClass-TDD | Nokia | antti.toskala@nokia.com | Rel-5 | Issam | RInImp-BSClass-TDD |  |  |  |
| 5247 | 78.1.2 | Base Station Classification for 1.28 Mcps TDD option | 261d | 2001-06-15 A | 2002-06-14 A | 100% | 2001-06-15 | 2002-06-14 | 261d | finish no earlier than 2002-06-14 |  | R4 | 2088h | 2088h | RInImp-BSClass-LCRTDD | Siemens | Meik.Kottkamp@siemens.com | Rel-5 | Issam | RInImp-BSClass-LCRTDD |  |  |  |
| 5248 | 78.2 | Enhancement on the DSCH hard split mode | 271d | 2001-03-16 A | 2002-03-29 A | 100% | 2001-03-16 | 2002-03-29 | 271d | finish no earlier than 2002-03-29 |  | R1 | 2168h | 2168h | RInImp-DSCHhsp | Samsung | Jaeyoel KIM | Rel-5 | Patrick | RInImp-DSCHhsp |  |  |  |
| 5249 | 78.3 | Hybrid ARQ II/III | 355d | 2000-08-21 A | 2001-12-28 A | 100% | 2000-08-21 | 2001-12-28 | 355d | finish no earlier than 2001-12-28 |  | R2 | 2840h | 2840h | RInImp-HARQ | Siemens | armin.sitte@siemens.com | Rel-5 | Yong-Jun | RInImp-HARQ |  |  | RP-14 |
| 5250 | 78.4 | FS on USTS | 355d | 2000-08-14 A | 2001-12-21 A | 100% | 2000-08-14 | 2001-12-21 | 355d | finish no earlier than 2001-12-21 |  | R1 | 2840h | 2840h | RInImp-USTS | SK Telecom | D. Kim | Rel-5 | Patrick | RInImp-USTS |  |  |  |
| 5251 | 78.5 | FS on UE antenna efficiency test method performance requirements | 255d | 2000-09-25 A | 2001-09-14 A | 100% | 2000-09-25 | 2001-09-14 | 255d | finish no earlier than 2001-09-14 |  | R4 | 2040h | 2040h | RInImp-UEAnTM | Allgon | O. Edvardsson | Rel-5 | Issam | RInImp-UEAnTM |  |  |  |
| 5252 | 78.6 | FS on the re-introduction of the downlink SIR measurement | 200d | 2001-03-12 A | 2001-12-14 A | 100% | 2001-03-12 | 2001-12-14 | 200d | finish no earlier than 2001-12-14 |  | R4 | 1600h | 1600h | RInImp-SIR | Ericsson | Torgny.Palenius@ericsson.com | Rel-5 | Issam | RInImp-SIR |  |  |  |
| 5253 | 78.7 | FS on mitigating the effect of CPICH interference at the UE | 255d | 2001-03-19 A | 2002-03-08 A | 100% | 2001-03-19 | 2002-03-08 | 255d | finish no earlier than 2002-03-08 |  | R4 | 2040h | 2040h | RInImp-CPICH_Intf | Intel | shimon.moshavi@INTEL.COM | Rel-5 | Issam | RInImp-CPICH_Intf |  |  |  |
| 5254 | 78.8 | **Deleted - Conformance Test Spec. improvements in Radio Interface** | 140d | 2002-02-18 A | 2002-08-30 A | 100% | 2002-02-18 | 2002-08-30 | 140d |  |  | T1 | 3360h | 3360h |  |  |  | Rel-5 | Ingbert |  |  |  | TP-17 |
| 5255 | 78.8.1 | Deleted - Testing improvement of inter-frequency and inter-system measurement | 140d | 2002-02-18 A | 2002-08-30 A | 100% | 2002-02-18 | 2002-08-30 | 140d | finish no earlier than 2002-08-30 |  | T1 | 1120h | 1120h |  |  |  | Rel-5 | Ingbert |  |  |  | TP-17 |
| 5256 | 78.8.2 | Deleted - Testing Hybrid ARQ II/III | 140d | 2002-02-18 A | 2002-08-30 A | 100% | 2002-02-18 | 2002-08-30 | 140d | finish no earlier than 2002-08-30 |  | T1 | 1120h | 1120h |  |  |  | Rel-5 | Ingbert |  |  |  | TP-17 |
| 5257 | 79 | **Rel-5 RAN improvements** | 1561d? | 2001-03-16 A | 2007-03-09 A | 100% | 2001-03-16 | 2007-03-09 | 1561d? |  |  | RP | 49424h | 49424h |  |  |  | Rel-5 |  |  |  |  |  |
| 5258 | 79.1 | **RRM optimization for Iur and Iub** | 318d | 2001-03-16 A | 2002-06-04 A | 100% | 2001-03-16 | 2002-06-04 | 318d |  |  | R3 | 8904h | 8904h | RANimp-RRMopt | Ericsson | Gert-Jan.van.Lieshout@eln.ericsson.se | Rel-5 | Juha | RANimp-RRMopt |  |  |  |
| 5259 | 79.1.1 | Iur common transport channel efficiency optimization | 271d | 2001-03-16 A | 2002-03-29 A | 100% | 2001-03-16 | 2002-03-29 | 271d | finish no earlier than 2002-03-29 |  | R3 | 2168h | 2168h | RANimp-RRMopt-ctc | Ericsson | Shahrokh Amirijoo | Rel-5 | Juha | RANimp-RRMopt-ctc |  |  |  |
| 5260 | 79.1.2 | Iur neighbouring cell reporting efficiency optimization | 271d | 2001-03-16 A | 2002-03-29 A | 100% | 2001-03-16 | 2002-03-29 | 271d | finish no earlier than 2002-03-29 |  | R3 | 2168h | 2168h | RANimp-RRMopt-ncr | Ericsson | Shahrokh Amirijoo | Rel-5 | Juha | RANimp-RRMopt-ncr |  |  |  |
| 5261 | 79.1.3 | FS Introduction of direct transport bearers between SRNC and Node-B | 253d | 2001-06-15 A | 2002-06-04 A | 100% | 2001-06-15 | 2002-06-04 | 253d | finish no earlier than 2002-06-28 |  | R3 | 2024h | 2024h | RAN-imp-RRMopt-DTB | Ericsson | Risto Sepponen | Rel-5 | Juha | RAN-imp-RRMopt-DTB |  |  |  |
| 5262 | 79.2 | RL Timing Adjustment | 271d | 2001-03-16 A | 2002-03-29 A | 100% | 2001-03-16 | 2002-03-29 | 271d | finish no earlier than 2002-03-29 |  | R3 | 2168h | 2168h | RANimp-RLTA | Ericsson | Elena Voltolina | Rel-5 | Juha | RANimp-RLTA |  |  |  |
| 5263 | 79.3 | Separation of resource reservation and radio link activation | 271d | 2001-03-16 A | 2002-03-29 A | 100% | 2001-03-16 | 2002-03-29 | 271d | finish no earlier than 2002-03-29 |  | R3 | 2168h | 2168h | RANimp-SepRR | Ericsson | Gert-Jan.van.Lieshout@eln.ericsson.se | Rel-5 | Juha | RANimp-SepRR |  |  |  |
| 5264 | 79.4 | FS SRNS Relocation Procedure Enhancement | 318d | 2001-06-15 A | 2002-09-03 A | 100% | 2001-06-15 | 2002-09-03 | 318d | finish no earlier than 2002-09-06 |  | R3 | 2544h | 2544h | RANimp-SRNS | Nokia | Olivier Guyot | Rel-5 | Juha | RANimp-SRNS |  |  |  |
| 5265 | 79.5 | FS Improvement of Radio Resource Management across RNS and RNS/PSS | 201d | 2001-03-16 A | 2001-12-21 A | 100% | 2001-03-16 | 2001-12-21 | 201d | finish no earlier than 2001-12-21 |  | R3 | 1608h | 1608h | RANimp-ImpRRM | Nokia | antti.toskala@nokia.com | Rel-5 | Juha | RANimp-ImpRRM |  |  |  |
| 5266 | 79.6 | Re-arrangements of Iub transport bearers | 271d | 2001-03-16 A | 2002-03-29 A | 100% | 2001-03-16 | 2002-03-29 | 271d | finish no earlier than 2002-03-29 |  | R3 | 2168h | 2168h | RANimp-TTPS | Nokia | antti.toskala@nokia.com | Rel-5 | Juha | RANimp-TTPS |  |  |  |
| 5267 | 79.7 | RAB support enhancement for Rel-5 | 325d | 2001-04-02 A | 2002-06-28 A | 100% | 2001-04-02 | 2002-06-28 | 325d |  |  | R2 | 2600h | 2600h | RANimp-RABSE5 | Nokia | Juha Mikola | Rel-5 | Yong-Jun | RANimp-RABSE5 |  |  |  |
| 5268 | 16.5.1 | Testing of ROHC performance | 391d | 2005-09-09 A | 2007-03-09 A | 100% | 2005-09-09 | 2007-03-09 | 391d | finish no earlier than 2007-03-09 | 2006-06-02 | R5 | 3128h | 3128h | RANimp-RABSE5_Test | Nokia | jarkko.hellsten@nokia.com | Rel-5 | Ingbert | RANimp-RABSE5_Test | 34.108, 34.123-1, 34.123-2, 34.123-3 | Fri 11/03/05 |  |
| 5269 | 79.8 | Beamforming requirements for UE | 61d | 2001-09-21 A | 2001-12-14 A | 100% | 2001-09-21 | 2001-12-14 | 61d | finish no earlier than 2001-12-14 |  | R1 | 488h | 488h | RANimp-BFR-UE | Nokia | Jussi Kähtävä (juha.mikola@nokia.com) | Rel-5 | Patrick | RANimp-BFR-UE |  |  |  |
| 5270 | 79.9 | Support of Site Selection Diversity Transmission in UTRAN | 123d | 2001-12-14 A | 2002-06-04 A | 100% | 2001-12-14 | 2002-06-04 | 123d | finish no earlier than 2002-06-04 |  | R1 | 984h | 984h | RANimp-SSDT | NEC |  | Rel-5 | Patrick | RANimp-SSDT |  |  |  |
| 5271 | 79.10 | Node B Synchronisation for 1.28 Mcps TDD | 271d | 2001-03-16 A | 2002-03-29 A | 100% | 2001-03-16 | 2002-03-29 | 271d | finish no earlier than 2002-03-29 |  | R1 | 2168h | 2168h | RANimp-NBSLCR | CATT | Jinling HU | Rel-5 | Patrick | RANimp-NBSLCR |  |  |  |

Notes:
- 5237: -
- 5238: -
- 5239: -
- 5240: -
- 5241: -
- 5242: -
- 5243: -
- 5244: -
- 5245: -
- 5246: -
- 5247: -
- 5248: -
- 5249: Stopped at RP#14; work on this task was performed as part of High Speed Downlink Packet Access feature
- 5250: -
- 5251: -
- 5252: -
- 5253: -
- 5254: Marked as stopped 12/2008
- 5255: Marked as stopped 12/2008
- 5256: Marked as stopped 12/2008
- 5257: -
- 5258: -
- 5259: -
- 5260: -
- 5261: FS was closed and introduction of WI not agreed at RAN #16
- 5262: -
- 5263: -
- 5264: -
- 5265: FS was closed and WI was introduced at RAN #14
- 5266: -
- 5267: RFC 3095 context relocation
- 5268: -
- 5269: -
- 5270: RP-020356
- 5271: -

| ID | WBS | Task | Duration | Start | Finish | Complete | Baseline start | Baseline finish | Baseline duration | Constraint | Deadline | Resources | Work | Actual work | Release | MCC resp | TSG stopped | Acronym | Impacted TSs and TRs | Acronym_3GU_Export | WI rapporteur name | WI rapporteur e-mail | Created at |
| --- | --- | --- | --- | --- | --- | --- | --- | --- | --- | --- | --- | --- | --- | --- | --- | --- | --- | --- | --- | --- | --- | --- | --- |
| 5272 | 79.12 | **Deleted - Conformance Test Aspects - RAN Improvements** | 565d? | 2002-01-01 A | 2004-03-01 A | 100% | 2002-01-01 | 2004-03-01 | 565d? |  |  | T1 | 8008h | 8008h | Rel-5 | Ingbert | TP-23 |  |  |  |  |  |  |
| 5273 | 79.12.1 | Deleted - Testing Radio access bearer support enhancements | 175d | 2002-01-01 A | 2002-09-02 A | 100% | 2002-01-01 | 2002-09-02 | 175d | finish no earlier than 2002-09-02 |  | T1 | 1400h | 1400h | Rel-5 | Ingbert | TP-17 |  |  |  |  |  |  |
| 5274 | 1404.12.2 | Deleted - General changes to TS34.121 and TS34.122 corresponding to release 5 | 261d? | 2003-03-03 A | 2004-03-01 A | 100% | 2003-03-03 | 2004-03-01 | 261d? | finish no earlier than 2004-03-01 |  | T1 | 2088h | 2088h | Rel-5 | Ingbert | TP-23 | RANimp-test,TEI5 | 34.108, 34.121, 34.122 | RANimp-test, TEI5 |  |  |  |
| 5275 | 80 | UTRAN Sharing in Connected Mode | 197d | 2001-12-03 A | 2002-09-03 A | 100% | 2001-12-03 | 2002-09-03 | 197d | finish no earlier than 2002-09-06 |  | R3 | 1576h | 1576h | Rel-5 | Juha |  | NETSHARE |  | NETSHARE | Ericsson | Martin Israelsson |  |
| 5276 | 81 | **Provisioning of IP-based multimedia services** | 1806d | 2000-01-03 A | 2006-12-01 A | 100% | 2000-01-03 | 2006-12-01 | 1806d |  |  | S1; S2; S3; S5; NP; T3; T1; R5 | 325092h | 325092h | Rel-5 | Alain |  | IMS |  | IMS | Openwave | Mark Cataldo |  |
| 5277 | 81.1 | **Call control and roaming to support IMS in UMTS** | 1806d | 2000-01-03 A | 2006-12-01 A | 100% | 2000-01-03 | 2006-12-01 | 1806d |  |  | S2; R5 | 109760h | 109760h | Rel-5 | Maurice |  | IMS-CCR |  | IMS-CCR | Lucent | Liz Daniel |  |
| 5278 | 81.1.1 | Stage 1 for Call control and roaming to support IMS in UMTS | 215d | 2000-02-21 A | 2000-12-15 A | 100% | 2000-02-21 | 2000-12-15 | 215d | finish no earlier than 2000-09-21 |  | S1 | 1720h | 1720h | Rel-5 | Alain |  |  | 22.228 |  | Motorola | Mark Cataldo |  |
| 5279 | 81.1.2 | Stage 2 (Architecture and Main flows) | 246d | 2000-04-14 A | 2001-03-23 A | 100% | 2000-04-14 | 2001-03-23 | 246d | finish no earlier than 2001-03-23 |  | S2 | 1968h | 1968h | Rel-5 | Maurice |  |  | 23.228 |  | Lucent | Liz Daniel |  |
| 5280 | 81.1.3 | Impact on MM/CC/SM | 400d | 2000-08-28 A | 2002-03-08 A | 100% | 2000-08-28 | 2002-03-08 | 400d | finish no earlier than 2002-03-08 |  | N1 | 3200h | 3200h | Rel-5 | Frederic |  | IMS-CCR-IWMM |  | IMS-CCR-IWMM | Lucent | Keith Drage (drage@alcatel-lucent.com) |  |
| 5281 | 81.1.4 | **SIP Call Control protocol for the IMS** | 385d | 2000-10-02 A | 2002-03-22 A | 100% | 2000-10-02 | 2002-03-22 | 385d |  |  | N1 | 12320h | 12320h | Rel-5 | Frederic |  |  | 24.228, 24.229, 23.218 |  | Lucent | Keith Drage (drage@alcatel-lucent.com) |  |
| 5282 | 81.1.4.1 | IMS signalling flows | 385d | 2000-10-02 A | 2002-03-22 A | 100% | 2000-10-02 | 2002-03-22 | 385d | finish no earlier than 2002-03-22 |  | N1 | 3080h | 3080h | Rel-5 | Frederic |  |  | 24.228 |  |  |  |  |
| 5283 | 81.1.4.2 | IMS stage 3 | 385d | 2000-10-02 A | 2002-03-22 A | 100% | 2000-10-02 | 2002-03-22 | 385d | finish no earlier than 2002-03-22 |  | N1 | 3080h | 3080h | Rel-5 | Frederic |  |  | 24.229 |  |  |  |  |
| 5284 | 81.1.4.3 | IMS Session Handling; stage 2 | 385d | 2000-10-02 A | 2002-03-22 A | 100% | 2000-10-02 | 2002-03-22 | 385d | finish no earlier than 2002-03-22 |  | N1 | 3080h | 3080h | Rel-5 | Frederic |  |  | 23.218 |  |  |  |  |
| 5285 | 16.5.1 | Conformance Test Aspects – IMS Call Control | 451d | 2005-03-11 A | 2006-12-01 A | 100% | 2005-03-11 | 2006-12-01 | 451d |  | 2006-06-02 | R5 | 3608h | 3608h | Rel-5 | Ingbert |  | IMS-CCR_Test | 34.108, 34.229-1, 34.229-2, 34.229-3 | IMS-CCR_Test | Motorola | Jacob.John@motorola.com | Fri 11/03/05 |
| 5286 | 81.1.4.4 | **Main IETF dependencies** | 641d | 2000-01-03 A | 2002-06-14 A | 100% | 2000-01-03 | 2002-06-14 | 641d |  |  | NP | 58048h | 58048h | Rel-5 | Kimmo |  |  |  |  | Lucent |  |  |
| 5287 | 81.1.4.4.1 | IETF: RFC 3261 (Session Initiation Protocol) | 346d | 2000-11-24 A | 2002-03-22 A | 100% | 2000-11-24 | 2002-03-22 | 346d | finish no earlier than 2002-03-22 |  | N1 | 2768h | 2768h | Rel-5 | Frederic |  |  |  |  | Lucent |  |  |
| 5288 | 81.1.4.4.2 | IETF: RFC 3262 (Reliability of provisional responses) | 346d | 2000-11-24 A | 2002-03-22 A | 100% | 2000-11-24 | 2002-03-22 | 346d | finish no earlier than 2002-03-22 |  | N1 | 2768h | 2768h | Rel-5 | Frederic |  |  |  |  | Lucent |  |  |
| 5289 | 81.1.4.4.3 | IETF: RFC 3312 (Without COMET)(Integration of resource management and SIP) | 382d | 2000-11-24 A | 2002-05-13 A | 100% | 2000-11-24 | 2002-05-13 | 382d | finish no earlier than 2002-05-13 |  | N1 | 3056h | 3056h | Rel-5 | Frederic |  |  |  |  | Lucent |  |  |
| 5290 | 81.1.4.4.4 | IETF: RFC 3323 (SIP extensions for caller identity and privacy) | 382d | 2000-11-24 A | 2002-05-13 A | 100% | 2000-11-24 | 2002-05-13 | 382d | finish no earlier than 2002-05-13 |  | N1 | 3056h | 3056h | Rel-5 | Frederic |  |  |  |  | Lucent |  |  |
| 5291 | 81.1.4.4.5 | IETF: RFC 3313 (SIP extensions for media authorization) | 382d | 2000-11-24 A | 2002-05-13 A | 100% | 2000-11-24 | 2002-05-13 | 382d | finish no earlier than 2002-05-13 |  | N1 | 3056h | 3056h | Rel-5 | Frederic |  |  |  |  | Lucent |  |  |
| 5292 | 81.1.4.4.6 | IETF: RFC 3265 (specific event notification) | 346d | 2000-11-24 A | 2002-03-22 A | 100% | 2000-11-24 | 2002-03-22 | 346d | finish no earlier than 2002-03-22 |  | N1 | 2768h | 2768h | Rel-5 | Frederic |  |  |  |  | Lucent |  |  |
| 5293 | 81.1.4.4.7 | IETF: RFC editor Queue (refer method) | 401d | 2000-11-24 A | 2002-06-07 A | 100% | 2000-11-24 | 2002-06-07 | 401d | finish no earlier than 2002-06-07 |  | N1 | 3208h | 3208h | Rel-5 | Frederic |  |  |  |  | Lucent |  |  |
| 5294 | 81.1.4.4.8 | IETF: RFC editor Queue (DHCP options for SIP servers) | 382d | 2000-11-24 A | 2002-05-13 A | 100% | 2000-11-24 | 2002-05-13 | 382d | finish no earlier than 2002-05-13 |  | N1 | 3056h | 3056h | Rel-5 | Frederic |  |  |  |  | Lucent |  |  |
| 5295 | 81.1.4.4.10 | IETF: RFC 3267 (AMR and AMR WB RTP and SDP) | 346d | 2000-11-24 A | 2002-03-22 A | 100% | 2000-11-24 | 2002-03-22 | 346d | finish no earlier than 2002-03-22 |  | N1 | 2768h | 2768h | Rel-5 | Frederic |  |  |  |  | Lucent |  |  |
| 5296 | 81.1.4.4.11 | IETF: RFC 3266 (IPv6 support within SDP) | 581d | 2000-01-03 A | 2002-03-22 A | 100% | 2000-01-03 | 2002-03-22 | 581d | finish no earlier than 2002-03-22 |  | N1 | 4640h | 4640h | Rel-5 | Frederic |  |  |  |  | Lucent |  |  |
| 5297 | 81.1.4.4.12 | IETF: RFC 3311 (The Update method) | 382d | 2000-11-24 A | 2002-05-13 A | 100% | 2000-11-24 | 2002-05-13 | 382d | finish no earlier than 2002-05-13 |  | N1 | 3056h | 3056h | Rel-5 | Frederic |  |  |  |  | Lucent |  |  |
| 5298 | 81.1.4.4.13 | IETF: RFC 3324 (Network Asserted Identity) | 382d | 2000-11-24 A | 2002-05-13 A | 100% | 2000-11-24 | 2002-05-13 | 382d | finish no earlier than 2002-05-13 |  | N1 | 3056h | 3056h | Rel-5 | Frederic |  |  |  |  | Lucent |  |  |
| 5299 | 81.1.4.4.14 | IETF: RFC editor Queue (Various 3GPP Private Extensions) | 382d | 2000-11-24 A | 2002-05-13 A | 100% | 2000-11-24 | 2002-05-13 | 382d | finish no earlier than 2002-05-13 |  | N1 | 3056h | 3056h | Rel-5 | Frederic |  |  |  |  | Lucent |  |  |

Notes:
- 5272: Marked as stopped 12/2008
- 5273: Marked as stopped 12/2008
- 5274: Marked as stopped 12/2008
- 5275: Formerly 'Shared Network support in connected mode', renamed at RAN #16.
- 5276: -
- 5277: -
- 5278: Issues include e.g.: Roaming requirements, Requirements on supplementary services, Interworking requirements
- 5279: Issues include e.g.: Mobile IP, RAB selection principles, Optimized VoIP bearer mechanisms, SIP multimedia protocol
- 5280: Per 26/2-02: This is understood to be the PCO & TFT CRs which CN1 provides to TSGN #15 for approval. If this is correct understanding, then the task is 100 % complete.
- 5281: TSGN_10 approved the change:CN1 - SA2 SIP joint meeting spotted one more place for improvement: work tasks with ID 1998 and 1278 are actually subtasks under of single CN1 WT. One WI has been approved for the CN1 WT with title "SIP Call Control protocol
- 5282: 24.228
- 5283: 24.229
- 5284: 23.218
- 5285: -
- 5286: -
- 5287: -
- 5288: -
- 5289: -
- 5290: -
- 5291: -
- 5292: -
- 5293: -
- 5294: -
- 5295: -
- 5296: -
- 5297: -
- 5298: -
- 5299: -

| ID | WBS | Task | Duration | Start | Finish | Complete | Baseline start | Baseline finish | Baseline duration | Constraint | Resources | Work | Actual work | Release | MCC resp | Acronym | Impacted TSs and TRs | WI rapporteur name | WI rapporteur e-mail | Acronym_3GU_Export | TSG stopped |
| --- | --- | --- | --- | --- | --- | --- | --- | --- | --- | --- | --- | --- | --- | --- | --- | --- | --- | --- | --- | --- | --- |
| 5300 | 81.1.4.5 | **Addressing** | 380d | 2000-10-09 A | 2002-03-22 A | 100% | 2000-10-09 | 2002-03-22 | 380d |  | S2 | 7744h | 7744h | Rel-5 | Maurice |  |  |  |  |  |  |
| 5301 | 81.1.4.5.1 | Architectural issues | 235d | 2000-10-09 A | 2001-08-31 A | 100% | 2000-10-09 | 2001-08-31 | 235d | finish no earlier than 2001-03-16 | S2 | 1880h | 1880h | Rel-5 | Maurice |  |  |  |  |  |  |
| 5302 | 81.1.4.5.2 | Impact on HSS | 353d | 2000-11-15 A | 2002-03-22 A | 100% | 2000-11-15 | 2002-03-22 | 353d | finish no earlier than 2002-03-22 | N4 | 2824h | 2824h | Rel-5 | Kimmo |  |  |  |  |  |  |
| 5303 | 81.1.4.6 | **Service Examples (Work stopped)** | 304d | 2001-04-17 A | 2002-06-14 A | 100% | 2001-04-17 | 2002-06-14 | 304d |  | S1 | 4864h | 4864h | Rel-5 | Alain | IMS-Sex | 22.928 | Motorola | Mark Cataldo | IMS-Sex |  |
| 5304 | 81.1.4.6.1 | IMS Framework Report (work stopped) | 304d | 2001-04-17 A | 2002-06-14 A | 100% | 2001-04-17 | 2002-06-14 | 304d | finish no earlier than 2002-06-14 | S1 | 2432h | 2432h | Rel-5 | Alain | IMS-FrWk | 22.941 | SBC | Randolph Wohlert (rwohlert@tri.sbc.com) | IMS-FrWk |  |
| 5305 | 81.2 | **Access Security for IMS** | 190d | 2001-10-08 A | 2002-06-28 A | 100% | 2001-10-08 | 2002-06-28 | 190d |  | S3; T3 | 5640h | 5640h | Rel-5 | Mirko | IMS-ASEC |  | Ericsson | krister.boman@emw.ericsson.se | IMS-ASEC |  |
| 5306 | 81.2.2 | IMS impacts on UICC (ISIM application) | 185d | 2001-10-08 A | 2002-06-21 A | 100% | 2001-10-08 | 2002-06-21 | 185d | finish no earlier than 2002-06-21 | T3 | 1480h | 1480h | Rel-5 | Xavier |  | 33.102, New TS 31.103 | Vodafone | Jeremy Norris |  |  |
| 5307 | 81.2.3 | Deleted - SIP extensions for Integrity protection | 140d | 2001-12-17 A | 2002-06-28 A | 100% | 2001-12-17 | 2002-06-28 | 140d | finish no earlier than 2002-06-28 | N1 | 1120h | 1120h | Rel-5 | Frederic |  |  |  |  |  | SP-69 |
| 5308 | 81.3 | Security Aspects of Requirement for Network Configuration Independence | 130d | 2001-07-02 A | 2001-12-28 A | 100% | 2001-07-02 | 2001-12-28 | 130d | finish no earlier than 2001-12-28 | S3 | 1040h | 1040h | Rel-5 | Mirko | SEC1-NCI | 33.203 | AT&T Wireless | hugh.shieh@attws.com | SEC1-NCI |  |
| 5309 | 81.4 | IMS Lawful Interception | 410d | 2000-09-04 A | 2002-03-29 A | 100% | 2000-09-04 | 2002-03-29 | 410d | finish no earlier than 2002-03-29 | S3 | 3280h | 3280h | Rel-5 | Mirko | IMS-LI | 33.106, 33.107, New 33.108 | Reg TP | berthold.wilhelm@regtp.de | IMS-LI |  |
| 5310 | 81.5 | Charging and OAM&P for IMS | 383d | 2000-12-25 A | 2002-06-12 A | 100% | 2000-12-25 | 2002-06-12 | 383d | finish no earlier than 2002-06-12 | S5 | 3064h | 3064h | Rel-5 | Mirko | IMS-OAM | 32-series |  |  | IMS-OAM |  |
| 5311 | 81.6 | **Multimedia codecs and protocols for conversational PS services** | 568d | 2000-07-26 A | 2002-09-27 A | 100% | 2000-07-26 | 2002-09-27 | 568d |  | S4 | 15640h | 15640h | Rel-5 | Paolo | IMS-CODEC | 26.235, 26.236 | Toshiba, Nokia | B. Aronson (Toshiba), pasi.s.ojala@nokia.com | IMS-CODEC |  |
| 5312 | 81.6.1 | Codecs | 427d | 2000-07-26 A | 2002-03-14 A | 100% | 2000-07-26 | 2002-03-14 | 427d | finish no earlier than 2001-03-21 | S4 | 3416h | 3416h | Rel-5 | Paolo |  | 26.235, 26.236 |  |  |  |  |
| 5313 | 81.6.2 | Transport protocols | 1d | 2002-03-12 A | 2002-03-12 A | 100% | 2002-03-12 | 2002-03-12 | 1d | finish no earlier than 2002-03-12 | S4 | 8h | 8h | Rel-5 | Paolo |  | 26.236 | Nokia | P. Ojala |  |  |
| 5314 | 81.6.4 | recommendation for QoS parameter values for various media types | 195d | 2001-12-31 A | 2002-09-27 A | 100% | 2001-12-31 | 2002-09-27 | 195d | finish no earlier than 2002-09-27 | S4 | 1560h | 1560h | Rel-5 | Paolo |  |  |  |  |  |  |
| 5315 | 81.6.5 | IETF: RFC 3310 (HTTP Digest Authentication using AKA) | 382d | 2000-11-24 A | 2002-05-13 A | 100% | 2000-11-24 | 2002-05-13 | 382d | finish no earlier than 2002-05-13 | N1 | 3056h | 3056h | Rel-5 | Frederic |  |  |  |  |  |  |
| 5316 | 81.6.6 | IETF: RFC 3329 (Security mechanism agreement for SIP connections) | 382d | 2000-11-24 A | 2002-05-13 A | 100% | 2000-11-24 | 2002-05-13 | 382d | finish no earlier than 2002-05-13 | N1 | 3056h | 3056h | Rel-5 | Frederic |  |  |  |  |  |  |
| 5317 | 81.7 | **SIP message compression** | 185d | 2001-09-24 A | 2002-06-07 A | 100% | 2001-09-24 | 2002-06-07 | 185d |  | S2 | 3128h | 3128h | Rel-5 | Maurice |  |  |  |  |  |  |
| 5318 | 81.7.1 | Stage 2 for SIP message compression | 25d | 2001-09-24 A | 2001-10-26 A | 100% | 2001-09-24 | 2001-10-26 | 25d | finish no earlier than 2001-10-26 | S2 | 200h | 200h | Rel-5 | Maurice |  |  |  |  |  |  |
| 5319 | 81.7.2 | Compression signalling | 181d | 2001-09-28 A | 2002-06-07 A | 100% | 2001-09-28 | 2002-06-07 | 181d | finish no earlier than 2002-06-07 | N1 | 1448h | 1448h | Rel-5 | Frederic |  |  |  |  |  |  |
| 5320 | 81.8 | **Stage 3 description of IMS interfaces** | 383d | 2001-03-14 A | 2002-08-30 A | 100% | 2001-03-14 | 2002-08-30 | 383d |  | NP | 29531.6h | 29531.6h | Rel-5 | Kimmo |  |  |  |  |  |  |
| 5321 | 81.8.1 | Cx interface (HSS to CSCF) | 135.95d | 2001-03-14 A | 2002-06-07 A | 100% | 2001-03-14 | 2002-06-07 | 135.95d | finish no earlier than 2002-06-07 | N4 | 1087.58h | 1087.58h | Rel-5 | Kimmo |  |  |  |  |  |  |
| 5322 | 81.8.2 | Mp interface (MRFC - MRFP) enhancements | 258d | 2001-03-14 A | 2002-03-08 A | 100% | 2001-03-14 | 2002-03-08 | 258d | finish no earlier than 2002-06-07 | N4 | 2064h | 2064h | Rel-5 | Kimmo |  |  |  |  |  |  |
| 5323 | 81.8.3 | Mw interface (CSCF to P-CSCF) | 323d | 2001-03-14 A | 2002-06-07 A | 100% | 2001-03-14 | 2002-06-07 | 323d | finish no earlier than 2002-06-07 | N1 | 2584h | 2584h | Rel-5 | Frederic |  |  |  |  |  |  |
| 5324 | 81.8.4 | Mr interface (CSCF to MRF) | 273d | 2001-03-14 A | 2002-03-29 A | 100% | 2001-03-14 | 2002-03-29 | 273d | finish no earlier than 2002-03-29 | N1 | 2184h | 2184h | Rel-5 | Frederic |  |  |  |  |  |  |
| 5325 | 81.8.5 | Dx interface (I-CSCF to SLF) | 323d | 2001-03-14 A | 2002-06-07 A | 100% | 2001-03-14 | 2002-06-07 | 323d | finish no earlier than 2002-06-07 | N4 | 2584h | 2584h | Rel-5 | Kimmo |  |  |  |  |  |  |
| 5326 | 81.8.6 | Go interface (GGSN to PCF) | 323d | 2001-03-14 A | 2002-06-07 A | 100% | 2001-03-14 | 2002-06-07 | 323d | finish no earlier than 2002-06-07 | N3 | 2584h | 2584h | Rel-5 | Gwiho |  |  |  |  |  |  |
| 5327 | 81.8.7 | ISC (IMS Service Control) Interface | 323d | 2001-03-14 A | 2002-06-07 A | 100% | 2001-03-14 | 2002-06-07 | 323d | finish no earlier than 2002-06-07 | N1 | 2584h | 2584h | Rel-5 | Frederic |  |  |  |  |  |  |
| 5328 | 81.8.8 | Sh interface (HSS to AS) | 82d | 2002-02-14 A | 2002-06-07 A | 100% | 2002-02-14 | 2002-06-07 | 82d | finish no earlier than 2002-06-07 | N4 | 656h | 656h | Rel-5 | Kimmo |  |  |  |  |  |  |
| 5329 | 81.8.9 | Si interface (HSS to IM-SSF) | 162.5d | 2002-01-16 A | 2002-08-30 A | 100% | 2002-01-16 | 2002-08-30 | 162.5d | finish no earlier than 2002-06-07 | N4 | 1300h | 1300h | Rel-5 | Kimmo |  |  |  |  |  |  |
| 5330 | 81.8.10 | Gm interface (UE to CSCF) | 323d | 2001-03-14 A | 2002-06-07 A | 100% | 2001-03-14 | 2002-06-07 | 323d | finish no earlier than 2002-06-07 | N1 | 2584h | 2584h | Rel-5 | Frederic |  |  |  |  |  |  |
| 5331 | 81.8.11 | Mi interface (CSCF to BGCF) | 323d | 2001-03-14 A | 2002-06-07 A | 100% | 2001-03-14 | 2002-06-07 | 323d | finish no earlier than 2002-06-07 | N1 | 2584h | 2584h | Rel-5 | Frederic |  |  |  |  |  |  |
| 5332 | 81.8.12 | Mj interface (BGCF to MGCF) | 323d | 2001-03-14 A | 2002-06-07 A | 100% | 2001-03-14 | 2002-06-07 | 323d | finish no earlier than 2002-06-07 | N1 | 2584h | 2584h | Rel-5 | Frederic |  |  |  |  |  |  |
| 5333 | 81.8.13 | Mk interface (BGCF to BGCF) | 323d | 2001-03-14 A | 2002-06-07 A | 100% | 2001-03-14 | 2002-06-07 | 323d | finish no earlier than 2002-06-07 | N1 | 2584h | 2584h | Rel-5 | Frederic |  |  |  |  |  |  |
| 5334 | 81.9 | Support of VHE/OSA by entities and protocols of the IMS (e.g. CSCF) | 186d | 2001-09-21 A | 2002-06-07 A | 100% | 2001-09-21 | 2002-06-07 | 186d | finish no earlier than 2002-06-07 | N5 | 1488h | 1488h | Rel-5 | Kimmo | IMS-ONOSA | 29.198, 29.998 | Ericsson | Ard.Jan.Moerdijk@eln.ericsson.se | IMS-ONOSA |  |

Notes:
- 5300: -
- 5301: -
- 5302: Covered by 29.228 & 29228
- 5303: -
- 5304: -
- 5305: -
- 5306: -
- 5307: CN1 is not aware of any requirements and is not doing anything on this task
- 5308: Consider security aspects in SA2 TS 23.228 clause 4.4 & annex C
- 5309: SP#17 completed
- 5310: -
- 5311: -
- 5312: -
- 5313: -
- 5314: -
- 5315: -
- 5316: -
- 5317: -
- 5318: -
- 5319: -
- 5320: -
- 5321: -
- 5322: [DAB 08-03-02] - No work required in CN4
- 5323: -
- 5324: -
- 5325: CN4#11 30/11/01: No inputs received in CN4
- 5326: [DAB - 23/05/03] - 100 % complete
- 5327: -
- 5328: CN4#11 30/11/01: No inputs received in CN4
- 5329: SA16: Part of Rel5 only if completed in September 02. Marked as closed 12/2008 (was marked 72% complete)
- 5330: -
- 5331: -
- 5332: -
- 5333: -
- 5334: -

| ID | WBS | Task | Duration | Start | Finish | Predecessors | Complete | Baseline start | Baseline finish | Baseline duration | Constraint | Resources | Work | Actual work | Acronym | WI rapporteur name | WI rapporteur e-mail | Release | MCC resp | Acronym_3GU_Export | TSG stopped | Impacted TSs and TRs | PCG approved | TSG approved |
| --- | --- | --- | --- | --- | --- | --- | --- | --- | --- | --- | --- | --- | --- | --- | --- | --- | --- | --- | --- | --- | --- | --- | --- | --- |
| 5335 | 81.10 | **CAMEL control of IMS services** | 365d | 2001-04-16 A | 2002-09-06 A |  | 100% | 2001-04-16 | 2002-09-06 | 365d |  | N2 | 9952h | 9952h | IMS-CAMEL | Lucent | Angelica Remoquillo | Rel-5 | Kimmo | IMS-CAMEL |  |  |  |  |
| 5336 | 81.10.1 | Stage2 work 'general' | 365d | 2001-04-16 A | 2002-09-06 A |  | 100% | 2001-04-16 | 2002-09-06 | 365d | finish no earlier than 2002-09-06 | N2 | 2920h | 2920h |  |  |  | Rel-5 | Kimmo |  |  |  |  |  |
| 5337 | 81.10.2 | Stage3 work 'CAP' | 175d | 2002-01-07 A | 2002-09-06 A |  | 100% | 2002-01-07 | 2002-09-06 | 175d | finish no earlier than 2002-09-06 | N2 | 1400h | 1400h |  |  |  | Rel-5 | Kimmo |  |  |  |  |  |
| 5338 | 81.10.3 | Stage2 work 'Si interface' | 175d | 2002-01-07 A | 2002-09-06 A |  | 100% | 2002-01-07 | 2002-09-06 | 175d | finish no earlier than 2002-09-06 | N2 | 1400h | 1400h |  |  |  | Rel-5 | Kimmo |  |  |  |  |  |
| 5339 | 81.10.4 | Stage3 work 'Si interface' | 82d | 2002-02-14 A | 2002-06-07 A |  | 100% | 2002-02-14 | 2002-06-07 | 82d | finish no earlier than 2002-06-07 | N4 | 656h | 656h |  |  |  | Rel-5 | Kimmo |  |  |  |  |  |
| 5340 | 81.10.5 | Deleted - SDM issues for CAMEL control of IMS | 82d | 2002-02-14 A | 2002-06-07 A |  | 100% | 2002-02-14 | 2002-06-07 | 82d | finish no earlier than 2002-06-07 | N4 | 656h | 656h |  |  |  | Rel-5 | Kimmo |  | NP-17 |  |  |  |
| 5341 | 81.11 | Pre-pay/real-time charging in IMS | 196d | 2001-06-15 A | 2002-03-15 A |  | 100% | 2001-06-15 | 2002-03-15 | 196d | finish no earlier than 2002-03-15 | S1 | 1568h | 1568h |  |  |  | Rel-5 | Alain |  |  |  |  |  |
| 5342 | 81.12 | **IMS Charging** | 289d | 2001-08-06 A | 2002-09-12 A |  | 100% | 2001-08-06 | 2002-09-12 | 289d |  | S2; S5 | 8944h | 8944h | OAM-CH | T-Mobile | karl-heinz.nenner@t-mobile.de | Rel-5 | Mirko | OAM-CH |  | 32.225 |  |  |
| 5343 | 81.12.1 | Charging Implications of IMS architecture | 75d | 2001-08-06 A | 2001-11-16 A |  | 100% | 2001-08-06 | 2001-11-16 | 75d | finish no earlier than 2001-11-16 | S2 | 600h | 600h |  |  |  | Rel-5 | Maurice |  |  |  |  |  |
| 5344 | 81.12.2 | Charging management for IMS (off-line & on-line) | 214d | 2001-11-19 A | 2002-09-12 A | 5343 | 100% | 2001-11-19 | 2002-09-12 | 214d | finish no earlier than 2002-09-12 | S5 | 1712h | 1712h |  |  |  | Rel-5 | Mirko |  |  | 32.225 |  |  |
| 5345 | 86.1.6.10 | Billing, accounting and call detail record aspects | 251d | 2001-09-27 A | 2002-09-12 A |  | 100% | 2001-09-27 | 2002-09-12 | 251d | finish no earlier than 2002-09-12 | S5 | 2008h | 2008h |  | T-Mobile | Karl-Heinz.Nenner@T-MOBILE.DE | Rel-5 | Mirko |  |  | 32.225 |  |  |
| 5346 | 81.13 | **Other IETF dependencies** | 401d | 2000-11-24 A | 2002-06-07 A |  | 100% | 2000-11-24 | 2002-06-07 | 401d |  | NP | 9624h | 9624h |  |  |  | Rel-5 |  |  |  |  |  |  |
| 5347 | 81.13.1 | IETF: draft-ietf-aaa-diameter - should be CN4 | 401d | 2000-11-24 A | 2002-06-07 A |  | 100% | 2000-11-24 | 2002-06-07 | 401d | finish no earlier than 2002-06-07 | NP | 3208h | 3208h |  |  |  | Rel-5 |  |  |  |  |  |  |
| 5348 | 81.13.2 | IETF: draft-johansson-aaa-diameter-mm-app - should be CN4 | 401d | 2000-11-24 A | 2002-06-07 A |  | 100% | 2000-11-24 | 2002-06-07 | 401d | finish no earlier than 2002-06-07 | NP | 3208h | 3208h |  |  |  | Rel-5 |  |  |  |  |  |  |
| 5349 | 81.15 | Conformance Test Aspects - Provisioning of IMS | 205d | 2002-03-18 A | 2002-12-27 A |  | 100% | 2002-03-18 | 2002-12-27 | 205d | finish no earlier than 2002-12-27 | T1 | 1640h | 1640h | IMS-TEST |  |  | Rel-5 | Ingbert | IMS-TEST |  |  |  |  |
| 5350 | 81.16 | Testing of support for IMS - prose | 270d | 2002-09-18 A | 2003-09-30 A |  | 100% | 2002-09-18 | 2003-09-30 | 270d | finish no earlier than 2003-09-30 | T1 | 2160h | 2160h |  | Anritsu | dan.fox@eu.anritsu.com | Rel-5 | Ingbert |  |  | 34.108, 34.123 |  |  |
| 5351 | 81.17 | Testing of support for IMS - TTCN | 381d | 2002-09-18 A | 2004-03-03 A |  | 100% | 2002-09-18 | 2004-03-03 | 381d | finish no earlier than 2004-03-03 | T1 | 3048h | 3048h |  | Anritsu | dan.fox@eu.anritsu.com | Rel-5 | Ingbert |  |  | 34.108, 34.123 |  |  |
| 5352 | 1407 | UE Conformance Test Aspects – IMS for Converged IP Communications | 263d? | 2016-12-14 A | 2017-12-15 A |  | 100% |  |  |  | finish no earlier than 2017-12-15 | R5 | 2104h | 2104h | IMS_CONV_IP_COM-UEConTest | Rohnert, Hans | Hans.Rohnert.ext@rohde-schwarz.com | Rel-5 |  |  |  | TS 34.229-1, TS 34.229-2, TS 34.229-3 | 38 | 74 |
| 5353 | 82 | **Extended Transparent End-to-End PS Streaming Service** | 313d? | 2002-01-03 A | 2003-03-17 A |  | 100% | 2002-01-03 | 2003-03-17 | 313d? |  | S4 | 6224h | 6224h | PSS-E | Ericsson | olle.franceschi@ericsson.com | Rel-5 | Paolo | PSS-E |  | 26.233, 26.234 |  |  |
| 5354 | 82.1 | **Stage 1 for Extended Transparent End-to-End PS Streaming Service** | 86d? | 2002-11-18 A | 2003-03-17 A |  | 100% | 2002-11-18 | 2003-03-17 | 86d? |  | S1 | 1376h | 1376h |  | Vodafone | stephen.wolak@vodafone.com | Rel-5 | Alain |  |  | 22.233 |  |  |
| 5355 | 1408.1.1 | Interaction with other services | 86d? | 2002-11-18 A | 2003-03-17 A |  | 100% | 2002-11-18 | 2003-03-17 | 86d? | finish no earlier than 2003-03-17 | S1 | 688h | 688h |  | Vodafone | stephen.wolak@vodafone.com | Rel-5 | Alain |  |  | 22.233 |  |  |
| 5356 | 82.2 | Stage 2 (version Rel-5 of TS 26.234) | 51d | 2002-01-03 A | 2002-03-14 A |  | 100% | 2002-01-03 | 2002-03-14 | 51d | finish no earlier than 2002-03-26 | S4 | 408h | 408h |  |  |  | Rel-5 | Paolo |  |  | 26.234 |  |  |
| 5357 | 82.3 | RTP usage model | 242d | 2002-01-03 A | 2002-12-06 A |  | 100% | 2002-01-03 | 2002-12-06 | 242d | finish no earlier than 2002-12-06 | S4 | 1936h | 1936h |  |  |  | Rel-5 | Paolo |  |  | 26.937 |  |  |
| 5358 | 83 | **Rel-5 Open Service Access (OSA) enhancements** | 955d | 1999-04-27 A | 2002-12-20 A |  | 100% | 1999-04-27 | 2002-12-20 | 955d |  | S1; S3 | 72648h | 72648h | OSA1 | Siemens | joerg.swetina@neclab.eu | Rel-5 | Alain | OSA1 |  | 22.127, 23.127, 29.198-x, 29.998-x |  |  |
| 5359 | 83.1 | General Stage 2 for Rel-5 | 194d | 2001-09-11 A | 2002-06-07 A |  | 100% | 2001-09-11 | 2002-06-07 | 194d |  | S2 | 1232h | 1232h |  |  |  | Rel-5 | Maurice |  |  |  |  |  |

Notes:
- 5335: -
- 5336: DAB 12.12.01 split into cn4 and cn2 parts
- 5337: DAB 12.12.01 split into cn4 and cn2 parts
- 5338: DAB 12.12.01 split into cn4 and cn2 parts
- 5339: [DAB 08-03-02] - UID 12004 is MASTER of UID 14998
- 5340: Marked as stopped 12/2008
- 5341: Marked as closed 12/2008 (was marked 60% complete)
- 5342: -
- 5343: -
- 5344: -
- 5345: -
- 5346: Was introduced at SP#13 by Ileana Leuca (exact position in the WP and related WG have to be defined)
- 5347: Marked as closed 12/2008 (was marked 90% complete)
- 5348: Marked as closed 12/2008 (was marked 50% complete)
- 5349: The task is a BB, individual work items were considered but are constrained by lack of supporting companies. Marked as stopped 12/2008
- 5350: Marked as stopped 12/2008
- 5351: Marked as stopped 12/2008
- 5352: UID: 740999->740068; Rel-14->Rel-519/9/17: Compl:0%->75%; ...; 8/1/18: Compl:75%->100%
- 5353: -
- 5354: 2nd resp SA4
- 5355: 2nd resp SA4. Marked as closed 12/2008 (was marked 65% complete)
- 5356: 2nd resp SA2
- 5357: Marked as closed 12/2008 (was marked 90% complete)
- 5358: -
- 5359: Marked as closed 12/2008 (was marked 47% complete)

| ID | WBS | Task | Duration | Start | Finish | Predecessors | Complete | Baseline start | Baseline finish | Baseline duration | Constraint | Resources | Work | Actual work | Acronym | Release | MCC resp | Acronym_3GU_Export | Impacted TSs and TRs | WI rapporteur name | WI rapporteur e-mail |
| --- | --- | --- | --- | --- | --- | --- | --- | --- | --- | --- | --- | --- | --- | --- | --- | --- | --- | --- | --- | --- | --- |
| 5360 | 83.2 | **OSA APIs for Multimedia Call Control** | 499d | 2000-07-11 A | 2002-06-07 A |  | 100% | 2000-07-11 | 2002-06-07 | 499d |  | S2 | 5960h | 5960h | OSA1-CSCF | Rel-5 | Maurice | OSA1-CSCF |  |  |  |
| 5361 | 83.2.1 | Stage 1 for OSA APIs for Multimedia Call Control | 438d | 2000-07-11 A | 2002-03-14 A |  | 100% | 2000-07-11 | 2002-03-14 | 438d | finish no earlier than 2002-03-14 | S1 | 3504h | 3504h |  | Rel-5 | Alain |  | 22.127 | Siemens | Manfred.leitgeb@siemens.at |
| 5362 | 83.2.2 | Stages 2 and 3 for Multimedia Call Control | 194d | 2001-09-11 A | 2002-06-07 A |  | 100% | 2001-09-11 | 2002-06-07 | 194d | finish no earlier than 2002-06-07 | N5 | 1552h | 1552h |  | Rel-5 | Kimmo |  | 29.198-04 |  |  |
| 5363 | 83.3 | Generic user interaction - Stage 3 | 194d | 2001-09-11 A | 2002-06-07 A |  | 100% | 2001-09-11 | 2002-06-07 | 194d | finish no earlier than 2002-06-07 | N5 | 1552h | 1552h |  | Rel-5 | Kimmo |  | 29.198-05 |  |  |
| 5364 | 83.4 | OSA Charging - Stage 3 | 194d | 2001-09-11 A | 2002-06-07 A |  | 100% | 2001-09-11 | 2002-06-07 | 194d | finish no earlier than 2002-06-07 | N5 | 1552h | 1552h |  | Rel-5 | Kimmo |  | 29.198-12 |  |  |
| 5365 | 83.5 | Call Control Service Mapping; Multiparty Call Control SIP - Stage 3 | 194d | 2001-09-11 A | 2002-06-07 A |  | 100% | 2001-09-11 | 2002-06-07 | 194d | finish no earlier than 2002-06-07 | N5 | 1552h | 1552h |  | Rel-5 | Kimmo |  | 29.998-04-4 |  |  |
| 5366 | 83.6 | WSDL APIs for SOAP/HTTP - Stage 3 | 455d | 2000-09-11 A | 2002-06-07 A |  | 100% | 2000-09-11 | 2002-06-07 | 455d | finish no earlier than 2002-06-07 | N5 | 3640h | 3640h |  | Rel-5 | Kimmo |  | 29.198, 29.998 |  |  |
| 5367 | 83.7 | **OSA Security** | 639d | 2000-07-11 A | 2002-12-20 A |  | 100% | 2000-07-11 | 2002-12-20 | 639d |  | S3 | 15000h | 15000h | OSA1-SEC | Rel-5 | Mirko | OSA1-SEC | 33.102 | Ericsson | colin.blanchard@bt.com |
| 5368 | 83.7.1 | Stage 1 for OSA Security | 349d | 2000-07-11 A | 2001-11-09 A |  | 100% | 2000-07-11 | 2001-11-09 | 349d | finish no earlier than 2001-11-09 | S1 | 2792h | 2792h |  | Rel-5 | Alain |  | 22.127 | Siemens | Manfred.leitgeb@siemens.at |
| 5369 | 83.7.2 | OSA Stage 3 | 430d | 2000-10-23 A | 2002-06-14 A |  | 100% | 2000-10-23 | 2002-06-14 | 430d | finish no earlier than 2002-06-14 | S3 | 3440h | 3440h |  | Rel-5 | Mirko |  | 33.102 | BT, Ericsson | colin.blanchard@bt.com |
| 5370 | 83.7.3 | security related SCF(s) definition | 186d | 2001-09-21 A | 2002-06-07 A |  | 100% | 2001-09-21 | 2002-06-07 | 186d | finish no earlier than 2002-06-07 | N5 | 1488h | 1488h |  | Rel-5 | Kimmo |  | 29.198, 29.998 | Ericsson | Ard.Jan.Moerdijk@eln.ericsson.se |
| 5371 | 83.7.4 | OSA changes required from supporting platforms, e.g. gsmSCF, HLR | 69d | 2000-09-11 A | 2000-12-14 A |  | 100% | 2000-09-11 | 2000-12-14 | 69d | finish no earlier than 2000-12-14 | S3 | 552h | 552h |  | Rel-5 | Mirko |  | 33.102 | BT, Ericsson | colin.blanchard@bt.com |
| 5372 | 1409.7.5 | OSA Security (moved from Rel-6) | 202d | 2002-03-14 A | 2002-12-20 A |  | 100% | 2002-03-14 | 2002-12-20 | 202d | finish no earlier than 2002-12-20 | S3 | 1616h | 1616h |  | Rel-5 | Mirko |  | 33.102 | BT, Ericsson | colin.blanchard@bt.com |
| 5373 | 83.8 | **Interactions OSA - e-commerce** | 815d | 1999-04-27 A | 2002-06-07 A |  | 100% | 1999-04-27 | 2002-06-07 | 815d |  | S2 | 6152h | 6152h | OSA1-ECOM | Rel-5 | Maurice | OSA1-ECOM |  |  |  |
| 5374 | 83.8.1 | Stage 1 for Interactions OSA - e-commerce | 439d | 1999-04-27 A | 2000-12-28 A |  | 100% | 1999-04-27 | 2000-12-28 | 439d | finish no earlier than 2000-12-28 | S1 | 3504h | 3504h |  | Rel-5 | Alain |  | 22.127 | Siemens | joerg.swetina@neclab.eu |
| 5375 | 83.8.2 | Stages 2 and 3 for Interactions OSA - e-commerce | 186d | 2001-09-21 A | 2002-06-07 A |  | 100% | 2001-09-21 | 2002-06-07 | 186d | finish no earlier than 2002-06-07 | N5 | 1488h | 1488h |  | Rel-5 | Kimmo |  | 29.198, 29.998 | Ericsson | Ard.Jan.Moerdijk@eln.ericsson.se |
| 5376 | 83.9 | Policy Management - Stage 3 | 194d | 2001-09-11 A | 2002-06-07 A |  | 100% | 2001-09-11 | 2002-06-07 | 194d | finish no earlier than 2002-06-07 | N5 | 1552h | 1552h |  | Rel-5 | Kimmo |  | 29.198-13 |  |  |
| 5377 | 83.10 | Presence and Availability Management (PAM) - Stage 3 | 194d | 2001-09-11 A | 2002-06-07 A |  | 100% | 2001-09-11 | 2002-06-07 | 194d | finish no earlier than 2002-06-07 | N5 | 1552h | 1552h |  | Rel-5 | Kimmo |  | 29.198-14 |  |  |
| 5378 | 83.11 | **LCS - OSA interfaces** | 455d | 2000-09-11 A | 2002-06-07 A |  | 100% | 2000-09-11 | 2002-06-07 | 455d |  | S1 | 5656h | 5656h | OSA1-LCSI | Rel-5 | Alain | OSA1-LCSI |  | Siemens | joerg.swetina@neclab.eu |
| 5379 | 83.11.1 | Stage 1 for LCS - OSA interfaces | 65d | 2000-09-11 A | 2000-12-08 A |  | 100% | 2000-09-11 | 2000-12-08 | 65d | finish no earlier than 2000-12-08 | S1 | 520h | 520h |  | Rel-5 | Alain |  | 22.127 | Siemens | joerg.swetina@neclab.eu |
| 5380 | 83.11.2 | Stage 2 for LCS - OSA interfaces | 1d | 2000-12-11 A | 2000-12-11 A | 5379 | 100% | 2000-12-11 | 2000-12-11 | 1d | finish no earlier than 2000-12-11 | S2 | 8h | 8h |  | Rel-5 | Maurice |  | 23.127 | Ericsson | Christophe GOURRAUD |
| 5381 | 83.11.3 | Stage 3 for LCS - OSA interfaces | 186d | 2001-09-21 A | 2002-06-07 A | 5380 | 100% | 2001-09-21 | 2002-06-07 | 186d | finish no earlier than 2002-06-07 | N5 | 1488h | 1488h |  | Rel-5 | Kimmo |  | 29.198, 29.998 | Ericsson | Ard.Jan.Moerdijk@eln.ericsson.se |
| 5382 | 1409.12 | Access to User Profile | 145d | 2001-06-01 A | 2001-12-20 A |  | 100% | 2001-06-01 | 2001-12-20 | 145d | finish no earlier than 2001-12-20 | S1 | 1160h | 1160h | OSA2-UP | Rel-5 | Alain | OSA2-UP |  |  |  |
| 5383 | 1409.13 | **Retrieval of Terminal capabilities** | 634d | 2000-07-11 A | 2002-12-13 A |  | 100% | 2000-07-11 | 2002-12-13 | 634d |  | S2 | 10808h | 10808h | OSA2-TC | Rel-5 | Maurice | OSA2-TC |  |  |  |
| 5384 | 1409.13.1 | Stage 1 for Retrieval of Terminal capabilities | 132d | 2000-07-11 A | 2001-01-10 A |  | 100% | 2000-07-11 | 2001-01-10 | 132d | finish no earlier than 2001-01-10 | S1 | 1056h | 1056h |  | Rel-5 | Alain |  | 22.127 | Siemens | joerg.swetina@neclab.eu |
| 5385 | 1409.13.2 | Stages 2 and 3 for Retrieval of Terminal capabilities | 321d | 2001-09-21 A | 2002-12-13 A | 5384 | 100% | 2001-09-21 | 2002-12-13 | 321d | finish no earlier than 2002-12-13 | N5 | 2568h | 2568h |  | Rel-5 | Kimmo |  | 29.198, 29.998 | Ericsson | Ard.Jan.Moerdijk@eln.ericsson.se |
| 5386 | 1409.13.3 | Provisioning of the terminal capabilities | 445d | 2001-04-02 A | 2002-12-13 A |  | 100% | 2001-04-02 | 2002-12-13 | 445d | finish no earlier than 2002-12-13 | T2 | 3560h | 3560h |  | Rel-5 |  |  | 23.057 |  |  |

Notes:
- 5360: For Rel5 even if completed by March
- 5361: -
- 5362: -
- 5363: -
- 5364: -
- 5365: -
- 5366: -
- 5367: SP#8 approved WID
- 5368: -
- 5369: SP#8 approved WID
- 5370: -
- 5371: SP#8 approved WID
- 5372: SP#8 approved WID
- 5373: -
- 5374: Marked as closed 12/2008 (was marked 95% complete)
- 5375: -
- 5376: -
- 5377: -
- 5378: az: CN#13 - changed to Rel5
- 5379: -
- 5380: az 24/05/01: Rel4 completion 90->100%.
- 5381: -
- 5382: -
- 5383: -
- 5384: -
- 5385: -
- 5386: According to T2 SWG1 M. Cataldo this is automatically supported by the MExE support of UAProf therefore 100% complete

| ID | WBS | Task | Duration | Start | Finish | Predecessors | Complete | Baseline start | Baseline finish | Baseline duration | Constraint | Resources | Work | Actual work | Acronym | WI rapporteur name | WI rapporteur e-mail | Release | MCC resp | Acronym_3GU_Export | Impacted TSs and TRs |
| --- | --- | --- | --- | --- | --- | --- | --- | --- | --- | --- | --- | --- | --- | --- | --- | --- | --- | --- | --- | --- | --- |
| 5387 | 84 | **CAMEL phase 4** | 625d | 2000-04-17 A | 2002-09-06 A |  | 100% | 2000-04-17 | 2002-09-06 | 625d |  | S1 | 41104h | 41104h | CAMEL4 | Nokia | keijo.palviainen@nokia.com | Rel-5 | Alain | CAMEL4 |  |
| 5388 | 84.1 | Service requirements | 565d | 2000-04-17 A | 2002-06-14 A |  | 100% | 2000-04-17 | 2002-06-14 | 565d | finish no earlier than 2002-06-14 | S1 | 4520h | 4520h |  |  |  | Rel-5 | Alain |  |  |
| 5389 | 84.2 | Call Party Handling | 500d | 2000-07-10 A | 2002-06-07 A |  | 100% | 2000-07-10 | 2002-06-07 | 500d | finish no earlier than 2002-06-07 | N2 | 4000h | 4000h | CAMEL4-CPH |  |  | Rel-5 | Kimmo | CAMEL4-CPH |  |
| 5390 | 84.3 | Mid call procedure for MO and MT calls | 495d | 2000-07-17 A | 2002-06-07 A |  | 100% | 2000-07-17 | 2002-06-07 | 495d | finish no earlier than 2002-06-07 | N2 | 3960h | 3960h | CAMEL4-MCP |  |  | Rel-5 | Kimmo | CAMEL4-MCP |  |
| 5391 | 84.4 | Interactions with Optimal Routing | 430d | 2000-07-17 A | 2002-03-08 A |  | 100% | 2000-07-17 | 2002-03-08 | 430d | finish no earlier than 2002-03-08 | N2 | 3440h | 3440h | CAMEL4-IOR |  |  | Rel-5 | Kimmo | CAMEL4-IOR |  |
| 5392 | 84.5 | Inclusion of flexible tone injection | 430d | 2000-07-17 A | 2002-03-08 A |  | 100% | 2000-07-17 | 2002-03-08 | 430d | finish no earlier than 2002-03-08 | N2 | 3440h | 3440h | CAMEL4-IFTI |  |  | Rel-5 | Kimmo | CAMEL4-IFTI |  |
| 5393 | 84.6 | CSE control over MT SMS | 430d | 2000-07-17 A | 2002-03-08 A |  | 100% | 2000-07-17 | 2002-03-08 | 430d | finish no earlier than 2002-03-08 | N2 | 3440h | 3440h | CAMEL4-CCSMS |  |  | Rel-5 | Kimmo | CAMEL4-CCSMS |  |
| 5394 | 84.7 | Notification of GPRS mobility management to CSE | 331d | 2001-03-02 A | 2002-06-07 A |  | 100% | 2001-03-02 | 2002-06-07 | 331d | finish no earlier than 2002-06-07 | N2 | 2648h | 2648h | CAMEL4-NMM |  |  | Rel-5 | Kimmo | CAMEL4-NMM |  |
| 5395 | 84.8 | Provision of location information of called subscriber | 266d | 2001-03-02 A | 2002-03-08 A |  | 100% | 2001-03-02 | 2002-03-08 | 266d | finish no earlier than 2002-03-08 | N2 | 2128h | 2128h | CAMEL4-LOCB |  |  | Rel-5 | Kimmo | CAMEL4-LOCB |  |
| 5396 | 84.9 | Inclusion of ODB data in the CSE_HLR interface | 175d | 2001-07-09 A | 2002-03-08 A |  | 100% | 2001-07-09 | 2002-03-08 | 175d | finish no earlier than 2002-03-08 | N2 | 1400h | 1400h | CAMEL4-ODB |  |  | Rel-5 | Kimmo | CAMEL4-ODB |  |
| 5397 | 84.10 | Location information during an ongoing call (Handover DP) | 280d | 2001-05-14 A | 2002-06-07 A |  | 100% | 2001-05-14 | 2002-06-07 | 280d | finish no earlier than 2002-06-07 | N2 | 2240h | 2240h | CAMEL4-HODP |  |  | Rel-5 | Kimmo | CAMEL4-HODP |  |
| 5398 | 84.11 | GPRS Any Time Interrogation | 240d | 2001-07-09 A | 2002-06-07 A |  | 100% | 2001-07-09 | 2002-06-07 | 240d | finish no earlier than 2002-06-07 | N2 | 1920h | 1920h | CAMEL4-ATI |  |  | Rel-5 | Kimmo | CAMEL4-ATI |  |
| 5399 | 84.12 | Transfer of IMEI (with SW version) to CSE (CAMEL4-ATI) | 240d | 2001-07-09 A | 2002-06-07 A |  | 100% | 2001-07-09 | 2002-06-07 | 240d | finish no earlier than 2002-06-07 | N2 | 1920h | 1920h |  |  |  | Rel-5 | Kimmo |  |  |
| 5400 | 84.13 | Handling of partial implementations of CAMEL4 | 131d | 2002-03-08 A | 2002-09-06 A |  | 100% | 2002-03-08 | 2002-09-06 | 131d | finish no earlier than 2002-06-07 | N2 | 1048h | 1048h | CAMEL4-SUB |  |  | Rel-5 | Kimmo | CAMEL4-SUB |  |
| 5401 | 85 | **Rel-5 MExE enhancements** | 250d | 2001-03-26 A | 2002-03-08 A |  | 100% | 2001-03-26 | 2002-03-08 | 250d |  | T2 | 2880h | 2880h | MEXE5 |  |  | Rel-5 | Kimmo | MEXE5 |  |
| 5402 | 85.1 | MExE Rel-5 Improvements and Investigations | 110d | 2001-03-26 A | 2002-03-08 A |  | 100% | 2001-03-26 | 2002-03-08 | 110d | finish no earlier than 2001-12-17 | T2 | 880h | 880h | MEXE5-ENHANC | Motorola | Mark Cataldo | Rel-5 | Kimmo | MEXE5-ENHANC | 22.057, 23.057 |
| 5403 | 86 | **Wideband Telephony Service - AMR** | 1036d | 2000-01-01 A | 2003-12-19 A |  | 100% | 2000-01-01 | 2003-12-19 | 1036d |  | S4 | 75408h | 75408h | AMRWB | Siemens | Imre.Varga@mch.siemens.de | Rel-5 | Paolo | AMRWB |  |
| 5404 | 86.1 | **Specification** | 636d | 2000-01-01 A | 2002-06-07 A |  | 100% | 2000-01-01 | 2002-06-07 | 636d |  | S4 | 19984h | 19984h |  |  |  | Rel-5 | Paolo |  |  |
| 5405 | 86.1.1 | Stage 1 for Wideband Telephony Service - AMR | 125d | 2001-10-01 A | 2002-03-22 A |  | 100% | 2001-10-01 | 2002-03-22 | 125d | finish no earlier than 2002-03-22 | S1 | 1000h | 1000h |  |  |  | Rel-5 | Alain |  |  |
| 5406 | 86.1.2 | **Stage 2 for Wideband Telephony Service - AMR** | 77d | 2000-01-03 A | 2000-04-17 A |  | 100% | 2000-01-03 | 2000-04-17 | 77d |  | S4 | 1232h | 1232h |  |  |  | Rel-5 | Paolo |  |  |
| 5407 | 86.1.2.1 | Design Constraints for Wideband Telephony Service - AMR | 27d | 2000-01-03 A | 2000-02-07 A |  | 100% | 2000-01-03 | 2000-02-07 | 27d |  | S4 | 208h | 208h |  |  |  | Rel-5 | Paolo |  |  |
| 5408 | 86.1.2.2 | General Description for Wideband Telephony Service - AMR | 51d | 2000-02-07 A | 2000-04-17 A | 5407 | 100% | 2000-02-07 | 2000-04-17 | 51d | start no earlier than 2000-09-25 | S4 | 408h | 408h |  |  |  | Rel-5 | Paolo |  |  |
| 5409 | 86.1.3 | Feasibility Study for Wideband Telephony Service - AMR | 26d | 2000-04-28 A | 2000-06-02 A | 5408 | 100% | 2000-04-28 | 2000-06-02 | 26d | finish no earlier than 2000-06-02 | S4 | 208h | 208h |  |  |  | Rel-5 | Paolo |  | 26.901 |
| 5410 | 86.1.4 | N1 Aspects for Wideband Telephony Service - AMR | 66d | 2001-09-21 A | 2001-12-21 A |  | 100% | 2001-09-21 | 2001-12-21 | 66d | finish no earlier than 2001-12-21 | N1 | 528h | 528h |  |  |  | Rel-5 | Frederic |  |  |
| 5411 | 86.1.5 | N4 work for Wideband Telephony Service - AMR | 83d | 2002-02-13 A | 2002-06-07 A |  | 100% | 2002-02-13 | 2002-06-07 | 83d | finish no earlier than 2002-06-07 | N4 | 664h | 664h |  |  |  | Rel-5 | Kimmo |  |  |

Notes:
- 5387: -
- 5388: -
- 5389: -
- 5390: -
- 5391: -
- 5392: -
- 5393: -
- 5394: -
- 5395: -
- 5396: Added on May 29, 2001
- 5397: -
- 5398: -
- 5399: -
- 5400: stage2 and stage3 CRs for approval at CN#17
- 5401: -
- 5402: -
- 5403: -
- 5404: -
- 5405: -
- 5406: -
- 5407: -
- 5408: -
- 5409: S4,TD SP-000024: TR 26.901 v.4.0.0
- 5410: Some of N1 tasks: Indication of supported codecs by the MS, Bearer cap negociation, codec indication to MS
- 5411: CN4#11 30/11/01: No inputs to CN4 at this meeting

| ID | WBS | Task | Duration | Start | Finish | Predecessors | Complete | Baseline start | Baseline finish | Baseline duration | Constraint | Resources | Work | Actual work | Release | MCC resp | Acronym | Acronym_3GU_Export | Impacted TSs and TRs | TSG stopped | WI rapporteur name | WI rapporteur e-mail |
| --- | --- | --- | --- | --- | --- | --- | --- | --- | --- | --- | --- | --- | --- | --- | --- | --- | --- | --- | --- | --- | --- | --- |
| 5412 | 86.1.6 | **Codec issues** | 636d | 2000-01-03 A | 2002-06-07 A |  | 100% | 2000-01-03 | 2002-06-07 | 636d |  | S4 | 9496h | 9496h | Rel-5 | Paolo |  |  |  |  |  |  |
| 5413 | 86.1.6.1 | Codec qualification | 86d | 2000-02-02 A | 2000-05-31 A |  | 100% | 2000-02-02 | 2000-05-31 | 86d | finish no earlier than 2000-05-31 | S4 | 688h | 688h | Rel-5 | Paolo |  |  |  |  |  |  |
| 5414 | 86.1.6.2 | Codec selection tests | 102d | 2000-06-01 A | 2000-10-20 A | 5413 | 100% | 2000-06-01 | 2000-10-20 | 102d | finish no earlier than 2000-10-20 | S4 | 816h | 816h | Rel-5 | Paolo |  |  |  |  |  |  |
| 5415 | 86.1.6.3 | Codec selection | 5d | 2000-10-23 A | 2000-10-27 A | 5414 | 100% | 2000-10-23 | 2000-10-27 | 5d | finish no earlier than 2000-10-27 | S4 | 40h | 40h | Rel-5 | Paolo |  |  |  |  |  |  |
| 5416 | 86.1.6.4 | TFO AMR-WB | 63d | 2001-12-18 A | 2002-03-14 A |  | 100% | 2001-12-18 | 2002-03-14 | 63d | finish no earlier than 2002-03-14 | S4 | 504h | 504h | Rel-5 | Paolo | AMRWB-TFO | AMRWB-TFO |  |  |  |  |
| 5417 | 86.1.6.5 | Other codec issues (verif., characterization) | 441d | 2000-09-29 A | 2002-06-07 A |  | 100% | 2000-09-29 | 2002-06-07 | 441d | finish no earlier than 2002-06-07 | S4 | 3528h | 3528h | Rel-5 | Paolo |  |  | 26.976 |  |  |  |
| 5418 | 86.1.6.6 | AMR-WB and narrrowband interworking | 121d | 2001-09-27 A | 2002-03-14 A |  | 100% | 2001-09-27 | 2002-03-14 | 121d | finish no earlier than 2002-03-14 | S4 | 968h | 968h | Rel-5 | Paolo | AMRWB-IWG | AMRWB-IWG |  |  |  |  |
| 5419 | 86.1.6.7 | Interworking with fixed broadband networks | 121d | 2001-09-27 A | 2002-03-14 A |  | 100% | 2001-09-27 | 2002-03-14 | 121d | finish no earlier than 2002-03-14 | S4 | 968h | 968h | Rel-5 | Paolo |  |  |  |  |  |  |
| 5420 | 86.1.6.8 | Tones and announcements | 121d | 2001-09-27 A | 2002-03-14 A |  | 100% | 2001-09-27 | 2002-03-14 | 121d | finish no earlier than 2002-03-14 | S4 | 968h | 968h | Rel-5 | Paolo |  |  |  |  |  |  |
| 5421 | 86.1.6.9 | Deleted - WB Conferencing and WB Voice Group calls | 1d | 2000-01-03 A | 2000-01-03 A |  | 100% | 2000-01-03 | 2000-01-03 | 1d | finish no earlier than 2000-01-03 | S1 | 8h | 8h | Rel-5 | Alain |  |  |  | SP-07 |  |  |
| 5422 | 86.1.8 | **Conformance tests (CRs to 34 series)** | 74d | 2000-01-01 A | 2000-04-12 A |  | 100% | 2000-01-01 | 2000-04-12 | 74d |  | T1 | 1768h | 1768h | Rel-5 | Ingbert |  |  |  |  |  |  |
| 5423 | 86.1.8.1 | **Terminal Acoustic Characteristics** | 74d | 2000-01-01 A | 2000-04-12 A |  | 100% | 2000-01-01 | 2000-04-12 | 74d |  | S4 | 1176h | 1176h | Rel-5 | Paolo |  |  |  |  |  |  |
| 5424 | 86.1.8.1.1 | Definition for Terminal Acoustic Characteristics | 22d | 2000-01-01 A | 2000-01-31 A |  | 100% | 2000-01-01 | 2000-01-31 | 22d | finish no earlier than 2000-01-28 | S4 | 168h | 168h | Rel-5 | Paolo |  |  | 26.131 |  |  |  |
| 5425 | 86.1.8.1.2 | Test specification for Terminal Acoustic Characteristics | 52d | 2000-02-01 A | 2000-04-12 A | 5424 | 100% | 2000-02-01 | 2000-04-12 | 52d | finish no earlier than 2000-03-13 | S4 | 416h | 416h | Rel-5 | Paolo |  |  | 26.132 |  |  |  |
| 5426 | 86.2 | Floating-point ANSI-C code for the AMR-WB speech codec | 123d | 2001-09-25 A | 2002-03-14 A |  | 100% | 2001-09-25 | 2002-03-14 | 123d | finish no earlier than 2002-03-14 | S4 | 984h | 984h | Rel-5 | Paolo | AMRWB-FP | AMRWB-FP | 26.204 |  | Nokia | janne.m.vainio@nokia.com |
| 5427 | 86.3 | **Support of AMR-WB in GERAN: GMSK and 8PSK WB FR / HR** | 651d | 2000-01-03 A | 2002-06-28 A |  | 100% | 2000-01-03 | 2002-06-28 | 651d |  | GP | 23488h | 23488h | Rel-5 | Paolo | GAMRWB | GAMRWB |  |  |  |  |
| 5428 | 86.3.1 | Channel coding in 45.003 for Support of AMR-WB in GERAN: GMSK and 8PSK WB FR / HR | 591d | 2000-01-03 A | 2002-04-05 A |  | 100% | 2000-01-03 | 2002-04-05 | 591d |  | GP | 4720h | 4720h | Rel-5 | Paolo |  |  |  |  |  |  |
| 5429 | 86.3.2 | Signalling for the A interface | 391d | 2000-01-03 A | 2001-06-29 A |  | 100% | 2000-01-03 | 2001-06-29 | 391d | finish no earlier than 2001-06-29 | GP | 3120h | 3120h | Rel-5 | Paolo |  |  |  |  |  |  |
| 5430 | 86.3.3 | Signalling for Iu | 651d | 2000-01-03 A | 2002-06-28 A |  | 100% | 2000-01-03 | 2002-06-28 | 651d | finish no earlier than 2002-06-28 | GP | 5200h | 5200h | Rel-5 | Paolo |  |  |  |  |  |  |
| 5431 | 86.3.4 | Receiver performance in TS 45.005 | 325d | 2001-04-02 A | 2002-06-28 A |  | 100% | 2001-04-02 | 2002-06-28 | 325d | finish no earlier than 2002-06-28 | GP | 2600h | 2600h | Rel-5 | Paolo |  |  |  |  |  |  |
| 5432 | 86.3.5 | Link Adaptation in 45.009 | 330d | 2001-03-26 A | 2002-06-28 A |  | 100% | 2001-03-26 | 2002-06-28 | 330d | finish no earlier than 2002-06-28 | GP | 2640h | 2640h | Rel-5 | Paolo |  |  |  |  |  |  |
| 5433 | 86.4 | **Deleted - GERAN MS conformance test for AMR-WB** | 1036d | 2000-01-03 A | 2003-12-19 A |  | 100% | 2000-01-03 | 2003-12-19 | 1036d |  | GP | 16568h | 16568h | Rel-5 | Paolo |  |  |  | SP-69 |  |  |
| 5434 | 86.4.1 | Deleted - MS test for AMR-WB | 1036d | 2000-01-03 A | 2003-12-19 A |  | 100% | 2000-01-03 | 2003-12-19 | 1036d | finish no earlier than 2003-12-19 | GP | 8280h | 8280h | Rel-5 | Paolo |  |  |  | GP-17 |  |  |
| 5435 | 86.5 | GERAN BTS conformance test for AMR-WB | 762d | 2000-01-03 A | 2002-12-02 A |  | 100% | 2000-01-03 | 2002-12-02 | 762d |  | GP | 6096h | 6096h | Rel-5 | Paolo |  |  |  |  |  |  |

Notes:
- 5412: -
- 5413: -
- 5414: -
- 5415: -
- 5416: -
- 5417: ANSI C-Code , Test Sequences, Speech Transcoding Functions, Error Concealment of lost frames, Source Controlled Bit-Rate Operation, Voice Activity Detector, Frame Structure
- 5418: -
- 5419: -
- 5420: -
- 5421: -
- 5422: -
- 5423: -
- 5424: -
- 5425: -
- 5426: -
- 5427: -
- 5428: 50098 -> 50298
- 5429: -
- 5430: -
- 5431: -
- 5432: -
- 5433: Not started 02/2003. Marked as stopped 12/2008
- 5434: Marked as stopped 12/2008
- 5435: -

| ID | WBS | Task | Duration | Start | Finish | Complete | Baseline start | Baseline finish | Baseline duration | Constraint | Resources | Work | Actual work | Acronym | Release | MCC resp | Acronym_3GU_Export | WI rapporteur name | WI rapporteur e-mail |
| --- | --- | --- | --- | --- | --- | --- | --- | --- | --- | --- | --- | --- | --- | --- | --- | --- | --- | --- | --- |
| 5436 | 11 | **Rel-5 Terminal interfaces** | 223d | 2001-05-14 A | 2002-03-20 A | 100% | 2001-05-14 | 2002-03-20 | 223d |  | T2 | 3568h | 3568h | TLM5 | Rel-5 | Kimmo | TI, TLM5 |  |  |
| 5437 | 87 | Terminal local model enhancements | 223d | 2001-05-14 A | 2002-03-20 A | 100% | 2001-05-14 | 2002-03-20 | 223d | finish no earlier than 2002-03-20 | T2 | 1784h | 1784h | TLM5 | Rel-5 |  | TLM5 |  |  |
| 5438 | 88 | **Rel-5 Location Services enhancements** | 845d | 2000-04-03 A | 2003-06-27 A | 100% | 2000-04-03 | 2003-06-27 | 845d |  | S2; S1; S3; S5; N4; R2; R3; GP | 237560h | 237560h | LCS1 | Rel-5 | Maurice | LCS1, Rel-5 | Nokia | Jan Kall |
| 5439 | 88.1 | **UE positioning for Rel-5 Location Services enhancements** | 315d | 2001-01-15 A | 2002-03-29 A | 100% | 2001-01-15 | 2002-03-29 | 315d |  | R2 | 6120h | 6120h | LCS1-Uepos | Rel-5 | Issam | LCS1-Uepos, Rel-5 |  |  |
| 5440 | 88.1.1 | UE positioning enhancements for 1.28 Mcps TDD | 255d | 2001-04-09 A | 2002-03-29 A | 100% | 2001-04-09 | 2002-03-29 | 255d | finish no earlier than 2002-03-29 | R2 | 2040h | 2040h | LCS-128Pos | Rel-5 | Yong-Jun | LCS-128Pos | CATT | Xiaohua Mei |
| 5441 | 88.1.2 | Open SMLC-SRNC Interface within the UTRAN to support A-GPS Positioning | 195d | 2001-01-15 A | 2001-10-12 A | 100% | 2001-01-15 | 2001-10-12 | 195d |  | R2 | 1560h | 1560h | LCS-INTF | Rel-5 | Yong-Jun | LCS-INTF | Qualcomm | Kirk Burroughs |
| 5442 | 88.2 | **Event Based and Periodic LCS** | 535d | 2000-05-22 A | 2002-06-07 A | 100% | 2000-05-22 | 2002-06-07 | 535d |  | S1; S2; N4 | 14848h | 14848h | LCS1-EBP | Rel-5 | Alain | LCS1-EBP | Pacific Bell Wireless | Randolph Wohlert (rwohlert@tri.sbc.com) |
| 5443 | 88.2.1 | Stage 1 for Event based and Periodic LCS | 130d | 2000-05-22 A | 2000-11-17 A | 100% | 2000-05-22 | 2000-11-17 | 130d | finish no earlier than 2000-07-21 | S1 | 1040h | 1040h |  | Rel-5 | Alain |  | Pacific Bell Wireless | Randolph Wohlert (rwohlert@tri.sbc.com) |
| 5444 | 88.2.2 | Stage 2 for Event based and Periodic LCS | 60d | 2000-11-06 A | 2001-01-26 A | 100% | 2000-11-06 | 2001-01-26 | 60d | finish no earlier than 2001-01-26 | S2 | 480h | 480h |  | Rel-5 | Maurice |  |  |  |
| 5445 | 88.2.3 | Impact on MAP | 61d | 2002-03-15 A | 2002-06-07 A | 100% | 2002-03-15 | 2002-06-07 | 61d | finish no earlier than 2002-06-07 | N4 | 488h | 488h |  | Rel-5 | Kimmo |  |  |  |
| 5446 | 88.3 | **Location Services for GERAN in A/Gb Mode** | 485d | 2000-04-03 A | 2002-02-08 A | 100% | 2000-04-03 | 2002-02-08 | 485d |  | GP | 26400h | 26400h | LCS-GERAN | Rel-5 | Paolo | LCS-GERAN | Nokia | Margaret Livingston |
| 5447 | 88.3.1 | GERAN LCS Stage 2 (first release) | 485d | 2000-04-03 A | 2002-02-08 A | 100% | 2000-04-03 | 2002-02-08 | 485d | finish no earlier than 2002-02-08 | GP; S2; G1; G2 | 15520h | 15520h |  | Rel-5 | Paolo |  | Nokia | Margaret Livingston |
| 5448 | 88.3.2 | Gb interface support for LCS | 370d | 2000-04-03 A | 2001-08-31 A | 100% | 2000-04-03 | 2001-08-31 | 370d | finish no earlier than 2001-08-31 | GP | 2960h | 2960h |  | Rel-5 | Paolo |  | Nokia | Margaret Livingston |
| 5449 | 88.3.3 | L3 protocol support for LCS | 305d | 2000-04-03 A | 2001-06-01 A | 100% | 2000-04-03 | 2001-06-01 | 305d | finish no earlier than 2001-06-01 | GP | 2440h | 2440h |  | Rel-5 | Paolo |  | Nokia | Margaret Livingston |
| 5450 | 88.3.4 | Stage 3 for Location Services for GERAN in A/Gb Mode | 305d | 2000-04-03 A | 2001-06-01 A | 100% | 2000-04-03 | 2001-06-01 | 305d | finish no earlier than 2001-06-01 | GP | 2440h | 2440h |  | Rel-5 | Paolo |  | Nokia | Margaret Livingston |
| 5451 | 88.4 | **Location Services for GERAN in Iu Mode** | 585d | 2000-04-03 A | 2002-06-28 A | 100% | 2000-04-03 | 2002-06-28 | 585d |  | S2; G1; G2; R2; R3 | 64264h | 64264h |  | Rel-5 | Paolo |  | Nokia | Margaret Livingston |
| 5452 | 88.4.1 | GERAN LCS Stage 2 | 585d | 2000-04-03 A | 2002-06-28 A | 100% | 2000-04-03 | 2002-06-28 | 585d | finish no earlier than 2002-06-28 | S2; G1; G2 | 14040h | 14040h |  | Rel-5 | Paolo |  | Nokia | Margaret Livingston |
| 5453 | 88.4.2 | Iu-ps interface support for LCS | 585d | 2000-04-03 A | 2002-06-28 A | 100% | 2000-04-03 | 2002-06-28 | 585d | finish no earlier than 2002-06-28 | R2; R3 | 9360h | 9360h |  | Rel-5 | Paolo |  | Nokia | Margaret Livingston |
| 5454 | 88.4.3 | Iu-cs interface support for LCS | 585d | 2000-04-03 A | 2002-06-28 A | 100% | 2000-04-03 | 2002-06-28 | 585d | finish no earlier than 2002-06-28 | R2; R3 | 9360h | 9360h |  | Rel-5 | Paolo |  | Nokia | Margaret Livingston |
| 5455 | 88.4.4 | Iur-g interface support for LCS | 62.5d | 2002-01-23 A | 2002-04-19 A | 100% | 2002-01-23 | 2002-04-19 | 62.5d | finish no earlier than 2002-04-19 | G1; G2 | 1000h | 1000h |  | Rel-5 | Paolo |  | Nokia | Margaret Livingston |
| 5456 | 88.4.5 | RRC protocol support for LCS | 75d | 2001-08-20 A | 2001-11-30 A | 100% | 2001-08-20 | 2001-11-30 | 75d | finish no earlier than 2001-11-30 | G1; G2; R2; R3 | 2400h | 2400h |  | Rel-5 | Paolo |  | Nokia | Margaret Livingston |
| 5457 | 88.4.6 | Additional impacts on Broadcast of LCS data on packet channels | 77.5d | 2001-08-20 A | 2001-12-05 A | 100% | 2001-08-20 | 2001-12-05 | 77.5d | finish no earlier than 2001-12-05 | G1; G2; R2; R3 | 2480h | 2480h |  | Rel-5 | Paolo |  | Nokia | Margaret Livingston |
| 5458 | 88.4.7 | Stage 3 for Location Services for GERAN in Iu Mode | 69.5d | 2002-03-25 A | 2002-06-28 A | 100% | 2002-03-25 | 2002-06-28 | 69.5d | finish no earlier than 2002-06-28 | G1; G2; R2; R3 | 2224h | 2224h |  | Rel-5 | Paolo |  | Nokia | Margaret Livingston |
| 5459 | 88.5 | **GERAN MS Conformance test for LCS** | 280d | 2002-06-03 A | 2003-06-27 A | 100% | 2002-06-03 | 2003-06-27 | 280d |  | GP | 11200h | 11200h | LCS-GERAN-MSconf | Rel-5 | Paolo | LCS-GERAN-MSconf |  |  |
| 5460 | 88.5.1 | LCS MS test case work plan (Release 98/99/4) | 280d | 2002-06-03 A | 2003-06-27 A | 100% | 2002-06-03 | 2003-06-27 | 280d | finish no earlier than 2003-06-27 | G4; G5 | 4480h | 4480h |  | Rel-5 | Paolo |  |  |  |
| 5461 | 88.5.2 | LCS MS test cases | 280d | 2002-06-03 A | 2003-06-27 A | 100% | 2002-06-03 | 2003-06-27 | 280d | finish no earlier than 2003-06-27 | G4; G5 | 4480h | 4480h |  | Rel-5 | Paolo |  |  |  |

Notes:
- 5436: Acronym changed from "TI, TLMN5"
- 5437: - / Impacted TSs and TRs: 23.227
- 5438: . Acronym changed from "LCS1, Rel-5"
- 5439: Acronym changed from "LCS1-Uepos, Rel-5"
- 5440: - / Impacted TSs and TRs: 25.123, 25.224, 25.225, 25.302, 25.303, 25.304, 25.305, 25.331, 25.420, 25.423, 25.430, 25.433, New TR 25.859
- 5441: RP#13 completed
- 5442: -
- 5443: Evaluate Event based and Periodic LCS to be included in R00, corresponding Stage 1 description / Impacted TSs and TRs: 22.071
- 5444: Marked as closed 12/2008 (was marked 51% complete)
- 5445: Possible impact on UTRAN of LCS quality level request
- 5446: -
- 5447: -
- 5448: -
- 5449: -
- 5450: -
- 5451: -
- 5452: -
- 5453: -
- 5454: -
- 5455: FFS
- 5456: -
- 5457: -
- 5458: -
- 5459: -
- 5460: Marked as closed 12/2008 (was marked 60% complete)
- 5461: Marked as closed 12/2008 (was marked 60% complete)

| ID | WBS | Task | Duration | Start | Finish | Predecessors | Complete | Baseline start | Baseline finish | Baseline duration | Constraint | Resources | Work | Actual work | Acronym | Release | MCC resp | TSG stopped | Acronym_3GU_Export | Impacted TSs and TRs | WI rapporteur name | WI rapporteur e-mail |
| --- | --- | --- | --- | --- | --- | --- | --- | --- | --- | --- | --- | --- | --- | --- | --- | --- | --- | --- | --- | --- | --- | --- |
| 5462 | 88.6 | **Deleted - GERAN BTS Conformance test for LCS** | 280d | 2002-06-03 A | 2003-06-27 A |  | 100% | 2002-06-03 | 2003-06-27 | 280d |  | GP | 11200h | 11200h | LCS-GERAN-BTSconf | Rel-5 | Paolo | GP-15 | LCS-GERAN-BTSconf |  |  |  |
| 5463 | 88.6.1 | Deleted - LCS BTS test case work plan (Release 98/99/4) | 280d | 2002-06-03 A | 2003-06-27 A |  | 100% | 2002-06-03 | 2003-06-27 | 280d | finish no earlier than 2003-06-27 | G4; G5 | 4480h | 4480h |  | Rel-5 | Paolo | GP-15 |  |  |  |  |
| 5464 | 88.6.2 | Deleted - LCS BTS test cases | 280d | 2002-06-03 A | 2003-06-27 A |  | 100% | 2002-06-03 | 2003-06-27 | 280d | finish no earlier than 2003-06-27 | G4; G5 | 4480h | 4480h |  | Rel-5 | Paolo | GP-15 |  |  |  |  |
| 5465 | 88.7 | LCS interoperation stage 2 aspects | 480d | 2000-08-28 A | 2002-06-28 A |  | 100% | 2000-08-28 | 2002-06-28 | 480d |  | S2 | 3840h | 3840h |  | Rel-5 | Maurice |  |  |  |  |  |
| 5466 | 88.8 | **LCS interoperability aspects to GERAN (LCS-GERAN)** | 480d | 2000-08-28 A | 2002-06-28 A |  | 100% | 2000-08-28 | 2002-06-28 | 480d |  | GP; S5 | 34560h | 34560h |  | Rel-5 | Paolo |  |  |  |  |  |
| 5467 | 88.8.1 | Co-ordinated development of GSM LCS Phase 2 and UMTS LCS, S2 and GERAN | 480d | 2000-08-28 A | 2002-06-28 A |  | 100% | 2000-08-28 | 2002-06-28 | 480d | finish no earlier than 2002-06-28 | GP; S2; S5; R2; R3; G2; G1 | 26880h | 26880h |  | Rel-5 | Paolo |  |  |  |  |  |
| 5468 | 88.9 | FS on LCS support in the IMS | 90d | 2001-02-12 A | 2002-01-18 A |  | 100% | 2001-02-12 | 2002-01-18 | 90d | start no earlier than 2001-02-12 | S1 | 720h | 720h |  | Rel-5 | Alain |  |  |  |  |  |
| 5469 | 88.10 | Charging and OAM&P for LCS enhancements | 201d | 2001-09-21 A | 2002-06-28 A |  | 100% | 2001-09-21 | 2002-06-28 | 201d | finish no earlier than 2002-06-28 | S5 | 1608h | 1608h | LCS1-OAM | Rel-5 | Mirko |  | LCS1-OAM | 32.200-series |  |  |
| 5470 | 88.11 | New security aspects of LCS | 446d | 2000-04-14 A | 2001-12-28 A |  | 100% | 2000-04-14 | 2001-12-28 | 446d | finish no earlier than 2001-12-28 | S3; S2 | 7136h | 7136h | LCS1-SEC | Rel-5 | Mirko |  | LCS1-SEC | 23.271, 43.059 | Nokia | valtteri.niemi@nokia.com |
| 5471 | 88.12 | Specification for the Le interface | 45d | 2002-01-14 A | 2002-03-15 A |  | 100% | 2002-01-14 | 2002-03-15 | 45d | start no earlier than 2002-01-14 | S2 | 360h | 360h | LCS1-Le | Rel-5 | Maurice |  | LCS1-Le |  |  |  |
| 5472 | 88.13 | Deleted - CHECK STATUS - Inter-GMLC interface | 153d | 2002-05-30 A | 2002-12-30 A |  | 100% | 2002-05-30 | 2002-12-30 | 153d | finish no earlier than 2002-12-30 | S2 | 1224h | 1224h |  | Rel-5 | Maurice | SP-10 |  |  |  |  |
| 5473 | 89 | **Rel-5 Security enhancements (SEC1)** | 615d | 2000-02-21 A | 2002-06-28 A |  | 100% | 2000-02-21 | 2002-06-28 | 615d |  | S3 | 29974.9h | 29974.9h |  | Rel-5 | Mirko |  |  |  | Vodafone | Peter.Howard@vodafone.com |
| 5474 | 89.1 | **Rel-5 Network Domain Security (SEC1-NDS)** | 615d | 2000-02-21 A | 2002-06-28 A |  | 100% | 2000-02-21 | 2002-06-28 | 615d |  | S3 | 25054.9h | 25054.9h |  | Rel-5 | Mirko |  |  | New 33.200 (exists also for Rel-4) | Telenor | Geir-myrdahl.koien@telenor.com |
| 5475 | 89.1.3 | Rel-5 IP network layer security (NDS/IP) (SEC1-NDS-IP) | 457d | 2000-06-15 A | 2002-03-15 A |  | 100% | 2000-06-15 | 2002-03-15 | 457d | finish no earlier than 2002-03-15 | S3 | 3656h | 3656h |  | Rel-5 | Mirko |  |  | New 33.210 | Telenor | Geir-myrdahl.koien@telenor.com |
| 5476 | 89.1.1 | **Deleted - Control plane protection in core network (e.g., GTP, CAP, MAP/IP, provided by IPsec)** | 541d | 2000-05-12 A | 2002-06-07 A |  | 100% | 2000-05-12 | 2002-06-07 | 541d |  | S3 | 7118.9h | 7118.9h |  | Rel-5 | Mirko | SP-16 |  |  |  |  |
| 5477 | 89.1.1.1 | Deleted - Main aspects of User plane protection in core network (e.g., provided by IPsec) | 290d | 2000-05-12 A | 2001-06-21 A |  | 100% | 2000-05-12 | 2001-06-21 | 290d | finish no earlier than 2001-06-21 | S3 | 2320h | 2320h |  | Rel-5 | Mirko | SP-12 |  |  |  |  |
| 5478 | 89.1.1.2 | Deleted - Integration of GTP signalling security architecture - for User plane protection in core network (e.g., provided by IPsec) | 191d | 2001-09-14 A | 2002-06-07 A |  | 100% | 2001-09-14 | 2002-06-07 | 191d | finish no earlier than 2002-06-07 | N4 | 1528h | 1528h |  | Rel-5 | Kimmo | NP-16 |  |  |  |  |
| 5479 | 89.1.2 | **Deleted - User plane protection in core network (e.g., provided by IPsec)** | 615d | 2000-02-21 A | 2002-06-28 A |  | 100% | 2000-02-21 | 2002-06-28 | 615d |  | S3 | 9360h | 9360h |  | Rel-5 | Mirko | SP-16 |  |  |  |  |
| 5480 | 89.1.2.1 | Deleted -Main aspects of User plane protection in core network (e.g., provided by IPsec) | 349d | 2000-02-21 A | 2001-06-21 A |  | 100% | 2000-02-21 | 2001-06-21 | 349d | finish no earlier than 2001-06-21 | S3 | 2792h | 2792h |  | Rel-5 | Mirko | SP-12 |  |  |  |  |
| 5481 | 89.1.2.2 | Deleted - Integration of GTP signalling security architecture - for User plane protection in core network (e.g., provided by IPsec) | 206d | 2001-09-14 A | 2002-06-28 A |  | 100% | 2001-09-14 | 2002-06-28 | 206d | finish no earlier than 2002-06-28 | N4 | 1648h | 1648h |  | Rel-5 | Kimmo | NP-16 |  |  |  |  |
| 5482 | 90 | **Intra Domain Connection of RAN Nodes to Multiple CN Nodes** | 455d | 2000-10-02 A | 2002-06-28 A |  | 100% | 2000-10-02 | 2002-06-28 | 455d |  | S2; N1; N4; R3; GP | 30232h | 30232h | IUFLEX | Rel-5 | Alain |  | IUFLEX | 23.236 | Ericsson | stephen.terrill@ericsson.com |
| 5483 | 90.1 | Overall System Architecture for Intra Domain Connection of RAN Nodes to Multiple CN Nodes | 188d | 2001-01-03 A | 2001-09-21 A |  | 100% | 2001-01-03 | 2001-09-21 | 188d | finish no earlier than 2001-06-01 | S2 | 1504h | 1504h |  | Rel-5 | Maurice |  |  |  |  |  |
| 5484 | 90.2 | Stage 3: RAN node selecting CN node | 130d | 2001-09-24 A | 2002-03-22 A | 5483 | 100% | 2001-09-24 | 2002-03-22 | 130d | finish no earlier than 2002-03-22 | R3 | 1040h | 1040h |  | Rel-5 | Juha |  |  |  | Vodafone | Brendan.McWilliams@gb.vodafone.co.uk |
| 5485 | 90.3 | N1 work for Intra Domain Connection of RAN Nodes to Multiple CN Nodes | 205d | 2001-09-17 A | 2002-06-28 A |  | 100% | 2001-09-17 | 2002-06-28 | 205d | start no earlier than 2001-09-17 | N1 | 1640h | 1640h |  | Rel-5 | Frederic |  |  | 24.008 and check 29.018 |  |  |
| 5486 | 90.4 | N4 work for Intra Domain Connection of RAN Nodes to Multiple CN Nodes | 375d | 2000-10-02 A | 2002-03-08 A |  | 100% | 2000-10-02 | 2002-03-08 | 375d | finish no earlier than 2002-03-15 | N4 | 3000h | 3000h |  | Rel-5 | Kimmo |  |  |  |  |  |

Notes:
- 5462: Not started 02/3003. Marked as stopped 12/2008
- 5463: Marked as stopped 12/2008
- 5464: Marked as stopped 12/2008
- 5465: Marked as closed 12/2008 (was marked 17% complete)
- 5466: -
- 5467: -
- 5468: Marked as closed 12/2008 (was marked 75% complete)
- 5469: -
- 5470: SP#9 updated WID S3-000609 (Location services security)
- 5471: -
- 5472: Marked as stopped 12/2008
- 5473: Added BB UE authentication and rapporteur added. TO BE DELETED
- 5474: SP#9 approved WID SP-000420 (S3-000606 Network domain security). S3#17: All due in Rel5. (WI Update at S3#18). Replaced by NDS-IP and NDS-MAP. TO BE DELETED OR MOVED TO HISTORY FILE
- 5475: SP#12 WID updated SP-000420 (S3-000606) =>SP-010326 (S3-010286)
- 5476: Marked as stopped 12/2008
- 5477: TO BE DELETED. Marked as stopped 12/2008
- 5478: Waiting for input from SA3!. Marked as stopped 12/2008
- 5479: TO BE DELETED. Marked as stopped 12/2008
- 5480: -
- 5481: 14/02/2002 requirements are not clear/not receivedMarked as closed 12/2008 (was marked 95 complete)
- 5482: No clear indication on the end date. Put to Rel5 by AS.
- 5483: -
- 5484: Not identified
- 5485: -
- 5486: DAB 12.12.01 - % complete to 66%

| ID | WBS | Task | Duration | Start | Finish | Complete | Baseline start | Baseline finish | Baseline duration | Constraint | Resources | Work | Actual work | Acronym | WI rapporteur name | WI rapporteur e-mail | Release | MCC resp | Acronym_3GU_Export | TSG stopped | Impacted TSs and TRs |
| --- | --- | --- | --- | --- | --- | --- | --- | --- | --- | --- | --- | --- | --- | --- | --- | --- | --- | --- | --- | --- | --- |
| 5487 | 90.5 | **GERAN work for Intra Domain Connection of RAN Nodes to Multiple CN Nodes** | 101d | 2002-02-08 A | 2002-06-28 A | 100% | 2002-02-08 | 2002-06-28 | 101d |  | GP | 4848h | 4848h | IDCRAN-GERAN | Ericsson | ingemar.backlund@era.ericsson.se | Rel-5 | Paolo | IDCRAN-GERAN |  |  |
| 5488 | 90.5.1 | Stage 2 (changes to ) | 101d | 2002-02-08 A | 2002-06-28 A | 100% | 2002-02-08 | 2002-06-28 | 101d | finish no earlier than 2002-06-28 | G1 | 808h | 808h |  |  |  | Rel-5 | Paolo |  |  |  |
| 5489 | 90.5.2 | 43.051 Introduction of support for IDNNS in GERAN Iu mode | 101d | 2002-02-08 A | 2002-06-28 A | 100% | 2002-02-08 | 2002-06-28 | 101d | finish no earlier than 2002-06-28 | G1 | 808h | 808h |  |  |  | Rel-5 | Paolo |  |  |  |
| 5490 | 90.5.3 | Stage 3 (changes to ) | 101d | 2002-02-08 A | 2002-06-28 A | 100% | 2002-02-08 | 2002-06-28 | 101d | finish no earlier than 2002-06-28 | G2 | 808h | 808h |  |  |  | Rel-5 | Gert |  |  |  |
| 5491 | 90.5.4 | 48.016 Use of Gb interface concepts when a network applies IDNNS | 101d | 2002-02-08 A | 2002-06-28 A | 100% | 2002-02-08 | 2002-06-28 | 101d | finish no earlier than 2002-06-28 | G2 | 808h | 808h |  |  |  | Rel-5 | Gert |  |  |  |
| 5492 | 90.5.5 | 48.018 Include MSC/VLR identity in CS IMSI paging | 101d | 2002-02-08 A | 2002-06-28 A | 100% | 2002-02-08 | 2002-06-28 | 101d | finish no earlier than 2002-06-28 | G2 | 808h | 808h |  |  |  | Rel-5 | Gert |  |  |  |
| 5493 | 91 | **Deleted - GERAN improvements 3 (new transport layer on interface A)** | 446d | 2001-04-06 A | 2002-12-20 A | 100% | 2001-04-06 | 2002-12-20 | 446d |  | GP | 14272h | 14272h | GEIMP3 |  |  | Rel-5 | Paolo | GEIMP3 | SP-69 |  |
| 5494 | 91.1 | **Deleted - Evolution of the transport for A** | 446d | 2001-04-06 A | 2002-12-20 A | 100% | 2001-04-06 | 2002-12-20 | 446d |  | GP | 10704h | 10704h | GEIMP3-EtA |  |  | Rel-5 | Paolo | GEIMP3-EtA | GP-12 |  |
| 5495 | 91.1.1 | Deleted - Definition of a new A/Ater interface Transport Layer option based on the Iu Interface Transport Layer | 446d | 2001-04-06 A | 2002-12-20 A | 100% | 2001-04-06 | 2002-12-20 | 446d | finish no earlier than 2002-12-20 | GP | 3568h | 3568h |  |  |  | Rel-5 | Paolo |  | GP-12 |  |
| 5496 | 91.1.2 | Deleted - Adaptation of the Layer 3 BSSMAP procedures as required | 446d | 2001-04-06 A | 2002-12-20 A | 100% | 2001-04-06 | 2002-12-20 | 446d | finish no earlier than 2002-12-20 | GP | 3568h | 3568h |  |  |  | Rel-5 | Paolo |  | GP-12 |  |
| 5497 | 92 | **Rel-5 Charging Management & Operations, Administration, Maintenance and Provisioning (OAM&P)** | 264d | 2001-09-10 A | 2002-09-12 A | 100% | 2001-09-10 | 2002-09-12 | 264d |  | S5 | 9976h | 9976h | OAM5 |  |  | Rel-5 | Mirko | OAM5 |  |  |
| 5498 | 92.1 | Rel-5 Principles, high level Requirements and Architecture | 205d | 2001-09-17 A | 2002-06-28 A | 100% | 2001-09-17 | 2002-06-28 | 205d | finish no earlier than 2002-06-28 | S5 | 1640h | 1640h |  | Motorola |  | Rel-5 | Mirko |  |  | 32.101, 32.102 |
| 5499 | 92.2 | Rel-5 Performance Management | 259d | 2001-09-17 A | 2002-09-12 A | 100% | 2001-09-17 | 2002-09-12 | 259d | finish no earlier than 2002-09-12 | S5 | 2072h | 2072h |  | Nortel |  | Rel-5 | Mirko |  |  | 32.4xy, 52.402 |
| 5500 | 92.3 | Rel-5 Charging Management | 264d | 2001-09-10 A | 2002-09-12 A | 100% | 2001-09-10 | 2002-09-12 | 264d | finish no earlier than 2002-09-12 | S5 | 2112h | 2112h |  | T-Mobile | Karl-Heinz.Nenner@T-MOBILE.DE | Rel-5 | Mirko |  |  | 32.200, 32.205, 32.215, 32.225, 32.235 |
| 5501 | 92.4 | Rel-5 Network Infrastructure Management | 255d | 2001-09-21 A | 2002-09-12 A | 100% | 2001-09-21 | 2002-09-12 | 255d | finish no earlier than 2002-09-12 | S5 | 2040h | 2040h |  | Ericsson | thomas.tovinger@ericsson.com | Rel-5 | Mirko |  |  | 32.6xy, 32.3xy |
| 5502 | 93 | **GERAN enhancements for streaming services 1 (RLC enhancements)** | 430d | 2000-11-06 A | 2002-06-28 A | 100% | 2000-11-06 | 2002-06-28 | 430d |  | GP | 8944h | 8944h |  |  |  | Rel-5 | Paolo |  |  |  |
| 5503 | 93.1 | Concept for GERAN enhancements for streaming services 1 (RLC enhancements) | 258d | 2000-11-06 A | 2001-10-31 A | 100% | 2000-11-06 | 2001-10-31 | 258d | finish no earlier than 2001-10-31 | GP | 2064h | 2064h |  |  |  | Rel-5 | Paolo |  |  |  |
| 5504 | 93.2 | RLC protocol enhancement (SDU Discard) | 430d | 2000-11-06 A | 2002-06-28 A | 100% | 2000-11-06 | 2002-06-28 | 430d | finish no earlier than 2002-06-28 | GP | 3440h | 3440h |  |  |  | Rel-5 | Paolo |  |  |  |
| 5505 | 94 | **GERAN enhancements for streaming services 2 (usage of ECSD)** | 430d | 2000-11-06 A | 2002-06-28 A | 100% | 2000-11-06 | 2002-06-28 | 430d |  | GP | 19840h | 19840h |  | Ericsson | Frank Muller | Rel-5 | Paolo |  |  |  |
| 5506 | 94.1 | Usage of ECSD Concept | 380d | 2000-11-06 A | 2002-04-19 A | 100% | 2000-11-06 | 2002-04-19 | 380d | finish no earlier than 2002-04-19 | GP | 3040h | 3040h |  |  |  | Rel-5 | Paolo |  |  |  |
| 5507 | 94.2 | Stage 2 for GERAN enhancements for streaming services 2 (usage of ECSD) | 380d | 2000-11-06 A | 2002-04-19 A | 100% | 2000-11-06 | 2002-04-19 | 380d | finish no earlier than 2002-04-19 | GP | 3040h | 3040h |  |  |  | Rel-5 | Paolo |  |  |  |
| 5508 | 94.3 | Stage 3 for GERAN enhancements for streaming services 2 (usage of ECSD) | 430d | 2000-11-06 A | 2002-06-28 A | 100% | 2000-11-06 | 2002-06-28 | 430d | finish no earlier than 2002-06-28 | GP | 3440h | 3440h |  |  |  | Rel-5 | Paolo |  |  |  |
| 5509 | 94.4 | RLC PDU formats | 430d | 2000-11-06 A | 2002-06-28 A | 100% | 2000-11-06 | 2002-06-28 | 430d | finish no earlier than 2002-06-28 | GP | 3440h | 3440h |  |  |  | Rel-5 | Paolo |  |  |  |
| 5510 | 94.5 | MAC header | 430d | 2000-11-06 A | 2002-06-28 A | 100% | 2000-11-06 | 2002-06-28 | 430d | finish no earlier than 2002-06-28 | GP | 3440h | 3440h |  |  |  | Rel-5 | Paolo |  |  |  |

Notes:
- 5487: Accept changes Gb over IP
- 5488: -
- 5489: -
- 5490: -
- 5491: Closed, accept changes for Gb over IP
- 5492: -
- 5493: Terminated - not standardized. Marked as stopped 12/2008
- 5494: TERMINATED - NOT STANDARDIZED. Marked as stopped 12/2008
- 5495: TERMINATED - NOT STANDARDIZED. Marked as stopped 12/2008
- 5496: TERMINATED - NOT STANDARDIZED. Marked as stopped 12/2008
- 5497: -
- 5498: -
- 5499: -
- 5500: -
- 5501: -
- 5502: -
- 5503: -
- 5504: -
- 5505: AWS, Nokia, Ericsson, Nortel, Siemens, Motorola, Vodafone
- 5506: -
- 5507: -
- 5508: -
- 5509: -
- 5510: -

| ID | WBS | Task | Duration | Start | Finish | Predecessors | Complete | Baseline start | Baseline finish | Baseline duration | Constraint | Resources | Work | Actual work | Acronym | WI rapporteur name | WI rapporteur e-mail | Release | MCC resp | Acronym_3GU_Export |
| --- | --- | --- | --- | --- | --- | --- | --- | --- | --- | --- | --- | --- | --- | --- | --- | --- | --- | --- | --- | --- |
| 5511 | 95 | **GERAN/UTRAN interface evolution 1 (evolution of Iu PS)** | 476d | 2000-09-01 A | 2002-06-28 A |  | 100% | 2000-09-01 | 2002-06-28 | 476d |  | GP; R3 | 22848h | 22848h | GERUEV1 | SBC | Marc Grant | Rel-5 | Paolo | GERUEV1 |
| 5512 | 95.1 | **Evolution of Iu ps** | 476d | 2000-09-01 A | 2002-06-28 A |  | 100% | 2000-09-01 | 2002-06-28 | 476d |  | GP; R3 | 15232h | 15232h | GERUEV1-IuPS |  |  | Rel-5 | Paolo | GERUEV1-IuPS |
| 5513 | 95.1.1 | Identification of GERAN requirements on Iu ps | 326d | 2000-09-01 A | 2001-11-30 A |  | 100% | 2000-09-01 | 2001-11-30 | 326d | finish no earlier than 2001-11-30 | GP; R3 | 5216h | 5216h |  |  |  | Rel-5 | Paolo |  |
| 5514 | 95.1.2 | Update of Evolution of Iu ps specifications | 150d | 2001-12-03 A | 2002-06-28 A | 5513 | 100% | 2001-12-03 | 2002-06-28 | 150d | finish no earlier than 2002-06-28 | GP; R3 | 2400h | 2400h |  |  |  | Rel-5 | Paolo |  |
| 5515 | 96 | **GERAN/UTRAN interface evolution 2 (evolution of Iu CS)** | 522d | 2000-06-29 A | 2002-06-28 A |  | 100% | 2000-06-29 | 2002-06-28 | 522d |  | GP; R3 | 31872h | 31872h | GERUEV2 |  |  | Rel-5 | Paolo | GERUEV2 |
| 5516 | 96.1 | **Evolution of Iu cs** | 522d | 2000-06-29 A | 2002-06-28 A |  | 100% | 2000-06-29 | 2002-06-28 | 522d |  | GP; R3 | 23520h | 23520h | GERUEV2-IuCS | Lucent | Krishna Balachandran | Rel-5 | Paolo | GERUEV2-IuCS |
| 5517 | 96.1.1 | Identification of GERAN requirements on Iu cs | 472d | 2000-06-29 A | 2002-04-19 A |  | 100% | 2000-06-29 | 2002-04-19 | 472d | finish no earlier than 2002-04-19 | GP; R3 | 7552h | 7552h |  |  |  | Rel-5 | Paolo |  |
| 5518 | 96.1.2 | Update of Evolution of Iu cs specifications | 476d | 2000-09-01 A | 2002-06-28 A |  | 100% | 2000-09-01 | 2002-06-28 | 476d | finish no earlier than 2002-06-28 | GP; R3 | 7616h | 7616h |  |  |  | Rel-5 | Paolo |  |
| 5519 | 97 | **End to End QoS for PS Domain including IMS** | 480d | 2000-08-28 A | 2002-06-28 A |  | 100% | 2000-08-28 | 2002-06-28 | 480d |  | S2; S5; N3 | 18272h | 18272h | E2EQoS | Ericsson | Johnson.oyama@era.ericcson.se | Rel-5 | Maurice | E2EQoS, Rel-5 |
| 5520 | 97.1 | E2E QoSConcept and Architecture | 178d | 2001-01-03 A | 2001-09-07 A |  | 100% | 2001-01-03 | 2001-09-07 | 178d | finish no earlier than 2001-09-07 | S2 | 1424h | 1424h |  |  |  | Rel-5 | Maurice |  |
| 5521 | 97.2 | E2E QoS interworking | 465d | 2000-08-28 A | 2002-06-07 A |  | 100% | 2000-08-28 | 2002-06-07 | 465d | finish no earlier than 2002-06-07 | N3 | 3720h | 3720h | E2EQoS-IW | Lucent | Daisuke Yokota (yokota@lucent.com) | Rel-5 | Gwiho | E2EQoS-IW |
| 5522 | 97.3 | QoS Management (Provisioning and Monitoring) | 201d | 2001-09-21 A | 2002-06-28 A |  | 100% | 2001-09-21 | 2002-06-28 | 201d | finish no earlier than 2002-06-28 | S5 | 1608h | 1608h | E2EQoS-OAM |  |  | Rel-5 | Mirko | E2EQoS-OAM |
| 5523 | 98 | **Rel-5 Messaging enhancements** | 467d | 2001-06-15 A | 2003-03-31 A |  | 100% | 2001-06-15 | 2003-03-31 | 467d |  | T2 | 19000h | 19000h | MESS5 |  |  | Rel-5 | Kimmo | MESS5 |
| 5524 | 98.1 | **Rel-5 Multimedia Messaging (MMS) enhancements** | 467d | 2001-06-15 A | 2003-03-31 A |  | 100% | 2001-06-15 | 2003-03-31 | 467d |  | T2 | 11688h | 11688h | MESS5-MMS | Siemens | Josef.Laumen@SAL.SIEMENS.DE | Rel-5 | Alain | MESS5-MMS |
| 5525 | 98.1.1 | Definition of service requirements for MESS5-MMS | 196d | 2001-06-15 A | 2002-03-15 A |  | 100% | 2001-06-15 | 2002-03-15 | 196d | finish no earlier than 2002-03-15 | S1 | 1568h | 1568h | MESS5-SR | Siemens | Josef.Laumen@SAL.SIEMENS.DE | Rel-5 | Alain | MESS5-SR |
| 5526 | 98.1.2 | Technical realization of MESS5-MMS | 256d | 2001-06-15 A | 2002-06-07 A |  | 100% | 2001-06-15 | 2002-06-07 | 256d | finish no earlier than 2002-06-07 | T2 | 2048h | 2048h |  | Siemens | Josef.Laumen@SAL.SIEMENS.DE | Rel-5 |  |  |
| 5527 | 98.1.3 | WAP Forum dependency: MM1 stage 3 | 467d | 2001-06-15 A | 2003-03-31 A |  | 100% | 2001-06-15 | 2003-03-31 | 467d | finish no earlier than 2003-03-31 | T2 | 3736h | 3736h |  |  |  | Rel-5 |  |  |
| 5528 | 98.1.4 | MMS formats and codecs for MESS5-MMS | 75d | 2001-12-03 A | 2002-03-15 A |  | 100% | 2001-12-03 | 2002-03-15 | 75d | finish no earlier than 2002-03-15 | S4 | 600h | 600h |  |  |  | Rel-5 | Paolo |  |
| 5529 | 98.2 | **Enhanced Messaging Service (EMS) enhancements** | 191d | 2001-06-15 A | 2002-03-08 A |  | 100% | 2001-06-15 | 2002-03-08 | 191d |  | T2 | 3584h | 3584h | MESS5-EMS | Ericsson | Alan.Baldwin@EML.ERICSSON.SE | Rel-5 | Kimmo | MESS5-EMS |
| 5530 | 98.2.1 | Definition of service requirements for Enhanced Messaging Service (EMS) enhancements | 66d | 2001-06-15 A | 2001-09-14 A |  | 100% | 2001-06-15 | 2001-09-14 | 66d | finish no earlier than 2001-09-14 | S1 | 528h | 528h |  | Ericsson | Alan.Baldwin@EML.ERICSSON.SE | Rel-5 | Alain |  |
| 5531 | 98.2.2 | Technical realization of Enhanced Messaging Service (EMS) enhancements | 191d | 2001-06-15 A | 2002-03-08 A |  | 100% | 2001-06-15 | 2002-03-08 | 191d | finish no earlier than 2002-03-08 | T2 | 1528h | 1528h |  | Ericsson | Alan.Baldwin@EML.ERICSSON.SE | Rel-5 | Kimmo |  |
| 5532 | 99 | **GERAN Inter BSC NACC improvements over the Gb Interface** | 215d | 2001-09-03 A | 2002-06-28 A |  | 100% | 2001-09-03 | 2002-06-28 | 215d |  | GP | 11184h | 11184h | GERNACC |  |  | Rel-5 | Paolo | GERNACC |
| 5533 | 99.1 | **Modification of core network protocols for GERAN Inter BSC NACC over Gb Interface** | 165d | 2001-09-03 A | 2002-04-19 A |  | 100% | 2001-09-03 | 2002-04-19 | 165d |  | N4; S2 | 7048h | 7048h | GERNACC-Cnmod |  |  | Rel-5 | Kimmo | GERNACC-Cnmod |
| 5534 | 99.1.1 | Stage 2 - Concept | 43d | 2001-09-03 A | 2001-10-31 A |  | 100% | 2001-09-03 | 2001-10-31 | 43d | finish no earlier than 2001-10-31 | N4; S2 | 688h | 688h |  |  |  | Rel-5 | Kimmo |  |
| 5535 | 99.1.2 | Stage 2 - 23.060 change - Definition of Inter BSC NACC | 165d | 2001-09-03 A | 2002-04-19 A |  | 100% | 2001-09-03 | 2002-04-19 | 165d | finish no earlier than 2002-04-19 | N4; S2 | 2640h | 2640h |  |  |  | Rel-5 | Kimmo |  |
| 5536 | 99.1.3 | Stage 3 (changes to TS 29.060) | 135d | 2001-09-03 A | 2002-03-08 A |  | 100% | 2001-09-03 | 2002-03-08 | 135d | finish no earlier than 2002-03-08 | N4 | 1080h | 1080h |  |  |  | Rel-5 | Kimmo |  |

Notes:
- 5511: SBC, Motorola, Nokia, Ericsson, Nortel
- 5512: -
- 5513: -
- 5514: -
- 5515: -
- 5516: Lucent, Ericsson, AWS, Nortel
- 5517: -
- 5518: -
- 5519: Acronym changed from "E2EQoS, Rel-5"
- 5520: - / Impacted TSs and TRs: 23.207
- 5521: [DAB - 30/07/02] - % complete to 95% (if we exclude Diffserv). Marked as closed 12/2008 (was marked 95% complete) / Impacted TSs and TRs: 29.208, 29.207, 27.060, 29.061, 24.008, 24.228, , 24.229, 29.060, 29.163
- 5522: - / Impacted TSs and TRs: 32-series
- 5523: support of UAProf, so this in my opinion is 100% complete
- 5524: -
- 5525: - / Impacted TSs and TRs: 22.140
- 5526: stage 3 MM7 is missing / Impacted TSs and TRs: 23.140
- 5527: Marked as closed 12/2008 (was marked 80% complete)
- 5528: - / Impacted TSs and TRs: 26.140
- 5529: - / Impacted TSs and TRs: 23.040
- 5530: -
- 5531: - / Impacted TSs and TRs: 23.040
- 5532: -
- 5533: -
- 5534: -
- 5535: -
- 5536: IP 30/11/01: Input awaited from GERAN2 to CN4

| ID | WBS | Task | Duration | Start | Finish | Complete | Baseline start | Baseline finish | Baseline duration | Constraint | Resources | Work | Actual work | Acronym | Release | MCC resp | Acronym_3GU_Export | TSG stopped | WI rapporteur name | WI rapporteur e-mail |
| --- | --- | --- | --- | --- | --- | --- | --- | --- | --- | --- | --- | --- | --- | --- | --- | --- | --- | --- | --- | --- |
| 5537 | 99.2 | **Modification of Gb protocols for GERAN Inter BSC NACC over Gb Interface** | 151d | 2001-11-30 A | 2002-06-28 A | 100% | 2001-11-30 | 2002-06-28 | 151d |  | GP | 2416h | 2416h | GERNACC-Gbmod | Rel-5 | Paolo | GERNACC-Gbmod |  |  |  |
| 5538 | 99.2.1 | Stage 3 (changes to TS 48.018) | 151d | 2001-11-30 A | 2002-06-28 A | 100% | 2001-11-30 | 2002-06-28 | 151d | finish no earlier than 2002-06-28 | GP | 1208h | 1208h |  | Rel-5 | Paolo |  |  |  |  |
| 5539 | 100 | **Enhanced Power Control** | 540d | 2001-11-26 A | 2003-12-19 A | 100% | 2001-11-26 | 2003-12-19 | 540d |  | GP | 12840h | 12840h | EPC | Rel-5 | Paolo | EPC |  |  |  |
| 5540 | 100.1 | Realization of Enhanced power control and signalling support | 5d | 2001-11-26 A | 2001-11-30 A | 100% | 2001-11-26 | 2001-11-30 | 5d | finish no earlier than 2001-11-30 | GP | 40h | 40h |  | Rel-5 | Paolo |  |  |  |  |
| 5541 | 100.2 | Deleted - GERAN MS Conformance test for Enhanced Power Control | 530d | 2001-12-10 A | 2003-12-19 A | 100% | 2001-12-10 | 2003-12-19 | 530d | finish no earlier than 2003-12-19 | GP | 4240h | 4240h |  | Rel-5 | Paolo |  | GP-17 |  |  |
| 5542 | 100.3 | Deleted - GERAN BTS Conformance test for Enhanced Power Control | 530d | 2001-12-10 A | 2003-12-19 A | 100% | 2001-12-10 | 2003-12-19 | 530d | finish no earlier than 2003-12-19 | GP | 4240h | 4240h |  | Rel-5 | Paolo |  | GP-17 |  |  |
| 5543 | 101 | **8PSK AMR HR** | 530d | 2001-12-10 A | 2003-12-19 A | 100% | 2001-12-10 | 2003-12-19 | 530d |  | GP | 21080h | 21080h | 8PSK-AH | Rel-5 | Paolo | 8PSK-AH |  |  |  |
| 5544 | 101.1 | **Definition of channel coding, performance requirements and signalling support** | 145d | 2001-12-10 A | 2002-06-28 A | 100% | 2001-12-10 | 2002-06-28 | 145d |  | GP | 10440h | 10440h |  | Rel-5 | Paolo |  |  |  |  |
| 5545 | 101.1.1 | Concept | 145d | 2001-12-10 A | 2002-06-28 A | 100% | 2001-12-10 | 2002-06-28 | 145d | finish no earlier than 2002-06-28 | GP | 1160h | 1160h |  | Rel-5 | Paolo |  |  |  |  |
| 5546 | 101.1.2 | Changes to 44.018 | 145d | 2001-12-10 A | 2002-06-28 A | 100% | 2001-12-10 | 2002-06-28 | 145d | finish no earlier than 2002-06-28 | G2 | 1160h | 1160h |  | Rel-5 | Gert |  |  |  |  |
| 5547 | 101.1.3 | Changes to 45.001 | 145d | 2001-12-10 A | 2002-06-28 A | 100% | 2001-12-10 | 2002-06-28 | 145d | finish no earlier than 2002-06-28 | G1 | 1160h | 1160h |  | Rel-5 | Paolo |  |  |  |  |
| 5548 | 101.1.4 | Changes to 45.002 | 145d | 2001-12-10 A | 2002-06-28 A | 100% | 2001-12-10 | 2002-06-28 | 145d | finish no earlier than 2002-06-28 | G1 | 1160h | 1160h |  | Rel-5 | Paolo |  |  |  |  |
| 5549 | 101.1.5 | Changes to 45.003 | 145d | 2001-12-10 A | 2002-06-28 A | 100% | 2001-12-10 | 2002-06-28 | 145d | finish no earlier than 2002-06-28 | G1 | 1160h | 1160h |  | Rel-5 | Paolo |  |  |  |  |
| 5550 | 101.1.6 | Changes to 45.005 | 145d | 2001-12-10 A | 2002-06-28 A | 100% | 2001-12-10 | 2002-06-28 | 145d | finish no earlier than 2002-06-28 | G1 | 1160h | 1160h |  | Rel-5 | Paolo |  |  |  |  |
| 5551 | 101.1.7 | Changes to 24.008 | 145d | 2001-12-10 A | 2002-06-28 A | 100% | 2001-12-10 | 2002-06-28 | 145d | finish no earlier than 2002-06-28 | G2 | 1160h | 1160h |  | Rel-5 | Gert |  |  |  |  |
| 5552 | 101.1.8 | Changes to 48.058 | 145d | 2001-12-10 A | 2002-06-28 A | 100% | 2001-12-10 | 2002-06-28 | 145d | finish no earlier than 2002-06-28 | G2 | 1160h | 1160h |  | Rel-5 | Gert |  |  |  |  |
| 5553 | 101.2 | Deleted - GERAN MS Conformance test for 8PSK HR | 530d | 2001-12-10 A | 2003-12-19 A | 100% | 2001-12-10 | 2003-12-19 | 530d | finish no earlier than 2003-12-19 | GP | 4240h | 4240h |  | Rel-5 | Paolo |  | GP-17 |  |  |
| 5554 | 101.3 | GERAN BTS Conformance test for 8PSK HR | 270d | 2001-12-10 A | 2002-12-20 A | 100% | 2001-12-10 | 2002-12-20 | 270d | finish no earlier than 2002-12-20 | GP | 2160h | 2160h |  | Rel-5 | Paolo |  |  |  |  |
| 5555 | 102 | Service Change and UDI Fallback | 175d | 2001-10-08 A | 2002-06-07 A | 100% | 2001-10-08 | 2002-06-07 | 175d | finish no earlier than 2002-06-07 | N3 | 1400h | 1400h | SCUDIF | Rel-5 | Gwiho | SCUDIF |  | Ericsson | Rune.Werner.Wiik@ericsson.no |
| 5556 | 103 | **Rel-5 USIM toolkit enhancements** | 865d | 2000-06-05 A | 2003-09-26 A | 100% | 2000-06-05 | 2003-09-26 | 865d |  | T3; S1 | 36776h | 36776h | USAT5 | Rel-5 | Xavier | USAT1, USAT1-Interpr, USAT1LocLnk |  | G & D | Michael Meyer |
| 5557 | 103.1 | Deleted - Test specification for USIM toolkit security mechanisms | 349d | 2002-05-28 A | 2003-09-26 A | 100% | 2002-05-28 | 2003-09-26 | 349d | finish no earlier than 2003-09-26 | T3 | 2792h | 2792h |  | Rel-5 | Xavier |  | TP-21 | Gemplus | Sophie Viallet |
| 5558 | 103.2 | **Protocol Standardisation of a SIM Toolkit Interpreter** | 688d | 2000-06-05 A | 2003-01-22 A | 100% | 2000-06-05 | 2003-01-22 | 688d |  | T3; T2 | 18016h | 18016h |  | Rel-5 | Xavier |  |  | G & D | Michael Meyer |
| 5559 | 103.2.1 | Stage 1 for Protocol Standardisation of a SIM Toolkit Interpreter | 205d | 2000-06-05 A | 2001-03-16 A | 100% | 2000-06-05 | 2001-03-16 | 205d | finish no earlier than 2001-03-16 | T3 | 1640h | 1640h |  | Rel-5 | Xavier |  |  |  |  |
| 5560 | 103.2.2 | Stage 2 and 3 | 308d | 2001-01-03 A | 2002-03-08 A | 100% | 2001-01-03 | 2002-03-08 | 308d | finish no earlier than 2002-03-08 | T3 | 2464h | 2464h |  | Rel-5 | Xavier |  |  |  |  |
| 5561 | 103.2.3 | Test specification for Protocol Standardisation of a SIM Toolkit Interpreter | 363d | 2001-09-03 A | 2003-01-22 A | 100% | 2001-09-03 | 2003-01-22 | 363d | finish no earlier than 2003-01-22 | T3 | 2904h | 2904h |  | Rel-5 | Xavier |  |  | Gemplus | Gérald MAUNIER |

Notes:
- 5537: -
- 5538: -
- 5539: -
- 5540: Completed 11/2001
- 5541: Not started. Marked as stopped 12/2008
- 5542: Not started. Marked as stopped 12/2008
- 5543: Completed for Rel-5
- 5544: -
- 5545: -
- 5546: -
- 5547: -
- 5548: -
- 5549: -
- 5550: -
- 5551: -
- 5552: -
- 5553: Marked as stopped 12/2008
- 5554: -
- 5555: - / Impacted TSs and TRs: 29.007, 27.001, 24.008
- 5556: Acronym changed from USAT1, USAT1-Interpr, USAT1LocLnk / Impacted TSs and TRs: 22.038, 31.111 (USAT1), 22.038, 03.19, 03.48 (USAT1LocLnk), 23.048 (USAT1SM), 43.019 (USAT1APIJAVA)
- 5557: Marked as stopped 12/2008
- 5558: 28/5/2001: T3-19 proposed that since the stage 2 and 3 will not be presented to TP-12 for approval as expected, the WI will be moved to rel-5, with completion expected at TP-13. / Impacted TSs and TRs: T2 27.103
- 5559: 5/10/2001: Stage one comepeted at TP-12. / Impacted TSs and TRs: 31.112, 31.113, 31.114
- 5560: 5/10/2001: TS 31.112 and 31.113 approved at TP-13. TS 31.114 to be presented to TP-14. / Impacted TSs and TRs: 31.112, 31.113, 31.114
- 5561: 5/10/2001: Work started on test specification. Marked as closed 12/2008 (was marked 12% complete)

| ID | WBS | Task | Type | Duration | Start | Finish | Complete | Baseline start | Baseline finish | Baseline duration | Constraint | Resources | Work | Actual work | Acronym | WI rapporteur name | WI rapporteur e-mail | Release | MCC resp | Acronym_3GU_Export | TSG stopped |
| --- | --- | --- | --- | --- | --- | --- | --- | --- | --- | --- | --- | --- | --- | --- | --- | --- | --- | --- | --- | --- | --- |
| 5562 | 103.4 | **(U)SIM API** |  | 133d | 2002-03-20 A | 2002-09-20 A | 100% | 2002-03-20 | 2002-09-20 | 133d |  | T3 | 2128h | 2128h | USAT5-API | Microelectrónica Española | Mario Pérez | Rel-5 | Xavier | USAT1-API, TEI4 |  |
| 5563 | 103.4.1 | Rel-5 Java API Test specification |  | 133d | 2002-03-20 A | 2002-09-20 A | 100% | 2002-03-20 | 2002-09-20 | 133d | finish no earlier than 2002-09-20 | T3 | 1064h | 1064h |  | Microelectrónica Española | Mario Pérez | Rel-5 | Xavier |  |  |
| 5564 | 104 | (Small) Technical Enhancements and Improvements for Rel-5 | milestone | 0d? | 2000-01-03 A | 2000-01-03 A | 100% | 2000-01-03 | 2000-01-03 | 0d? |  | SP; CP; RP; GP |  |  | TEI5 |  |  | Rel-5 | all | TEI5 |  |
| 5565 | 1431 | Test - (Small) Technical Enhancements and Improvements for Rel-5 |  | 2349d? | 2000-01-03 A | 2008-12-31 A | 100% | 2000-01-03 | 2008-12-31 | 2349d? | finish no earlier than 2008-12-31 | R5; T1 | 37584h | 37584h | TEI5_Test |  |  | Rel-5 | Ingbert | TEI5_Test |  |
| 5566 | 105 | Technical Report on UE Functionality Split |  | 87d | 2000-01-03 A | 2000-05-01 A | 100% | 2000-01-03 | 2000-05-01 | 87d |  | S1 | 688h | 688h | UESPLIT | Motorola | jian.j.wu@motorola.com | Rel-5 | Alain | UESPLIT |  |
| 5567 | 106 | **User Equipment Management** |  | 267d | 2001-06-21 A | 2002-06-28 A | 100% | 2001-06-21 | 2002-06-28 | 267d |  | S5 | 3752h | 3752h | UEM | Vodafone | john.mudge@vf.vodafone.co.uk | Rel-5 | Mirko | UEM |  |
| 5568 | 106.1 | FS on User Equipment (UE) Management |  | 267d | 2001-06-21 A | 2002-06-28 A | 100% | 2001-06-21 | 2002-06-28 | 267d | finish no earlier than 2002-06-28 | S5 | 2136h | 2136h | OAM-UEM | Vodafone | john.mudge@vf.vodafone.co.uk | Rel-5 | Mirko | OAM-UEM |  |
| 5569 | 107 | **Flow control supporting an MS with multiple data flows with different QoS over the Gb interface** |  | 50d | 2002-06-24 A | 2002-08-30 A | 100% | 2002-06-24 | 2002-08-30 | 50d |  | GP | 1288h | 1288h | FlowCon | Ericsson | ingemar.backlund@era.ericsson.se | Rel-5 | Paolo | FlowCon |  |
| 5570 | 107.1 | **Update of stage 2 specifications** |  | 50d | 2002-06-24 A | 2002-08-30 A | 100% | 2002-06-24 | 2002-08-30 | 50d |  | GP | 808h | 808h |  |  |  | Rel-5 | Paolo |  |  |
| 5571 | 107.1.1 | Concept document 23.060 (changes to) |  | 46d | 2002-06-28 A | 2002-08-30 A | 100% | 2002-06-28 | 2002-08-30 | 46d | finish no earlier than 2002-08-30 | S2 | 368h | 368h |  |  |  | Rel-5 | Maurice |  |  |
| 5572 | 107.1.2 | Flow Control |  | 5d | 2002-06-24 A | 2002-06-28 A | 100% | 2002-06-24 | 2002-06-28 | 5d | finish no earlier than 2002-06-28 | GP | 40h | 40h |  |  |  | Rel-5 | Paolo |  |  |
| 5573 | 107.2 | **Modification of BSSGP protocol** |  | 5d | 2002-06-24 A | 2002-06-28 A | 100% | 2002-06-24 | 2002-06-28 | 5d |  | GP | 80h | 80h |  | Ericsson | ingemar.backlund@era.ericsson.se | Rel-5 | Paolo |  |  |
| 5574 | 107.2.1 | Stage 3 (changes to 48.018) |  | 5d | 2002-06-24 A | 2002-06-28 A | 100% | 2002-06-24 | 2002-06-28 | 5d | finish no earlier than 2002-06-28 | G2 | 40h | 40h |  |  |  | Rel-5 | Gert |  |  |
| 5575 | 108 | **Deleted - Multiple TBF in A/Gb mode - Phase 1 (MULTBF)** |  | 421d | 2002-04-19 A | 2003-11-28 A | 100% | 2002-04-19 | 2003-11-28 | 421d |  | GP | 17480h | 17480h |  | Ericsson | gunnar.mildh@era.ericsson.se | Rel-5 | Paolo |  | GP-17 |
| 5576 | 108.1 | **Deleted - Multiple TBF in A/Gb mode - Core (MULTBF-Agbmode)** |  | 351d | 2002-04-19 A | 2003-08-22 A | 100% | 2002-04-19 | 2003-08-22 | 351d |  | GP | 8112h | 8112h |  |  |  | Rel-5 | Paolo |  | GP-17 |
| 5577 | 108.1.1 | Deleted - Multiple TBF Concept paper |  | 351d | 2002-04-19 A | 2003-08-22 A | 100% | 2002-04-19 | 2003-08-22 | 351d | finish no earlier than 2003-08-22 | GP | 2808h | 2808h |  |  |  | Rel-5 | Paolo |  | GP-17 |
| 5578 | 108.1.2 | Deleted - Multiple TBF Stage 2 (43.064) CRs |  | 156d | 2002-04-19 A | 2002-11-22 A | 100% | 2002-04-19 | 2002-11-22 | 156d | finish no earlier than 2002-11-22 | G1 | 1248h | 1248h |  |  |  | Rel-5 | Paolo |  | GP-12 |
| 5579 | 108.1.3 | Deleted - Multiple TBF Stage 3 (44.060) CRs |  | 156d | 2002-04-19 A | 2002-11-22 A | 100% | 2002-04-19 | 2002-11-22 | 156d | finish no earlier than 2002-11-22 | G2 | 1248h | 1248h |  |  |  | Rel-5 | Gert |  | GP-12 |
| 5580 | 108.2 | **Deleted - Multiple TBF in A/Gb mode - Phase 1 – MS testing** |  | 375d | 2002-06-24 A | 2003-11-28 A | 100% | 2002-06-24 | 2003-11-28 | 375d |  | GP | 6000h | 6000h |  | Ericsson | ingemar.backlund@era.ericsson.se | Rel-5 | Paolo |  | GP-17 |
| 5581 | 108.2.1 | Deleted - MS conformance tests for Multiple TBF in A/Gb mode |  | 375d | 2002-06-24 A | 2003-11-28 A | 100% | 2002-06-24 | 2003-11-28 | 375d | finish no earlier than 2003-11-28 | G4 | 3000h | 3000h |  |  |  | Rel-5 | Paolo |  | GP-17 |
| 5582 | 109 | **Alignment of 3G functional split and Iu** |  | 922d | 2000-06-08 A | 2003-12-19 A | 100% | 2000-06-08 | 2003-12-19 | 922d |  | GP | 165704h | 165704h | GER3GAL | Ericsson | Frank Muller | Rel-5 | Paolo | GER3GAL |  |
| 5583 | 109.1 | **GERAN user / control plane** |  | 540d | 2000-08-07 A | 2002-08-30 A | 100% | 2000-08-07 | 2002-08-30 | 540d |  | GP | 36232h | 36232h | GER3GAL-GUCOPL | Ericsson | Frank Muller | Rel-5 | Paolo | GER3GAL-GUCOPL |  |
| 5584 | 109.1.1 | **Alignment with UMTS bearer concept** |  | 540d | 2000-08-07 A | 2002-08-30 A | 100% | 2000-08-07 | 2002-08-30 | 540d |  | GP | 24952h | 24952h |  |  |  | Rel-5 | Paolo |  |  |
| 5585 | 109.1.1.1 | Enhanced power control - for Alignment with UMTS bearer concept |  | 1d | 2001-08-31 A | 2001-08-31 A | 100% | 2001-08-31 | 2001-08-31 | 1d | finish no earlier than 2001-08-31 | GP | 8h | 8h |  |  |  | Rel-5 | Paolo |  |  |
| 5586 | 109.1.1.2 | Stage 2 - for Alignment with UMTS bearer concept |  | 235d | 2000-08-07 A | 2001-06-29 A | 100% | 2000-08-07 | 2001-06-29 | 235d | finish no earlier than 2001-06-29 | GP | 1880h | 1880h |  |  |  | Rel-5 | Paolo |  |  |
| 5587 | 109.1.1.3 | Adoption of the UTRAN PDCP |  | 295d | 2000-11-06 A | 2001-12-21 A | 100% | 2000-11-06 | 2001-12-21 | 295d | finish no earlier than 2001-12-21 | GP | 2360h | 2360h |  |  |  | Rel-5 | Paolo |  |  |
| 5588 | 109.1.1.4 | Development of RLC / MAC |  | 261d | 2001-08-31 A | 2002-08-30 A | 100% | 2001-08-31 | 2002-08-30 | 261d | finish no earlier than 2002-08-30 | GP | 2088h | 2088h |  |  |  | Rel-5 | Paolo |  |  |
| 5589 | 109.1.1.5 | Development of GERAN RRC |  | 266d | 2001-06-22 A | 2002-06-28 A | 100% | 2001-06-22 | 2002-06-28 | 266d | finish no earlier than 2002-06-28 | GP | 2128h | 2128h |  |  |  | Rel-5 | Paolo |  |  |
| 5590 | 109.1.1.6 | Ciphering and integrity protection concept paper |  | 166d | 2001-08-31 A | 2002-04-19 A | 100% | 2001-08-31 | 2002-04-19 | 166d | finish no earlier than 2002-04-19 | GP | 1328h | 1328h |  |  |  | Rel-5 | Paolo |  |  |
| 5591 | 109.1.1.7 | Multiple TBF or equivalent Concept paper |  | 116d | 2001-08-31 A | 2002-02-08 A | 100% | 2001-08-31 | 2002-02-08 | 116d | finish no earlier than 2002-02-08 | GP | 928h | 928h |  |  |  | Rel-5 | Paolo |  |  |
| 5592 | 109.1.1.8 | Paging concept |  | 166d | 2001-08-31 A | 2002-04-19 A | 100% | 2001-08-31 | 2002-04-19 | 166d | finish no earlier than 2002-04-19 | GP | 1328h | 1328h |  |  |  | Rel-5 | Paolo |  |  |
| 5593 | 109.1.1.9 | Dedicated Physical subchannels, includes traffic and control channels |  | 66d | 2001-08-31 A | 2001-11-30 A | 100% | 2001-08-31 | 2001-11-30 | 66d | finish no earlier than 2001-11-30 | GP | 528h | 528h |  |  |  | Rel-5 | Paolo |  |  |
| 5594 | 109.1.1.10 | Iu support and broadcast concept |  | 166d | 2001-08-31 A | 2002-04-19 A | 100% | 2001-08-31 | 2002-04-19 | 166d | finish no earlier than 2002-04-19 | GP | 1328h | 1328h |  |  |  | Rel-5 | Paolo |  |  |
| 5595 | 109.1.1.11 | Impact of using RLC instead of LAPDm concept |  | 116d | 2001-08-31 A | 2002-02-08 A | 100% | 2001-08-31 | 2002-02-08 | 116d | finish no earlier than 2002-02-08 | GP | 928h | 928h |  |  |  | Rel-5 | Paolo |  |  |
| 5596 | 109.1.1.12 | Contention resolution, mobile station identity, and access concept |  | 66d | 2001-08-31 A | 2001-11-30 A | 100% | 2001-08-31 | 2001-11-30 | 66d | finish no earlier than 2001-11-30 | GP | 528h | 528h |  |  |  | Rel-5 | Paolo |  |  |
| 5597 | 109.1.1.13 | PDCP concept |  | 166d | 2001-08-31 A | 2002-04-19 A | 100% | 2001-08-31 | 2002-04-19 | 166d | finish no earlier than 2002-04-19 | GP | 1328h | 1328h |  |  |  | Rel-5 | Paolo |  |  |
| 5598 | 109.1.1.14 | Downlink delayed TBF release |  | 261d | 2001-08-31 A | 2002-08-30 A | 100% | 2001-08-31 | 2002-08-30 | 261d | finish no earlier than 2002-08-30 | GP | 2088h | 2088h |  |  |  | Rel-5 | Paolo |  |  |
| 5599 | 109.1.1.15 | Add transparent RLC Concept |  | 116d | 2001-08-31 A | 2002-02-08 A | 100% | 2001-08-31 | 2002-02-08 | 116d | finish no earlier than 2002-02-08 | GP | 928h | 928h |  |  |  | Rel-5 | Paolo |  |  |
| 5600 | 109.1.1.16 | Handover concept |  | 116d | 2001-08-31 A | 2002-02-08 A | 100% | 2001-08-31 | 2002-02-08 | 116d | finish no earlier than 2002-02-08 | GP | 928h | 928h |  |  |  | Rel-5 | Paolo |  |  |

Notes:
- 5562: 8/3/2001: test spec is based on R99 core spec, so deleted from Workplan. Acronym changed from USAT1-API, TEI4
- 5563: - / Impacted TSs and TRs: 51.013
- 5564: "Joker" WI, to be used for a Rel 5 CR not related to any feature and with very limited impact on the system
- 5565: "Joker" WI, to be used for small modifications applicable to Rel 5 conformance testing. Moved in from Stoyan/testing WP. / Impacted TSs and TRs: 34.108, 34.109, 34.121-1, 34.121-2, 34.122, 34.123-1, 34.123-2, 34.123-3, 34.171, 34.229-1, 34.229-2, 34.229-3
- 5566: - / Impacted TSs and TRs: New TR 22.944
- 5567: - / Impacted TSs and TRs: 32.802
- 5568: - / Impacted TSs and TRs: 32.802
- 5569: 50101 -> 50201
- 5570: 50102 -> 50202
- 5571: -
- 5572: 50103 -> 50203
- 5573: 50104 -> 50204
- 5574: -
- 5575: GP#17 Nov 2003 Moved to Rel-6 as UID_50600 MULTBF (Only Multiple TBF Concept paper produced in Rel-5)
- 5576: Marked as closed 12/2008 (was marked 26% complete)
- 5577: Marked as closed 12/2008 (was marked 50% complete)
- 5578: Marked as stopped 12/2008
- 5579: Marked as stopped 12/2008
- 5580: 08/08: duplicate UID_50106=-> 50206. Marked as stopped 12/2008
- 5581: Not started. Marked as stopped 12/2008
- 5582: AWS, Nokia, Ericsson, Nortel, Siemens, Vodafone
- 5583: AWS, Nokia, Ericsson, Nortel, Siemens, Vodafone
- 5584: -
- 5585: -
- 5586: -
- 5587: Responsible is GERAN; RAN WG2 help may be needed.
- 5588: -
- 5589: -
- 5590: -
- 5591: -
- 5592: -
- 5593: -
- 5594: -
- 5595: -
- 5596: -
- 5597: -
- 5598: -
- 5599: -
- 5600: -

| ID | WBS | Task | Duration | Start | Finish | Complete | Baseline start | Baseline finish | Baseline duration | Constraint | Resources | Work | Actual work | Release | MCC resp | Acronym | WI rapporteur name | WI rapporteur e-mail | Acronym_3GU_Export |
| --- | --- | --- | --- | --- | --- | --- | --- | --- | --- | --- | --- | --- | --- | --- | --- | --- | --- | --- | --- |
| 5601 | 109.1.2 | **Physical layer alignment with UMTS bearer concept** | 280d | 2000-11-06 A | 2001-11-30 A | 100% | 2000-11-06 | 2001-11-30 | 280d |  | GP | 6960h | 6960h | Rel-5 | Paolo |  |  |  |  |
| 5602 | 109.1.2.1 | PDTCH/TCH in 45.003 | 155d | 2000-11-06 A | 2001-06-08 A | 100% | 2000-11-06 | 2001-06-08 | 155d | finish no earlier than 2001-06-08 | GP | 1240h | 1240h | Rel-5 | Paolo |  |  |  |  |
| 5603 | 109.1.2.2 | Control channels in 45.003 | 155d | 2000-11-06 A | 2001-06-08 A | 100% | 2000-11-06 | 2001-06-08 | 155d | finish no earlier than 2001-06-08 | GP | 1240h | 1240h | Rel-5 | Paolo |  |  |  |  |
| 5604 | 109.1.2.3 | Receiver performance in 45.005 for PDTCH/TCH and control channels | 280d | 2000-11-06 A | 2001-11-30 A | 100% | 2000-11-06 | 2001-11-30 | 280d | finish no earlier than 2001-11-30 | GP | 2240h | 2240h | Rel-5 | Paolo |  |  |  |  |
| 5605 | 109.2 | **Iu rg interface** | 430d | 2000-11-06 A | 2002-06-28 A | 100% | 2000-11-06 | 2002-06-28 | 430d |  | GP; RP | 61920h | 61920h | Rel-5 | Paolo | GER3GAL-Iurg | Ericsson | Frank Muller | GER3GAL-Iurg |
| 5606 | 109.2.1 | **Inter BSS interface** | 430d | 2000-11-06 A | 2002-06-28 A | 100% | 2000-11-06 | 2002-06-28 | 430d |  | GP; RP | 24080h | 24080h | Rel-5 | Paolo |  |  |  |  |
| 5607 | 109.2.1.1 | Identification of requirements for Inter BSS interface | 430d | 2000-11-06 A | 2002-06-28 A | 100% | 2000-11-06 | 2002-06-28 | 430d | finish no earlier than 2002-06-28 | GP | 3440h | 3440h | Rel-5 | Paolo |  |  |  |  |
| 5608 | 109.2.1.2 | Stage 2 for Inter BSS interface | 430d | 2000-11-06 A | 2002-06-28 A | 100% | 2000-11-06 | 2002-06-28 | 430d | finish no earlier than 2002-06-28 | GP | 3440h | 3440h | Rel-5 | Paolo |  |  |  |  |
| 5609 | 109.2.1.3 | Adoption of relevant parts from Iur - for Inter BSS interface | 430d | 2000-11-06 A | 2002-06-28 A | 100% | 2000-11-06 | 2002-06-28 | 430d | finish no earlier than 2002-06-28 | GP | 3440h | 3440h | Rel-5 | Paolo |  |  |  |  |
| 5610 | 109.2.1.4 | Complementation with GERAN specifics - for Inter BSS interface | 430d | 2000-11-06 A | 2002-06-28 A | 100% | 2000-11-06 | 2002-06-28 | 430d | finish no earlier than 2002-06-28 | GP | 3440h | 3440h | Rel-5 | Paolo |  |  |  |  |
| 5611 | 109.2.1.5 | Stage 3 for Inter BSS interface | 430d | 2000-11-06 A | 2002-06-28 A | 100% | 2000-11-06 | 2002-06-28 | 430d | finish no earlier than 2002-06-28 | GP | 3440h | 3440h | Rel-5 | Paolo |  |  |  |  |
| 5612 | 109.2.2 | **Inter BSS-RNS interface** | 430d | 2000-11-06 A | 2002-06-28 A | 100% | 2000-11-06 | 2002-06-28 | 430d |  | GP; RP | 30960h | 30960h | Rel-5 | Paolo |  |  |  |  |
| 5613 | 109.2.2.1 | Identification of requirements for Inter BSS-RNS interface | 430d | 2000-11-06 A | 2002-06-28 A | 100% | 2000-11-06 | 2002-06-28 | 430d | start no earlier than 2000-11-06 | GP; R3 | 6880h | 6880h | Rel-5 | Paolo |  |  |  |  |
| 5614 | 109.2.2.2 | Stage 2 for Inter BSS-RNS interface | 430d | 2000-11-06 A | 2002-06-28 A | 100% | 2000-11-06 | 2002-06-28 | 430d | finish no earlier than 2002-06-28 | GP; R3 | 6880h | 6880h | Rel-5 | Paolo |  |  |  |  |
| 5615 | 109.2.2.3 | Adoption of relevant parts from Iur - for Inter BSS-RNS interface | 430d | 2000-11-06 A | 2002-06-28 A | 100% | 2000-11-06 | 2002-06-28 | 430d | finish no earlier than 2002-06-28 | GP; R3 | 6880h | 6880h | Rel-5 | Paolo |  |  |  |  |
| 5616 | 109.2.2.4 | Complementation with GERAN specifics - for Inter BSS-RNS interface | 107.5d | 2002-01-30 A | 2002-06-28 A | 100% | 2002-01-30 | 2002-06-28 | 107.5d | finish no earlier than 2002-06-28 | GP; R3 | 1720h | 1720h | Rel-5 | Paolo |  |  |  |  |
| 5617 | 109.2.2.5 | Stage 3 for Inter BSS-RNS interface | 107.5d | 2002-01-30 A | 2002-06-28 A | 100% | 2002-01-30 | 2002-06-28 | 107.5d | finish no earlier than 2002-06-28 | GP; R3 | 1720h | 1720h | Rel-5 | Paolo |  |  |  |  |
| 5618 | 109.3 | **Voice over GERAN PS and CS concept** | 430d | 2000-11-06 A | 2002-06-28 A | 100% | 2000-11-06 | 2002-06-28 | 430d |  | GP; R3 | 35200h | 35200h | Rel-5 | Paolo |  |  |  |  |
| 5619 | 109.3.1 | Architecture for A, Iu cs and Iu ps | 430d | 2000-11-06 A | 2002-06-28 A | 100% | 2000-11-06 | 2002-06-28 | 430d | finish no earlier than 2002-06-28 | GP; R3 | 6880h | 6880h | Rel-5 | Paolo |  |  |  |  |
| 5620 | 109.3.2 | Transcoder position/operation | 115d | 2000-11-06 A | 2001-04-13 A | 100% | 2000-11-06 | 2001-04-13 | 115d | finish no earlier than 2001-04-13 | GP | 920h | 920h | Rel-5 | Paolo |  |  |  |  |
| 5621 | 109.3.3 | Handover for Voice over GERAN PS and CS | 430d | 2000-11-06 A | 2002-06-28 A | 100% | 2000-11-06 | 2002-06-28 | 430d | finish no earlier than 2002-06-28 | GP; R3 | 6880h | 6880h | Rel-5 | Paolo |  |  |  |  |
| 5622 | 109.3.4 | RTP payload | 430d | 2000-11-06 A | 2002-06-28 A | 100% | 2000-11-06 | 2002-06-28 | 430d | finish no earlier than 2002-06-28 | GP; R3 | 6880h | 6880h | Rel-5 | Paolo |  |  |  |  |
| 5623 | 109.3.5 | Codec renegotiation concept | 365d | 2000-11-06 A | 2002-03-29 A | 100% | 2000-11-06 | 2002-03-29 | 365d | finish no earlier than 2002-03-29 | GP; R3 | 5840h | 5840h | Rel-5 | Paolo |  |  |  |  |
| 5624 | 109.3.6 | LA | 115d | 2000-11-06 A | 2001-04-13 A | 100% | 2000-11-06 | 2001-04-13 | 115d | finish no earlier than 2001-04-13 | GP | 920h | 920h | Rel-5 | Paolo |  |  |  |  |

Notes:
- 5601: -
- 5602: -
- 5603: -
- 5604: -
- 5605: AWS, Nokia, Ericsson, Nortel, Siemens, Vodafone
- 5606: -
- 5607: -
- 5608: -
- 5609: -
- 5610: -
- 5611: -
- 5612: -
- 5613: -
- 5614: -
- 5615: -
- 5616: -
- 5617: -
- 5618: -
- 5619: -
- 5620: -
- 5621: -
- 5622: -
- 5623: -
- 5624: -

| ID | WBS | Task | Duration | Start | Finish | Complete | Baseline start | Baseline finish | Baseline duration | Constraint | Resources | Work | Actual work | Release | MCC resp | TSG stopped | Acronym | WI rapporteur name | WI rapporteur e-mail | Acronym_3GU_Export | Impacted TSs and TRs |
| --- | --- | --- | --- | --- | --- | --- | --- | --- | --- | --- | --- | --- | --- | --- | --- | --- | --- | --- | --- | --- | --- |
| 5625 | 109.4 | **Deleted - GERAN MS Conformance test for GERAN interface evolution** | 660d | 2001-06-11 A | 2003-12-19 A | 100% | 2001-06-11 | 2003-12-19 | 660d |  | GP | 10560h | 10560h | Rel-5 | Paolo | GP-17 |  |  |  |  |  |
| 5626 | 109.4.1 | Deleted - MS test for GERAN interface evolution | 660d | 2001-06-11 A | 2003-12-19 A | 100% | 2001-06-11 | 2003-12-19 | 660d | finish no earlier than 2003-12-19 | GP | 5280h | 5280h | Rel-5 | Paolo | GP-17 |  |  |  |  |  |
| 5627 | 109.5 | **GERAN BSS Conformance test for GERAN interface evolution** | 922d | 2000-06-08 A | 2003-12-19 A | 100% | 2000-06-08 | 2003-12-19 | 922d |  | GP | 14752h | 14752h | Rel-5 | Paolo |  |  |  |  |  |  |
| 5628 | 109.5.1 | Deleted - BSS test | 922d | 2000-06-08 A | 2003-12-19 A | 100% | 2000-06-08 | 2003-12-19 | 922d | finish no earlier than 2003-12-19 | GP | 7376h | 7376h | Rel-5 | Paolo | GP-17 |  |  |  |  |  |
| 5629 | 110 | **GERAN support for IMS** | 690d | 2000-05-01 A | 2002-12-20 A | 100% | 2000-05-01 | 2002-12-20 | 690d |  | GP | 83939.6h | 83939.6h | Rel-5 | Paolo |  | GERIMS | Nokia | Shkumbin Hamiti | GERIMS |  |
| 5630 | 110.1 | **GERAN Header adaptation** | 690d | 2000-05-01 A | 2002-12-20 A | 100% | 2000-05-01 | 2002-12-20 | 690d |  | GP; S2; RP | 40011.6h | 40011.6h | Rel-5 | Paolo |  | GERIMS-HEADAPT | Nokia | Shkumbin Hamiti | GERIMS-HEADAPT |  |
| 5631 | 110.1.1 | Definition of compression and removal modes for PDCP protocol | 29.15d | 2000-07-24 A | 2000-09-01 A | 100% | 2000-07-24 | 2000-09-01 | 29.15d | finish no earlier than 2000-09-01 | GP; S2; RP | 699.6h | 699.6h | Rel-5 | Paolo |  |  |  |  |  |  |
| 5632 | 110.1.2 | Conceptual description in stage 2 | 393d | 2000-05-01 A | 2001-10-31 A | 100% | 2000-05-01 | 2001-10-31 | 393d | finish no earlier than 2001-10-31 | GP; S2; RP | 9432h | 9432h | Rel-5 | Paolo |  |  |  |  |  |  |
| 5633 | 110.1.3 | Necessary changes on stage 3 regarding header removal | 555d | 2000-11-06 A | 2002-12-20 A | 100% | 2000-11-06 | 2002-12-20 | 555d | finish no earlier than 2002-12-20 | GP; S2; RP | 13320h | 13320h | Rel-5 | Paolo |  |  |  |  |  |  |
| 5634 | 110.2 | **Deleted - GERAN Radio access bearer design for IMS** | 430d | 2000-11-06 A | 2002-06-28 A | 100% | 2000-11-06 | 2002-06-28 | 430d |  | GP; S2; RP | 29520h | 29520h | Rel-5 | Paolo | GP-10 | GERIMS-RABDES | Nokia | Shkumbin Hamiti | GERIMS-RABDES |  |
| 5635 | 110.2.1 | **Deleted - MuM control signalling for conversational multimedia services** | 430d | 2000-11-06 A | 2002-06-28 A | 100% | 2000-11-06 | 2002-06-28 | 430d |  | GP; S2; RP | 19200h | 19200h | Rel-5 | Paolo | GP-10 |  |  |  |  |  |
| 5636 | 110.2.1.1 | Deleted - Identification of requirements for MuM control signalling for conversational multimedia services | 330d | 2000-11-06 A | 2002-02-08 A | 100% | 2000-11-06 | 2002-02-08 | 330d | finish no earlier than 2002-02-08 | GP; S2; RP | 7920h | 7920h | Rel-5 | Paolo | GP-08 |  |  |  |  |  |
| 5637 | 110.2.1.2 | Deleted - Necessary modifications due to SIP | 40d | 2002-05-06 A | 2002-06-28 A | 100% | 2002-05-06 | 2002-06-28 | 40d | finish no earlier than 2002-06-28 | GP; S2; RP | 960h | 960h | Rel-5 | Paolo | GP-10 |  |  |  |  |  |
| 5638 | 110.3 | **Deleted - GERAN MS Conformance test for support of IMS** | 400d | 2001-06-11 A | 2002-12-20 A | 100% | 2001-06-11 | 2002-12-20 | 400d |  | GP | 6400h | 6400h | Rel-5 | Paolo | GP-12 | GERIMS-MSconf | Nokia | Shkumbin Hamiti | GERIMS-MSconf |  |
| 5639 | 110.3.1 | Deleted - MS test for support of IMS | 400d | 2001-06-11 A | 2002-12-20 A | 100% | 2001-06-11 | 2002-12-20 | 400d | finish no earlier than 2002-12-20 | G4 | 3200h | 3200h | Rel-5 | Paolo | GP-12 |  |  |  |  |  |
| 5640 | 110.4 | Deleted - GERAN BTS Conformance test for support of IMS | 400d | 2001-06-11 A | 2002-12-20 A | 100% | 2001-06-11 | 2002-12-20 | 400d |  | GP | 3200h | 3200h | Rel-5 | Paolo | GP-12 | GERIMS-BTSconf | Nokia | Shkumbin Hamiti | GERIMS-BTSconf |  |
| 5641 | 1438 | MS Conformance Testing of Dual Transfer Mode | 65d? | 2002-11-11 A | 2003-02-07 A | 100% | 2002-11-11 | 2003-02-07 | 65d? | finish no earlier than 2003-02-07 | G4; G5 | 1040h | 1040h | Rel-5 | Paolo |  | MSCTDTM | Vodafone | Dave Fox | MSCTDTM |  |
| 5642 | 1439 | **Handling of early Ues** | 911d? | 2000-01-03 A | 2003-06-27 A | 100% | 2000-01-03 | 2003-06-27 | 911d? |  | S2 | 4488h | 4488h | Rel-5 | Maurice |  | LATE_UE |  |  | LATE_UE |  |
| 5643 | 1439.1 | Feasibility Study on Handling of early Ues | 50d? | 2002-10-07 A | 2002-12-13 A | 100% | 2002-10-07 | 2002-12-13 | 50d? | finish no earlier than 2002-12-13 | S2 | 400h | 400h | Rel-5 | Maurice |  |  |  |  |  |  |
| 5644 | 1439.2 | Stage 2 for Handling of early Ues | 125d? | 2003-01-06 A | 2003-06-27 A | 100% | 2003-01-06 | 2003-06-27 | 125d? | start no earlier than 2003-01-06 | S2 | 1000h | 1000h | Rel-5 | Maurice |  |  |  |  |  |  |
| 5645 | 1439.3 | FS for the Early Mobile Handling in UTRAN | 195d | 2002-09-09 A | 2003-06-06 A | 100% | 2002-09-09 | 2003-06-06 | 195d | finish no earlier than 2003-06-06 | R2 | 1560h | 1560h | Rel-5 | Yong-Jun |  | FSEarlyUE | Vodafone | alan.law@vodafone.com | FSEarlyUE |  |
| 5646 | 1439.4 | Note: Stage 3 RAN part not shown | 1d | 2000-01-03 A | 2000-01-03 A | 100% | 2000-01-03 | 2000-01-03 | 1d |  | RP | 8h | 8h | Rel-5 |  |  |  |  |  |  |  |
| 5647 | 1440 | Release 4 Features | 326d? | 2000-01-03 A | 2001-03-30 A | 100% | 2000-01-03 | 2001-03-30 | 326d? |  | NP; GP; RP; SP; TP | 13040h | 13040h | Rel-4 | All |  |  |  |  |  |  |
| 5648 | 15 | **Miscellaneous UE Conformance Testing Activities** | 958d | 2001-04-02 A | 2004-12-01 A | 100% | 2001-04-02 | 2004-12-01 | 958d |  | T1 | 36360h | 36360h | Rel-4 | Ingbert |  | MISTST1 |  |  | MISTST1 |  |
| 5649 | 15.1 | Optimization of Test Time, RF Aspects (FDD) | 508d | 2001-09-24 A | 2003-09-03 A | 100% | 2001-09-24 | 2003-09-03 | 508d | finish no earlier than 2003-09-03 | T1 | 4064h | 4064h | Rel-4 | Ingbert |  | MISTST1-OpFDD |  |  | MISTST1-OpFDD | 34.121 |
| 5650 | 15.2 | Optimization of Test Time, RF Aspects (TDD) | 508d | 2001-09-24 A | 2003-09-03 A | 100% | 2001-09-24 | 2003-09-03 | 508d | finish no earlier than 2003-09-03 | T1 | 4064h | 4064h | Rel-4 | Ingbert |  | MISTST1-OpTDD |  |  | MISTST1-OpTDD | 34.122 |
| 5651 | 15.3 | Extensions to R99 Test cases | 139.4w | 2001-04-02 A | 2003-12-02 A | 100% | 2001-04-02 | 2003-12-02 | 139.4w | finish no earlier than 2003-12-02 | T1 | 5576h | 5576h | Rel-4 | Ingbert |  | MISTST1-Ext |  |  | MISTST1-Ext | 34.123 p 1,2 |
| 5652 | 15.4 | Extension to R99 Test cases - TTCN | 439d | 2002-06-28 A | 2004-03-03 A | 100% | 2002-06-28 | 2004-03-03 | 439d | finish no earlier than 2004-03-03 | T1 | 3512h | 3512h | Rel-4 | Ingbert |  |  |  |  |  |  |
| 5653 | 15.5 | Creation of R99 TCs for TDD - prose | 719d | 2001-10-01 A | 2004-07-01 A | 100% | 2001-10-01 | 2004-07-01 | 719d | finish no earlier than 2004-07-01 | T1 | 5752h | 5752h | Rel-4 | Ingbert |  | MISTST1-TDD |  |  | MISTST1-TDD | 34.123-1 |
| 5654 | 15.6 | Deleted - Creation of R99 TCs for TDD - TTCN | 587d | 2002-09-03 A | 2004-12-01 A | 100% | 2002-09-03 | 2004-12-01 | 587d | finish no earlier than 2004-12-01 | T1 | 4696h | 4696h | Rel-4 | Ingbert | TP-26 |  |  |  |  |  |
| 5655 | 15.7 | Deleted - Review all other work items for impact on new or exiting 34 series specs. | 25.8w | 2002-07-02 A | 2002-12-27 A | 100% | 2002-07-02 | 2002-12-27 | 25.8w | finish no earlier than 2002-12-27 | T1 | 1032h | 1032h | Rel-4 | Ingbert | TP-18 |  |  |  |  | 34.121,122,123,125 |

Notes:
- 5625: Not started. Marked as stopped 12/2008
- 5626: Not started. Marked as stopped 12/2008
- 5627: Not started. Marked as stopped 12/2008
- 5628: Not started. Marked as stopped 12/2008
- 5629: AWS, Nokia, Ericsson, Nortel, Siemens, Motorola
- 5630: AWS, Nokia, Ericsson, Nortel, Siemens, Motorola
- 5631: -
- 5632: -
- 5633: -
- 5634: TERMINATED - NOT STANDARDIZED. Marked as stopped 12/2008
- 5635: TERMINATED - NOT STANDARDIZED. Marked as stopped 12/2008
- 5636: TERMINATED - NOT STANDARDIZED
- 5637: TERMINATED - NOT STANDARDIZED
- 5638: TERMINATED - NOT STANDARDIZED. Marked as stopped 12/2008
- 5639: TERMINATED - NOT STANDARDIZED. Marked as stopped 12/2008
- 5640: TERMINATED - NOT STANDARDIZED. Marked as stopped 12/2008
- 5641: Needed to complete DTM (R99)
- 5642: -
- 5643: -
- 5644: -
- 5645: -
- 5646: -
- 5647: -
- 5648: -
- 5649: It is believed that the current R99 test spec. can be optimised for faster overall test times. Marked as stopped 12/2008 (was 70% complete)
- 5650: It is believed that the current R99 test spec. can be optimised for faster overall test times
- 5651: Further test coverage of the R99 specification to cover supplementry services. Marked as stopped 12/2008 (was 70% complete)
- 5652: Marked as closed 12/2008 (was marked 50% complete)
- 5653: Marked as closed 12/2008 (was marked 50% complete)
- 5654: Marked as stopped 12/2008
- 5655: Marked as stopped 12/2008

| ID | WBS | Task | Duration | Start | Finish | Predecessors | Complete | Baseline start | Baseline finish | Baseline duration | Constraint | Resources | Work | Actual work | Acronym | Release | MCC resp | Acronym_3GU_Export | Impacted TSs and TRs | WI rapporteur name | WI rapporteur e-mail |
| --- | --- | --- | --- | --- | --- | --- | --- | --- | --- | --- | --- | --- | --- | --- | --- | --- | --- | --- | --- | --- | --- |
| 5656 | 46 | **Real Time Facsimile** | 89d | 2000-02-22 A | 2000-06-23 A |  | 100% | 2000-02-22 | 2000-06-23 | 89d |  | S1 | 4376h | 4376h | FAX-RT | Rel-4 | Alain | FAX-RT |  |  |  |
| 5657 | 46.1 | **Real Time Fax** | 89d | 2000-02-22 A | 2000-06-23 A |  | 100% | 2000-02-22 | 2000-06-23 | 89d |  | S2 | 3664h | 3664h |  | Rel-4 | Maurice |  |  |  |  |
| 5658 | 46.1.1 | Terminal capabilities, AT commands | 89d | 2000-02-22 A | 2000-06-23 A |  | 100% | 2000-02-22 | 2000-06-23 | 89d | finish no earlier than 2000-06-23 | T2 | 712h | 712h |  | Rel-4 |  |  | 21.904, 27.007 |  |  |
| 5659 | 46.1.2 | Signalling aspects (e.g. ICM) | 89d | 2000-02-22 A | 2000-06-23 A |  | 100% | 2000-02-22 | 2000-06-23 | 89d | start no earlier than 2000-02-22 | N1 | 712h | 712h |  | Rel-4 | Frederic |  |  |  |  |
| 5660 | 46.1.3 | Service provision | 89d | 2000-02-22 A | 2000-06-23 A |  | 100% | 2000-02-22 | 2000-06-23 | 89d | finish no earlier than 2000-06-23 | N3 | 712h | 712h |  | Rel-4 | Gwiho |  | 23.146 |  |  |
| 5661 | 46.1.4 | Review whether service/stage 1 aspects need to be aligned | 51d | 2000-04-14 A | 2000-06-23 A |  | 100% | 2000-04-14 | 2000-06-23 | 51d | finish no earlier than 2000-12-14 | S1 | 408h | 408h |  | Rel-4 | Alain |  |  |  |  |
| 5662 | 46.1.5 | Review whether architecture/stage 2 aspects need to be aligned | 51d | 2000-04-14 A | 2000-06-23 A |  | 100% | 2000-04-14 | 2000-06-23 | 51d | finish no earlier than 2000-12-14 | S2 | 408h | 408h |  | Rel-4 | Maurice |  |  |  |  |
| 5663 | 47 | Transparent End-to-End PS mobile streaming application | 253d | 2000-04-03 A | 2001-03-21 A |  | 100% | 2000-04-03 | 2001-03-21 | 253d | finish no earlier than 2000-12-29 | S4 | 2024h | 2024h | PSTREAM | Rel-4 | Paolo | PSTREAM | 26.233, 26.234 |  |  |
| 5664 | 48 | **Multimedia Messaging** | 277d | 2000-02-22 A | 2001-03-14 A |  | 100% | 2000-02-22 | 2001-03-14 | 277d |  | T2; S1 | 14424h | 14424h | MMS4 | Rel-4 | Kimmo | MMS, Rel-4 | 22.140, 23.140 | Siemens | Josef.Laumen@SAL.SIEMENS.DE |
| 5665 | 48.1 | Definition of service requirements for Multimedia Messaging | 72d | 2000-02-22 A | 2000-05-31 A |  | 100% | 2000-02-22 | 2000-05-31 | 72d | start no earlier than 2000-02-22 | S1 | 576h | 576h |  | Rel-4 | Alain |  |  |  |  |
| 5666 | 48.2 | Review of definition of service requirements | 205d | 2000-06-01 A | 2001-03-14 A | 5665 | 100% | 2000-06-01 | 2001-03-14 | 205d | finish no earlier than 2000-09-08 | T2 | 1640h | 1640h |  | Rel-4 | Kimmo |  | 22.140, 23.140 | Siemens |  |
| 5667 | 48.3 | **Technical Realisation** | 243d | 2000-04-10 A | 2001-03-14 A |  | 100% | 2000-04-10 | 2001-03-14 | 243d |  | T2 | 7776h | 7776h |  | Rel-4 | Kimmo |  | 22.140, 23.140 | Siemens | Josef.Laumen@SAL.SIEMENS.DE |
| 5668 | 48.3.1 | Review of definition of reference Achitecture model | 243d | 2000-04-10 A | 2001-03-14 A |  | 100% | 2000-04-10 | 2001-03-14 | 243d | finish no earlier than 2001-03-14 | T2 | 1944h | 1944h |  | Rel-4 | Kimmo |  | 22.140, 23.140 | Siemens | Josef.Laumen@SAL.SIEMENS.DE |
| 5669 | 48.3.2 | Fulfill Requirements of Stage 1 | 243d | 2000-04-10 A | 2001-03-14 A |  | 100% | 2000-04-10 | 2001-03-14 | 243d | finish no earlier than 2001-03-14 | T2 | 1944h | 1944h |  | Rel-4 | Kimmo |  | 22.140, 23.140 | Siemens | Josef.Laumen@SAL.SIEMENS.DE |
| 5670 | 48.3.3 | Definition of MMS primitives in Stage 2 | 243d | 2000-04-10 A | 2001-03-14 A |  | 100% | 2000-04-10 | 2001-03-14 | 243d | finish no earlier than 2001-03-14 | T2 | 1944h | 1944h |  | Rel-4 | Kimmo |  | 22.140, 23.140 | Siemens | Josef.Laumen@SAL.SIEMENS.DE |
| 5671 | 49 | **Transcoder-Free Operation** | 326d | 2000-01-03 A | 2001-03-30 A |  | 100% | 2000-01-03 | 2001-03-30 | 326d |  | N4; S2; N1 | 18272h | 18272h | TrFO | Rel-4 | Kimmo | TrFO |  |  |  |
| 5672 | 49.1 | **Out-of-Band Transcoder Control solution** | 326d | 2000-01-03 A | 2001-03-30 A |  | 100% | 2000-01-03 | 2001-03-30 | 326d |  | N4 | 8448h | 8448h | TrFO-OoBTC | Rel-4 | Kimmo | TrFO-OoBTC |  | NEC | Toshiyuki Tamura (tamurato@aj.jp.nec.com) |
| 5673 | 49.1.1 | implementation in UTRAN | 145d | 2000-09-11 A | 2001-03-30 A |  | 100% | 2000-09-11 | 2001-03-30 | 145d | finish no earlier than 2001-03-30 | R3 | 1160h | 1160h | TrFO-OoBTC-UTRAN | Rel-4 | Juha | TrFO-OoBTC-UTRAN | 25.401, 25.410, 25.413, 25.415, 23.153 | Siemens | Alexander Vesely |
| 5674 | 49.1.2 | Impact on architecture, Principles and Terminology | 211d | 2000-01-03 A | 2000-10-20 A |  | 100% | 2000-01-03 | 2000-10-20 | 211d | finish no earlier than 2000-10-20 | S2 | 1680h | 1680h |  | Rel-4 | Maurice |  |  |  |  |
| 5675 | 49.1.3 | Codec Negotiation between UE and MSC | 125d | 2000-08-14 A | 2001-02-02 A |  | 100% | 2000-08-14 | 2001-02-02 | 125d | finish no earlier than 2001-02-02 | N1 | 1000h | 1000h |  | Rel-4 | Frederic |  | 24.008, 23.009, 23.108, (29.002) | Motorola | Andrew Howell |
| 5676 | 49.1.4 | Codec Negotiation inter MSC | 125d | 2000-07-03 A | 2000-12-22 A |  | 100% | 2000-07-03 | 2000-12-22 | 125d | finish no earlier than 2000-12-22 | N4 | 1000h | 1000h |  | Rel-4 | Kimmo |  |  |  |  |
| 5677 | 49.1.5 | Bearer establishment inter MSC | 125d | 2000-07-03 A | 2000-12-22 A |  | 100% | 2000-07-03 | 2000-12-22 | 125d | finish no earlier than 2000-12-22 | N4 | 1000h | 1000h |  | Rel-4 | Kimmo |  | 23.153 |  |  |
| 5678 | 49.2 | **Speech Transcoder: Location and Control at the UMTS Core Network Border** | 125d | 2000-04-10 A | 2000-09-29 A |  | 100% | 2000-04-10 | 2000-09-29 | 125d |  | S2 | 2000h | 2000h | TrFO-STLC | Rel-4 | Maurice | TrFO-STLC |  |  |  |
| 5679 | 49.2.1 | Transcoder at Edge | 125d | 2000-04-10 A | 2000-09-29 A |  | 100% | 2000-04-10 | 2000-09-29 | 125d | finish no earlier than 2000-09-29 | NP | 1000h | 1000h |  | Rel-4 | Kimmo |  |  |  |  |

Notes:
- 5656: -
- 5657: postponed from R99 to R00, SP-000169
- 5658: -
- 5659: -
- 5660: -
- 5661: -
- 5662: -
- 5663: -
- 5664: Acronym changed from "MMS, Rel-4"
- 5665: -
- 5666: -
- 5667: -
- 5668: -
- 5669: e.g. minimum set of media formats, media format conversion, personalization of MMS.
- 5670: -
- 5671: Lead given to CN4 from CN
- 5672: -
- 5673: moved according to NP-000575
- 5674: e.g. study cascading TrFO/TFO/TrFO
- 5675: the link to NP-000085has been deleted because refering to a R99 status sheet
- 5676: Bearer establishment inter MSC. TS 23.153 R99 part complete. capabilities moved to annex + list of open issues
- 5677: Bearer establishment inter MSC. TS 23.153 R99 part complete. capabilities moved to annex.
- 5678: WI description and Tdoc S2-99352
- 5679: WI description and Tdoc S2-99352

| ID | WBS | Task | Duration | Start | Finish | Complete | Baseline start | Baseline finish | Baseline duration | Constraint | Resources | Work | Actual work | Acronym | Release | MCC resp | Acronym_3GU_Export | WI rapporteur name | WI rapporteur e-mail |
| --- | --- | --- | --- | --- | --- | --- | --- | --- | --- | --- | --- | --- | --- | --- | --- | --- | --- | --- | --- |
| 5680 | 50 | **GERAN improvements 1 (Gb over IP)** | 225d | 2000-05-09 A | 2001-03-19 A | 100% | 2000-05-09 | 2001-03-19 | 225d |  | GP | 6472h | 6472h | GEIMP1 | Rel-4 | Paolo | GEIMP1 |  |  |
| 5681 | 50.1 | **Gb over IP (Ip-fication of Gb)** | 225d | 2000-05-09 A | 2001-03-19 A | 100% | 2000-05-09 | 2001-03-19 | 225d |  | GP | 4672h | 4672h | GbIP | Rel-4 | Paolo | GbIP |  |  |
| 5682 | 50.1.1 | Concept of Gb over IP (Ip-fication of Gb) | 134d | 2000-05-09 A | 2000-11-10 A | 100% | 2000-05-09 | 2000-11-10 | 134d |  | GP | 1072h | 1072h |  | Rel-4 | Paolo |  |  |  |
| 5683 | 50.1.2 | Changes to 08.16, 08.18 | 225d | 2000-05-09 A | 2001-03-19 A | 100% | 2000-05-09 | 2001-03-19 | 225d |  | GP | 1800h | 1800h |  | Rel-4 | Paolo |  |  |  |
| 5684 | 51 | **GERAN improvements 2 (NACC)** | 677d | 2000-11-06 A | 2003-06-10 A | 100% | 2000-11-06 | 2003-06-10 | 677d |  | GP | 22408h | 22408h | GEIMP2 | Rel-4 | Paolo | GEIMP2 |  |  |
| 5685 | 51.1 | **Gb enhancements** | 155d | 2000-11-06 A | 2001-06-08 A | 100% | 2000-11-06 | 2001-06-08 | 155d |  | GP | 7440h | 7440h | Gben | Rel-4 | Paolo | Gben |  |  |
| 5686 | 51.1.1 | **Intra BSC NACC (Network Assisted Cell Change)** | 155d | 2000-11-06 A | 2001-06-08 A | 100% | 2000-11-06 | 2001-06-08 | 155d |  | GP | 6200h | 6200h |  | Rel-4 | Paolo |  |  |  |
| 5687 | 51.1.1.1 | Concept | 155d | 2000-11-06 A | 2001-06-08 A | 100% | 2000-11-06 | 2001-06-08 | 155d | finish no earlier than 2001-06-08 | GP | 1240h | 1240h |  | Rel-4 | Paolo |  |  |  |
| 5688 | 51.1.1.2 | Changes in 03.64 | 155d | 2000-11-06 A | 2001-06-08 A | 100% | 2000-11-06 | 2001-06-08 | 155d | finish no earlier than 2001-06-08 | GP | 1240h | 1240h |  | Rel-4 | Paolo |  |  |  |
| 5689 | 51.1.1.3 | Changes in 04.60 | 155d | 2000-11-06 A | 2001-06-08 A | 100% | 2000-11-06 | 2001-06-08 | 155d | finish no earlier than 2001-06-08 | GP | 1240h | 1240h |  | Rel-4 | Paolo |  |  |  |
| 5690 | 51.1.1.4 | Changes in 44.008 | 155d | 2000-11-06 A | 2001-06-08 A | 100% | 2000-11-06 | 2001-06-08 | 155d | finish no earlier than 2001-06-08 | GP | 1240h | 1240h |  | Rel-4 | Paolo |  |  |  |
| 5691 | 51.3 | **MS conformance test for Intra BSC NACC** | 398d | 2001-11-30 A | 2003-06-10 A | 100% | 2001-11-30 | 2003-06-10 | 398d |  | GP | 9552h | 9552h | GEIMP2-Msconf | Rel-4 | Paolo | GEIMP2-Msconf |  |  |
| 5692 | 51.3.1 | Changes in 51.010 | 398d | 2001-11-30 A | 2003-06-10 A | 100% | 2001-11-30 | 2003-06-10 | 398d | finish no earlier than 2003-12-19 | G5; G4 | 6368h | 6368h |  | Rel-4 | Paolo |  |  |  |
| 5693 | 52 | **GERAN improvements 4 (Delayed TBF)** | 105d | 2001-01-15 A | 2001-06-08 A | 100% | 2001-01-15 | 2001-06-08 | 105d |  | GP | 3960h | 3960h | GEIMP4 | Rel-4 | Paolo | GEIMP4 |  |  |
| 5694 | 52.1 | **Gb enhancements 2** | 105d | 2001-01-15 A | 2001-06-08 A | 100% | 2001-01-15 | 2001-06-08 | 105d |  | GP | 3120h | 3120h | GEIMP4-Gben2 | Rel-4 | Paolo | GEIMP4-Gben2 |  |  |
| 5695 | 52.1.1 | Stage 2 for Gb enhancements 2 | 105d | 2001-01-15 A | 2001-06-08 A | 100% | 2001-01-15 | 2001-06-08 | 105d | finish no earlier than 2001-06-08 | GP | 840h | 840h |  | Rel-4 | Paolo |  |  |  |
| 5696 | 52.1.2 | **Stage 3 (changes in 44.060)** | 60d | 2001-01-15 A | 2001-04-06 A | 100% | 2001-01-15 | 2001-04-06 | 60d |  | G2 | 1440h | 1440h |  | Rel-4 | Gert |  |  |  |
| 5697 | 52.1.2.1 | Definition of enhanced countdown procedure | 60d | 2001-01-15 A | 2001-04-06 A | 100% | 2001-01-15 | 2001-04-06 | 60d | finish no earlier than 2001-04-06 | G2 | 480h | 480h |  | Rel-4 | Gert |  |  |  |
| 5698 | 52.1.2.2 | Definition of enhanced TBF release procedure | 60d | 2001-01-15 A | 2001-04-06 A | 100% | 2001-01-15 | 2001-04-06 | 60d | finish no earlier than 2001-04-06 | G2 | 480h | 480h |  | Rel-4 | Gert |  |  |  |
| 5699 | 52.1.2.3 | Definition of USF=FREE type polling mechanism on PDCH | 60d | 2001-01-15 A | 2001-04-06 A | 100% | 2001-01-15 | 2001-04-06 | 60d | finish no earlier than 2001-04-06 | G2 | 480h | 480h |  | Rel-4 | Gert |  |  |  |
| 5700 | 53 | **Low Chip Rate TDD option** | 880d | 2000-07-19 A | 2003-12-02 A | 100% | 2000-07-19 | 2003-12-02 | 880d |  | R1 | 27488h | 27488h | LCRTDD | Rel-4 | Patrick | LCRTDD | CWTS | G. Yang |
| 5701 | 53.1 | Physical layer for Low Chip Rate TDD option | 183d | 2000-07-19 A | 2001-03-30 A | 100% | 2000-07-19 | 2001-03-30 | 183d | finish no earlier than 2001-03-30 | R1 | 1464h | 1464h | LCRTDD-Phys | Rel-4 | Patrick | LCRTDD-Phys | CWTS | G. Yang |
| 5702 | 53.2 | Layer 2 and layer 3 protocol aspects | 183d | 2000-07-19 A | 2001-03-30 A | 100% | 2000-07-19 | 2001-03-30 | 183d | finish no earlier than 2001-03-30 | R2 | 1464h | 1464h | LCRTDD-L23 | Rel-4 | Yong-Jun | LCRTDD-L23 | CWTS | Y. Liu |
| 5703 | 53.3 | RF radio transmission/reception, system performance requirements and conformance testing | 165d | 2000-08-14 A | 2001-03-30 A | 100% | 2000-08-14 | 2001-03-30 | 165d | finish no earlier than 2001-03-30 | R4 | 1320h | 1320h | LCRTDD-RF | Rel-4 | Issam | LCRTDD-RF | CWTS | D. Zhang |
| 5704 | 53.4 | UE radio access capability | 165d | 2000-08-14 A | 2001-03-30 A | 100% | 2000-08-14 | 2001-03-30 | 165d | finish no earlier than 2001-03-30 | R2 | 1320h | 1320h | LCRTDD-UErac | Rel-4 | Yong-Jun | LCRTDD-UErac | CWTS | Y. Liu |
| 5705 | 53.5 | Iub/Iur protocol aspects - for Low Chip Rate TDD option | 165d | 2000-08-14 A | 2001-03-30 A | 100% | 2000-08-14 | 2001-03-30 | 165d | finish no earlier than 2001-03-30 | R3 | 1320h | 1320h | LCRTDD-IubIur | Rel-4 | Juha | LCRTDD-IubIur | CWTS | Y. Liu |

Notes:
- 5680: -
- 5681: -
- 5682: -
- 5683: -
- 5684: -
- 5685: -
- 5686: -
- 5687: -
- 5688: -
- 5689: -
- 5690: -
- 5691: -
- 5692: az 05/08: duplicated UID_50099 => 50299. Marked as closed 12/2008 (was marked 50% complete)
- 5693: -
- 5694: -
- 5695: -
- 5696: -
- 5697: -
- 5698: -
- 5699: -
- 5700: -
- 5701: -
- 5702: -
- 5703: -
- 5704: -
- 5705: -

| ID | WBS | Task | Duration | Start | Finish | Predecessors | Complete | Baseline start | Baseline finish | Baseline duration | Constraint | Resources | Work | Actual work | Release | MCC resp | Impacted TSs and TRs | TSG stopped | Acronym | WI rapporteur name | WI rapporteur e-mail | Acronym_3GU_Export |
| --- | --- | --- | --- | --- | --- | --- | --- | --- | --- | --- | --- | --- | --- | --- | --- | --- | --- | --- | --- | --- | --- | --- |
| 5706 | 53.6 | **Low chiprate TDD interworking with GERAN** | 101d | 2000-09-01 A | 2001-01-19 A | 5705 | 100% | 2000-09-01 | 2001-01-19 | 101d |  | GP | 1616h | 1616h | Rel-4 | Paolo |  |  |  |  |  |  |
| 5707 | 53.6.1 | Handover and Cell Selection / Reselection to UTRA 1.28 Mcps TDD | 101d | 2000-09-01 A | 2001-01-19 A |  | 100% | 2000-09-01 | 2001-01-19 | 101d | finish no earlier than 2001-01-19 | GP | 808h | 808h | Rel-4 | Paolo |  |  |  |  |  |  |
| 5708 | 53.8 | **Conformance Test Aspects - Low Chip Rate TDD** | 577d | 2001-09-17 A | 2003-12-02 A | 5706 | 100% | 2001-09-17 | 2003-12-02 | 577d |  | T1 | 12088h | 12088h | Rel-4 | Ingbert |  |  |  |  |  |  |
| 5709 | 53.8.1 | Testing Layer 2 and layer 3 protocol aspects | 468d | 2001-09-17 A | 2003-07-02 A |  | 100% | 2001-09-17 | 2003-07-02 | 468d | finish no earlier than 2003-07-02 | T1 | 3744h | 3744h | Rel-4 | Ingbert | 34.123-1, 34.123-2 |  |  |  |  |  |
| 5710 | 53.8.2 | Deleted - Testing Layer 2 and layer 3 protocol aspects - TTCN | 261d | 2002-12-03 A | 2003-12-02 A |  | 100% | 2002-12-03 | 2003-12-02 | 261d | finish no earlier than 2003-12-02 | T1 | 2088h | 2088h | Rel-4 | Ingbert | 34.123-3 | TP-22 |  |  |  |  |
| 5711 | 53.8.3 | Testing RF Radio Transmission and Reception | 205d | 2001-09-17 A | 2002-06-28 A |  | 100% | 2001-09-17 | 2002-06-28 | 205d | finish no earlier than 2002-06-28 | T1 | 1640h | 1640h | Rel-4 | Ingbert |  |  |  |  |  |  |
| 5712 | 54 | **Enable bearer independent CS architecture** | 566d | 2000-01-03 A | 2002-03-01 A |  | 100% | 2000-01-03 | 2002-03-01 | 566d |  | S2; N3; N4 | 28008h | 28008h | Rel-4 | Maurice |  |  | CSSPLIT | Siemens | Alexander Milinski | CSSPLIT |
| 5713 | 54.1 | **Enable bearer-independent call control** | 425d | 2000-01-03 A | 2001-08-16 A |  | 100% | 2000-01-03 | 2001-08-16 | 425d |  | N4 | 12344h | 12344h | Rel-4 | Kimmo |  |  |  | Ericsson | Heinz-Peter.Keutmann@eed.ericsson.se |  |
| 5714 | 54.1.1 | Architecture and Stage 2 description | 181d | 2000-01-03 A | 2000-09-08 A |  | 100% | 2000-01-03 | 2000-09-08 | 181d | finish no earlier than 2000-09-08 | S2 | 1440h | 1440h | Rel-4 | Maurice | 23.002 |  |  |  |  |  |
| 5715 | 54.1.2 | Standardisation of protocols (control & user planes) over Nb interface | 64d | 2001-01-02 A | 2001-03-30 A |  | 100% | 2001-01-02 | 2001-03-30 | 64d | finish no earlier than 2001-03-30 | N3 | 512h | 512h | Rel-4 | Gwiho |  |  |  |  |  |  |
| 5716 | 54.1.3 | Standardisation of protocols over reference points between MSC server and Gateway MSC server | 130d | 2000-09-25 A | 2001-03-23 A |  | 100% | 2000-09-25 | 2001-03-23 | 130d | finish no earlier than 2001-03-23 | N4 | 1040h | 1040h | Rel-4 | Kimmo |  |  |  |  |  |  |
| 5717 | 54.1.4 | Standardisation of detailed stage 2 description | 180d | 2000-07-17 A | 2001-03-23 A |  | 100% | 2000-07-17 | 2001-03-23 | 180d | finish no earlier than 2001-03-23 | N4 | 1440h | 1440h | Rel-4 | Kimmo |  |  |  |  |  |  |
| 5718 | 54.1.5 | **Bearer control between MSC server and MGW** | 250d | 2000-09-01 A | 2001-08-16 A |  | 100% | 2000-09-01 | 2001-08-16 | 250d |  | N4 | 4512h | 4512h | Rel-4 | Kimmo |  |  |  |  |  |  |
| 5719 | 54.1.5.1 | stage 3 - protocol issues | 250d | 2000-09-01 A | 2001-08-16 A |  | 100% | 2000-09-01 | 2001-08-16 | 250d | finish no earlier than 2001-08-16 | N4 | 2000h | 2000h | Rel-4 | Kimmo |  |  |  |  |  |  |
| 5720 | 54.1.5.2 | stage 3 - parameter value issues | 64d | 2001-01-02 A | 2001-03-30 A |  | 100% | 2001-01-02 | 2001-03-30 | 64d | finish no earlier than 2001-03-30 | N3 | 512h | 512h | Rel-4 | Gwiho |  |  |  |  |  |  |
| 5721 | 54.4 | Deleted - Conformance Test Aspects - Enable bearer independent CS architecture | 260d | 2001-03-05 A | 2002-03-01 A |  | 100% | 2001-03-05 | 2002-03-01 | 260d |  | T1 | 2080h | 2080h | Rel-4 | Ingbert |  | TP-15 | CSSPLIT-TEST |  |  | CSSPLIT-TEST |
| 5722 | 55 | **MExE enhancements Rel-4** | 511d | 2000-01-03 A | 2001-12-14 A |  | 100% | 2000-01-03 | 2001-12-14 | 511d |  | T2; S3 | 26912h | 26912h | Rel-4 | Kimmo |  |  | MEXE |  |  | MEXE |
| 5723 | 55.1 | **MExE Security Analysis Activity** | 474d | 2000-02-22 A | 2001-12-14 A |  | 100% | 2000-02-22 | 2001-12-14 | 474d |  | S3; T2 | 12256h | 12256h | Rel-4 | Mirko |  |  | MEXE-SEC | BT | Andrew.Myers@bt.com | MEXE-SEC |
| 5724 | 55.1.1 | Stage 3 for MExE Security | 370d | 2000-07-17 A | 2001-12-14 A |  | 100% | 2000-07-17 | 2001-12-14 | 370d | finish no earlier than 2001-12-14 | S3 | 2960h | 2960h | Rel-4 | Mirko | 21.133, 33.102 |  |  | BT | Andrew.Myers@bt.com |  |
| 5725 | 55.1.2 | Terminal aspects for MExE Security | 214d | 2000-02-22 A | 2000-12-15 A |  | 100% | 2000-02-22 | 2000-12-15 | 214d | finish no earlier than 2000-12-15 | T2 | 1712h | 1712h | Rel-4 |  | 23.057 |  |  | BT | Andrew.Myers@bt.com |  |
| 5726 | 55.2 | **MExE Rel-4 Improvements and Investigations** | 251d | 2000-01-03 A | 2000-12-15 A |  | 100% | 2000-01-03 | 2000-12-15 | 251d |  | T2 | 6480h | 6480h | Rel-4 | Kimmo | 22.057, 23.057 |  | MEXE-ENHANC | Motorola | Mark Cataldo | MEXE-ENHANC |
| 5727 | 55.2.1 | 3rd MExE classmark | 251d | 2000-01-03 A | 2000-12-15 A |  | 100% | 2000-01-03 | 2000-12-15 | 251d | finish no earlier than 2000-12-15 | T2 | 2000h | 2000h | Rel-4 | Kimmo | 22.057, 23.057 |  |  | Motorola | Mark Cataldo |  |
| 5728 | 55.2.2 | FS on Secure download mechanism and capabilities to support SDR concepts | 225d | 2000-02-07 A | 2000-12-15 A |  | 100% | 2000-02-07 | 2000-12-15 | 225d | finish no earlier than 2000-12-15 | T2 | 1800h | 1800h | Rel-4 | Kimmo | 22.057, 23.057 |  |  | Motorola | Mark Cataldo |  |
| 5729 | 55.2.3 | FS on Support of MP3/MPEG4 content | 225d | 2000-02-07 A | 2000-12-15 A |  | 100% | 2000-02-07 | 2000-12-15 | 225d | finish no earlier than 2000-12-15 | T2 | 1800h | 1800h | Rel-4 | Kimmo | 22.057, 23.057 |  |  | Motorola | Mark Cataldo |  |

Notes:
- 5706: -
- 5707: -
- 5708: -
- 5709: Marked as closed 12/2008 (was marked 60% complete)
- 5710: Marked as stopped 12/2008
- 5711: duration set to 6 months (was 0), finish date set
- 5712: -
- 5713: DAB 12.12.01 should be 100% hence closed
- 5714: R00 stage 2 at least 80 % complete in TSGS #8 21.-23.6.2000
- 5715: -
- 5716: -
- 5717: -
- 5718: -
- 5719: -
- 5720: -
- 5721: Marked as stopped 12/2008
- 5722: -
- 5723: SP#12 updated WID
- 5724: -
- 5725: -
- 5726: -
- 5727: Additional features for MExE R2000
- 5728: -
- 5729: -

| ID | WBS | Task | Duration | Start | Finish | Complete | Baseline start | Baseline finish | Baseline duration | Constraint | Resources | Work | Actual work | Acronym | Release | MCC resp | Acronym_3GU_Export | Impacted TSs and TRs | WI rapporteur name | WI rapporteur e-mail |
| --- | --- | --- | --- | --- | --- | --- | --- | --- | --- | --- | --- | --- | --- | --- | --- | --- | --- | --- | --- | --- |
| 5730 | 56 | **Tandem Free aspects for 3G and between 2G and 3G systems** | 344d | 2000-02-22 A | 2001-06-15 A | 100% | 2000-02-22 | 2001-06-15 | 344d |  | S4 | 9696h | 9696h | TFO | Rel-4 | Paolo | TFO |  |  |  |
| 5731 | 56.1 | **Tandem Free AMR** | 344d | 2000-02-22 A | 2001-06-15 A | 100% | 2000-02-22 | 2001-06-15 | 344d |  | S4 | 6944h | 6944h | TFO-AMR | Rel-4 | Paolo | TFO-AMR |  |  |  |
| 5732 | 56.1.1 | Specification of Tandem Free AMR | 284d | 2000-02-22 A | 2001-03-23 A | 100% | 2000-02-22 | 2001-03-23 | 284d | start no earlier than 2000-02-22 | S4 | 2272h | 2272h |  | Rel-4 | Paolo |  | 28.062 |  |  |
| 5733 | 56.1.2 | **Impact of Tandem Free AMR on:** | 115d | 2001-01-08 A | 2001-06-15 A | 100% | 2001-01-08 | 2001-06-15 | 115d |  | NP | 1920h | 1920h |  | Rel-4 | Kimmo |  |  |  |  |
| 5734 | 56.1.2.1 | CN | 60d | 2001-03-26 A | 2001-06-15 A | 100% | 2001-03-26 | 2001-06-15 | 60d | finish no earlier than 2001-06-15 | NP | 480h | 480h |  | Rel-4 | Kimmo |  |  |  |  |
| 5735 | 56.1.2.2 | GERAN | 65d | 2001-01-08 A | 2001-04-06 A | 100% | 2001-01-08 | 2001-04-06 | 65d | finish no earlier than 2001-04-06 | GP | 520h | 520h |  | Rel-4 | Paolo |  |  |  |  |
| 5736 | 57 | **Advanced Speech Call Items enhancements_Rel-4** | 334d | 2000-12-03 A | 2002-03-14 A | 100% | 2000-12-03 | 2002-03-14 | 334d |  | N1 | 5925.6h | 5925.6h | ASCI4 | Rel-4 | Frederic | ASCI, Rel-4 |  | Nortel | sonia.garapaty@nortelnetworks.com |
| 5737 | 57.1 | Stage 2 for Advanced Speech Call Items enhancements_Rel-4 (ASCI) | 326.7d | 2000-12-03 A | 2002-03-14 A | 100% | 2000-12-03 | 2002-03-14 | 326.7d | finish no earlier than 2002-03-14 | N4 | 2613.6h | 2613.6h |  | Rel-4 | Kimmo |  | 23.067, 24.067 | Sagem | Vivien Perlic |
| 5738 | 57.2 | Stages 2 and 3 on A interface | 80d | 2000-12-03 A | 2001-03-23 A | 100% | 2000-12-03 | 2001-03-23 | 80d | finish no earlier than 2001-03-23 | N1 | 640h | 640h |  | Rel-4 | Frederic |  | 44.068, 44.069, 24.008 | Nortel | sonia.garapaty@nortelnetworks.com |
| 5739 | 58 | **700 MHz spectrum support** | 776d | 2000-01-03 A | 2002-12-20 A | 100% | 2000-01-03 | 2002-12-20 | 776d |  | GP | 20016h | 20016h | 700SS | Rel-4 | Paolo | 700SS |  |  |  |
| 5740 | 58.1 | **GERAN support for the 700 MHz band** | 276d | 2000-01-03 A | 2001-01-19 A | 100% | 2000-01-03 | 2001-01-19 | 276d |  | GP | 8808h | 8808h |  | Rel-4 | Paolo |  |  |  |  |
| 5741 | 58.1.1 | Signalling support | 276d | 2000-01-03 A | 2001-01-19 A | 100% | 2000-01-03 | 2001-01-19 | 276d | finish no earlier than 2001-01-19 | GP | 2200h | 2200h |  | Rel-4 | Paolo |  |  |  |  |
| 5742 | 58.1.2 | Physical layer definitions - for GERAN support for the 700 MHz band | 276d | 2000-01-03 A | 2001-01-19 A | 100% | 2000-01-03 | 2001-01-19 | 276d | finish no earlier than 2001-01-19 | GP | 2200h | 2200h |  | Rel-4 | Paolo |  |  |  |  |
| 5743 | 58.1.3 | Receiver performance and RF budget | 276d | 2000-01-03 A | 2001-01-19 A | 100% | 2000-01-03 | 2001-01-19 | 276d | finish no earlier than 2001-01-19 | GP | 2200h | 2200h |  | Rel-4 | Paolo |  |  |  |  |
| 5744 | 58.2 | GERAN MS Conformance test for 700 MHz band | 175d | 2001-04-02 A | 2001-11-30 A | 100% | 2001-04-02 | 2001-11-30 | 175d |  | GP | 1400h | 1400h |  | Rel-4 | Paolo |  |  |  |  |
| 5745 | 58.3 | GERAN BTS Conformance test for 700 MHz band | 450d | 2001-04-02 A | 2002-12-20 A | 100% | 2001-04-02 | 2002-12-20 | 450d |  | GP | 3600h | 3600h |  | Rel-4 | Paolo |  |  |  |  |
| 5746 | 59 | Operator Determined Barring for Packet Oriented Services | 208d | 2000-06-01 A | 2001-03-19 A | 100% | 2000-06-01 | 2001-03-19 | 208d | finish no earlier than 2001-03-19 | NP | 1664h | 1664h | ODB | Rel-4 | Kimmo | ODB |  | NEC | Toshiyuki Tamura (tamurato@aj.jp.nec.com) |
| 5747 | 60 | **UMTS QoS Architecture for PS Domain** | 759d | 2000-01-03 A | 2002-11-27 A | 100% | 2000-01-03 | 2002-11-27 | 759d |  | S2; S5; R3; GP | 72848h | 72848h | QoSPS | Rel-4 | Maurice | QoSPS |  | Ericsson | Ina.widegren@era.ericsson.se |
| 5748 | 60.1 | Architecture | 153d | 2000-06-05 A | 2001-01-03 A | 100% | 2000-06-05 | 2001-01-03 | 153d | finish no earlier than 2001-01-03 | S2 | 1224h | 1224h |  | Rel-4 | Maurice |  | 23.107 |  |  |
| 5749 | 60.2 | Charging and OAM&P for QoS Management | 201d | 2001-09-21 A | 2002-06-28 A | 100% | 2001-09-21 | 2002-06-28 | 201d | finish no earlier than 2002-06-28 | S5 | 1608h | 1608h | QoSPS-OAM | Rel-4 | Mirko | QoSPS-OAM | 32-series |  |  |
| 5750 | 60.3 | **RAB Quality of Service (re)Negotiation over Iu** | 155d | 2000-08-21 A | 2001-03-23 A | 100% | 2000-08-21 | 2001-03-23 | 155d |  | R3 | 3648h | 3648h | QoSPS-MAPEND-RABQoS | Rel-4 | Juha | QoSPS-MAPEND-RABQoS | 25.413 | Ericsson | anders.molander@ericsson.com |
| 5751 | 60.3.1 | RAB Quality of Service Negotiation over Iu | 155d | 2000-08-21 A | 2001-03-23 A | 100% | 2000-08-21 | 2001-03-23 | 155d | finish no earlier than 2001-03-23 | R3 | 1240h | 1240h | QoSPS-MAPEND-RABQoS-Negot | Rel-4 | Juha | QoSPS-MAPEND-RABQoS-Negot |  | Ericsson | anders.molander@ericsson.com |
| 5752 | 60.3.2 | RAB Quality of Service Negotiation over Iu during relocation | 16d | 2001-03-02 A | 2001-03-23 A | 100% | 2001-03-02 | 2001-03-23 | 16d | start no earlier than 2001-03-02 | R3 | 128h | 128h | QoSPS-MAPEND-RABQoS-NegotReloc | Rel-4 | Juha | QoSPS-MAPEND-RABQoS-NegotReloc |  |  |  |
| 5753 | 60.3.3 | RAB Quality of Service Re-Negotiation over Iu | 130d | 2000-09-25 A | 2001-03-23 A | 100% | 2000-09-25 | 2001-03-23 | 130d | finish no earlier than 2001-03-23 | R3 | 1040h | 1040h | QoSPS-MAPEND-RABQoS-ReNegot | Rel-4 | Juha | QoSPS-MAPEND-RABQoS-ReNegot |  | Motorola | S. Irwin |

Notes:
- 5730: RAN and CN to verify no problems for GSM terminals roaming in 3G R99
- 5731: RAN and CN to verify UMTS_AMR_2 support
- 5732: -
- 5733: "Implementation" changed to "Impact on:" by A. Sultan (for better wording)
- 5734: RAN and CN to verify UMTS_AMR_2 support
- 5735: End date Modified from June to March to have it in Rel4
- 5736: Approved at CN#10. Acronym changed from ASCI, Rel-4
- 5737: CN4#11 30/11/02: no inputs received in CN4
- 5738: -
- 5739: -
- 5740: -
- 5741: -
- 5742: -
- 5743: -
- 5744: -
- 5745: -
- 5746: Completed WI missing from the P-plan Added for tracking
- 5747: -
- 5748: -
- 5749: -
- 5750: -
- 5751: -
- 5752: -
- 5753: -

| ID | WBS | Task | Type | Duration | Start | Finish | Complete | Baseline start | Baseline finish | Baseline duration | Constraint | Resources | Work | Actual work | Acronym | Release | MCC resp | Acronym_3GU_Export | TSG stopped | WI rapporteur name | WI rapporteur e-mail | Impacted TSs and TRs |
| --- | --- | --- | --- | --- | --- | --- | --- | --- | --- | --- | --- | --- | --- | --- | --- | --- | --- | --- | --- | --- | --- | --- |
| 5754 | 60.4 | **GERAN QoS Aspects - Handovers: maintenance of real-time QoS while moving between cells in the PLMN including inter-SGSN and SRNS relocation or possibly other mechanisms** |  | 501d | 2000-01-03 A | 2001-11-30 A | 100% | 2000-01-03 | 2001-11-30 | 501d |  | GP | 14456h | 14456h | GERQoS | Rel-4 | Paolo | GERQoS |  |  |  |  |
| 5755 | 60.4.1 | **Handover Concept for the PS domain** |  | 501d | 2000-01-03 A | 2001-11-30 A | 100% | 2000-01-03 | 2001-11-30 | 501d |  | GP | 10448h | 10448h |  | Rel-4 | Paolo |  |  |  |  |  |
| 5756 | 60.4.1.1 | Stable RT handover report 25.936 including header removal |  | 14d | 2000-01-03 A | 2000-01-19 A | 100% | 2000-01-03 | 2000-01-19 | 14d | start no earlier than 2000-01-03 | GP | 104h | 104h |  | Rel-4 | Paolo |  |  |  |  |  |
| 5757 | 60.4.1.2 | Update of stage 2 |  | 293d | 2000-01-03 A | 2001-02-13 A | 100% | 2000-01-03 | 2001-02-13 | 293d | finish no earlier than 2001-02-13 | GP | 2336h | 2336h |  | Rel-4 | Paolo |  |  |  |  |  |
| 5758 | 60.4.1.3 | Update of relevant stage 3 specs -> RRC |  | 501d | 2000-01-03 A | 2001-11-30 A | 100% | 2000-01-03 | 2001-11-30 | 501d | finish no earlier than 2001-11-30 | G2 | 4000h | 4000h |  | Rel-4 | Gert |  |  |  |  |  |
| 5759 | 60.5 | **Deleted - GERAN MS Conformance test for inter-system and intra-system Packet data real-time Handover** |  | 324d | 2001-08-31 A | 2002-11-27 A | 100% | 2001-08-31 | 2002-11-27 | 324d |  | G4; R3 | 25920h | 25920h | GERQoS-Mstest | Rel-4 | Paolo | GERQoS-Mstest | GP-12 |  |  |  |
| 5760 | 60.5.1 | **Deleted - Handover for the PS domain** |  | 324d | 2001-08-31 A | 2002-11-27 A | 100% | 2001-08-31 | 2002-11-27 | 324d |  | G4; R3 | 20736h | 20736h |  | Rel-4 | Paolo |  | GP-12 |  |  |  |
| 5761 | 60.5.1.1 | Deleted - Stable RT handover report 25.936 including header removal |  | 324d | 2001-08-31 A | 2002-11-27 A | 100% | 2001-08-31 | 2002-11-27 | 324d | finish no earlier than 2002-11-27 | G4; R3 | 5184h | 5184h |  | Rel-4 | Paolo |  | GP-12 |  |  |  |
| 5762 | 60.5.1.2 | Deleted - Update of stage 2 |  | 324d | 2001-08-31 A | 2002-11-27 A | 100% | 2001-08-31 | 2002-11-27 | 324d | finish no earlier than 2002-11-27 | G4; R3 | 5184h | 5184h |  | Rel-4 | Paolo |  | GP-12 |  |  |  |
| 5763 | 60.5.1.3 | Deleted - Update of relevant stage 3 specs |  | 324d | 2001-08-31 A | 2002-11-27 A | 100% | 2001-08-31 | 2002-11-27 | 324d | finish no earlier than 2002-11-27 | G4; R3 | 5184h | 5184h |  | Rel-4 | Paolo |  | GP-12 |  |  |  |
| 5764 | 60.6 | PS-domain handover for real-time services |  | 155d | 2000-08-28 A | 2001-03-30 A | 100% | 2000-08-28 | 2001-03-30 | 155d | finish no earlier than 2001-03-30 | R3 | 1240h | 1240h | QoSPS-PSdoRTS | Rel-4 | Juha | QoSPS-PSdoRTS |  | Nokia | atte.lansisalmi@nokia.com |  |
| 5765 | 60.7 | Deleted - RAB QoS Renegotiation at Relocation |  | 58d | 2001-01-03 A | 2001-03-23 A | 100% | 2001-01-03 | 2001-03-23 | 58d | finish no earlier than 2001-03-23 | R3 | 464h | 464h |  | Rel-4 | Juha |  | RP-11 |  |  | 25.851, 25.946 |
| 5766 | 61 | (Small) Technical Enhancements and Improvements for Rel-4 | milestone | 0d? | 2000-01-03 A | 2000-01-03 A | 100% | 2000-01-03 | 2001-03-30 | 326d? |  | SP; CP; RP; GP |  |  | TEI4 | Rel-4 | all | TEI4 |  |  |  |  |
| 5767 | 1458 | Test - (Small) Technical Enhancements and Improvements for Rel-4 |  | 326d? | 2000-01-03 A | 2001-03-30 A | 100% | 2000-01-03 | 2001-03-30 | 326d? | finish no earlier than 2008-12-31 | R5; T1 | 5216h | 5216h | TEI4_Test | Rel-4 | Ingbert | TEI4_Test |  |  |  |  |
| 5768 | 62 | **Rel-4 Evolutions of the transport in the UTRAN** |  | 525d | 2000-08-21 A | 2002-08-23 A | 100% | 2000-08-21 | 2002-08-23 | 525d |  | RP | 8600h | 8600h | ETRAN | Rel-4 | Issam | ETRAN |  | Alcatel | Francois Courau |  |
| 5769 | 62.1 | QoS optimization for AAL2 connections over Iub and Iur interfaces |  | 160d | 2000-08-21 A | 2001-03-30 A | 100% | 2000-08-21 | 2001-03-30 | 160d | finish no earlier than 2001-03-30 | R3 | 1280h | 1280h | ETRAN-QoSAAL2 | Rel-4 | Juha | ETRAN-QoSAAL2 |  | Japan Telecom | T. Yoshimura |  |
| 5770 | 62.2 | Transport bearer modification procedure on Iub, Iur, and Iu |  | 130d | 2000-10-02 A | 2001-03-30 A | 100% | 2000-10-02 | 2001-03-30 | 130d | finish no earlier than 2001-03-30 | R3 | 1040h | 1040h | ETRAN-MigrMod | Rel-4 | Juha | ETRAN-MigrMod |  | Japan Telecom | T. Yoshimura |  |
| 5771 | 62.3 | **Deleted - Conformance Test Aspects of Rel-4 evolutions of the transport in UTRAN** |  | 130d | 2002-02-25 A | 2002-08-23 A | 100% | 2002-02-25 | 2002-08-23 | 130d |  | T1 | 2080h | 2080h |  | Rel-4 | Ingbert |  | TP-17 |  |  |  |
| 5772 | 62.3.1 | Deleted - Testing RAB support enhancements |  | 130d | 2002-02-25 A | 2002-08-23 A | 100% | 2002-02-25 | 2002-08-23 | 130d | finish no earlier than 2002-08-23 | T1 | 1040h | 1040h | CT-RABS? | Rel-4 | Ingbert | CT-RABS? | TP-17 |  |  | 34.108, 34. 121, 34.122, 34.123 p 1,2, 34.123 pt 3 |
| 5773 | 63 | **Rel-4 Evolutions of the transport in the CN** |  | 215d | 2000-05-29 A | 2001-03-23 A | 100% | 2000-05-29 | 2001-03-23 | 215d |  | N4; N1; N2; S2 | 13128h | 13128h | CNTRSP | Rel-4 | Kimmo | CNTRSP |  |  |  |  |
| 5774 | 63.1 | **IP Transport of CN protocols (e.g. CAP, MAP)** |  | 77d | 2000-12-07 A | 2001-03-23 A | 100% | 2000-12-07 | 2001-03-23 | 77d |  | N4 | 2808h | 2808h | SS7IP | Rel-4 | Kimmo | SS7IP |  |  |  |  |
| 5775 | 63.1.1 | **Stage 3 for IP Transport of CN protocols (e.g. CAP, MAP)** |  | 77d | 2000-12-07 A | 2001-03-23 A | 100% | 2000-12-07 | 2001-03-23 | 77d |  | N4 | 2192h | 2192h |  | Rel-4 | Kimmo |  |  |  |  |  |
| 5776 | 63.1.1.1 | CAP |  | 77d | 2000-12-07 A | 2001-03-23 A | 100% | 2000-12-07 | 2001-03-23 | 77d | finish no earlier than 2001-03-23 | N2 | 616h | 616h |  | Rel-4 | Kimmo |  |  |  |  |  |
| 5777 | 63.1.1.2 | MAP |  | 77d | 2000-12-07 A | 2001-03-23 A | 100% | 2000-12-07 | 2001-03-23 | 77d | finish no earlier than 2001-03-23 | N4 | 616h | 616h |  | Rel-4 | Kimmo |  |  |  |  | 29.202 |
| 5778 | 63.1.1.3 | BSSAP+ |  | 43d | 2001-01-15 A | 2001-03-14 A | 100% | 2001-01-15 | 2001-03-14 | 43d | finish no earlier than 2001-03-14 | N1 | 344h | 344h | SS7IP-BSSAP+ | Rel-4 | Frederic | SS7IP-BSSAP+ |  |  |  |  |

Notes:
- 5754: -
- 5755: -
- 5756: -
- 5757: -
- 5758: -
- 5759: Still exist? To be clarified by GERAN4/5. Marked as stopped 12/2008
- 5760: Marked as stopped 12/2008
- 5761: Marked as stopped 12/2008
- 5762: Marked as stopped 12/2008
- 5763: Marked as stopped 12/2008
- 5764: -
- 5765: Marked as stopped 12/2008
- 5766: "Joker" WI, to be used for a Rel 4 CR not related to any feature and with very limited impact on the system
- 5767: "Joker" WI, to be used for small modifications applicable to Rel 4 conformance testing. Moved in from the Stoyan/Testing WP
- 5768: -
- 5769: -
- 5770: -
- 5771: Marked as stopped 12/2008
- 5772: Marked as stopped 12/2008
- 5773: -
- 5774: -
- 5775: -
- 5776: -
- 5777: -
- 5778: -

| ID | WBS | Task | Duration | Start | Finish | Complete | Baseline start | Baseline finish | Baseline duration | Constraint | Resources | Work | Actual work | WI rapporteur name | WI rapporteur e-mail | Release | MCC resp | Acronym | Acronym_3GU_Export | Impacted TSs and TRs | TSG stopped |
| --- | --- | --- | --- | --- | --- | --- | --- | --- | --- | --- | --- | --- | --- | --- | --- | --- | --- | --- | --- | --- | --- |
| 5779 | 63.2 | **FS on Transport and control separation in the PS CN domain** | 215d | 2000-05-29 A | 2001-03-23 A | 100% | 2000-05-29 | 2001-03-23 | 215d |  | S2 | 3440h | 3440h | Ericsson | Juan-Antonio.Ibanez@eed.ericsson.se | Rel-4 | Maurice |  |  |  |  |
| 5780 | 63.2.1 | Architectural impacts | 215d | 2000-05-29 A | 2001-03-23 A | 100% | 2000-05-29 | 2001-03-23 | 215d | finish no earlier than 2001-03-23 | S2 | 1720h | 1720h |  |  | Rel-4 | Maurice |  |  |  |  |
| 5781 | 64 | **Rel-4 Improvements of Radio Interface** | 700d | 2000-07-10 A | 2003-03-14 A | 100% | 2000-07-10 | 2003-03-14 | 700d |  | RP | 28624h | 28624h |  |  | Rel-4 |  |  |  |  |  |
| 5782 | 64.1 | UTRA repeater specification (master) | 183d | 2000-07-10 A | 2001-03-21 A | 100% | 2000-07-10 | 2001-03-21 | 183d | finish no earlier than 2001-03-21 | R4 | 1464h | 1464h | Mikom, Allgon | T. Kummetz, Mikom; Alf Ahlström, Allgon | Rel-4 | Issam | RInImp-REP | RInImp-REP |  |  |
| 5783 | 64.2 | DSCH power control improvement in soft handover | 140d | 2000-09-11 A | 2001-03-23 A | 100% | 2000-09-11 | 2001-03-23 | 140d | finish no earlier than 2001-03-23 | R1 | 1120h | 1120h | Nokia | antti.toskala@nokia.com | Rel-4 | Patrick | RInImp-DSCHsho | RInImp-DSCHsho |  |  |
| 5784 | 64.3 | UMTS 1800 | 320d | 2000-09-25 A | 2001-12-14 A | 100% | 2000-09-25 | 2001-12-14 | 320d | finish no earlier than 2001-12-14 | R4 | 2560h | 2560h | Motorola | Howard Benn | Rel-4 | Issam | RInImp-UMTS18 | RInImp-UMTS18 |  |  |
| 5785 | 64.4 | UMTS 1900 | 195d | 2001-03-19 A | 2001-12-14 A | 100% | 2001-03-19 | 2001-12-14 | 195d | finish no earlier than 2001-12-14 | R4 | 1560h | 1560h | Motorola | Howard Benn | Rel-4 | Issam | RInImp-UMTS19 | RInImp-UMTS19 | 25.101 |  |
| 5786 | 64.5 | FS on High Speed downlink packet access | 155d | 2000-08-21 A | 2001-03-23 A | 100% | 2000-08-21 | 2001-03-23 | 155d | finish no earlier than 2001-03-23 | R2 | 1240h | 1240h | Motorola | Amitabha Ghosh (qa0047@email.mot.com) | Rel-4 | Yong-Jun | RInImp-HSDPA | RInImp-HSDPA |  |  |
| 5787 | 64.6 | Deleted - FS on improved common DL channel for Cell-FACH state | 340d | 2000-09-11 A | 2001-12-28 A | 100% | 2000-09-11 | 2001-12-28 | 340d | finish no earlier than 2001-12-28 | R2 | 2720h | 2720h | GBT | J. Kwak | Rel-4 | Yong-Jun | RInImp-DLCFACH | RInImp-DLCFACH |  | RP-14 |
| 5788 | 64.7 | **Conformance Test Spec. Rel-4 improvements in Radio Interface** | 375d | 2001-10-08 A | 2003-03-14 A | 100% | 2001-10-08 | 2003-03-14 | 375d |  | T1 | 12360h | 12360h |  |  | Rel-4 | Ingbert |  |  |  |  |
| 5789 | 64.7.1 | Deleted - Testing Improved usage of downlink resource in FDD for CCTrCHs of dedicated type | 140d | 2002-02-18 A | 2002-08-30 A | 100% | 2002-02-18 | 2002-08-30 | 140d | finish no earlier than 2002-08-30 | T1 | 1120h | 1120h |  |  | Rel-4 | Ingbert |  |  |  | TP-17 |
| 5790 | 64.7.2 | Deleted - Testing Terminal Power saving features | 140d | 2002-02-18 A | 2002-08-30 A | 100% | 2002-02-18 | 2002-08-30 | 140d | finish no earlier than 2002-08-30 | T1 | 1120h | 1120h |  |  | Rel-4 | Ingbert |  |  |  | TP-17 |
| 5791 | 64.7.3 | Deleted - Testing DSCH power control improvement in soft handover | 140d | 2002-02-18 A | 2002-08-30 A | 100% | 2002-02-18 | 2002-08-30 | 140d | finish no earlier than 2002-08-30 | T1 | 1120h | 1120h |  |  | Rel-4 | Ingbert |  |  |  | TP-17 |
| 5792 | 64.7.4 | Testing UMTS 1800 | 180d | 2001-10-08 A | 2002-06-14 A | 100% | 2001-10-08 | 2002-06-14 | 180d | finish no earlier than 2002-06-14 | T1 | 1440h | 1440h |  |  | Rel-4 | Ingbert |  |  | 34.108, 34,121, 34.122, 34.123-1 |  |
| 5793 | 64.7.5 | Testing UMTS 1900 | 180d | 2001-10-08 A | 2002-06-14 A | 100% | 2001-10-08 | 2002-06-14 | 180d | finish no earlier than 2002-06-14 | T1 | 1440h | 1440h |  |  | Rel-4 | Ingbert |  |  | 34.108, 34,121, 34.122, 34.123-1 |  |
| 5794 | 64.7.6 | Testing UMTS 1800 - TTCN | 195d | 2002-06-17 A | 2003-03-14 A | 100% | 2002-06-17 | 2003-03-14 | 195d | finish no earlier than 2003-03-14 | T1 | 1560h | 1560h |  |  | Rel-4 | Ingbert |  |  | 34.123-3 |  |
| 5795 | 64.7.7 | Testing UMTS 1900 - TTCN | 195d | 2002-06-17 A | 2003-03-14 A | 100% | 2002-06-17 | 2003-03-14 | 195d | finish no earlier than 2003-03-14 | T1 | 1560h | 1560h |  |  | Rel-4 | Ingbert |  |  | 34.123-3 |  |
| 5796 | 65 | **Rel-4 RAN improvements** | 938d? | 2000-08-14 A | 2004-03-17 A | 100% | 2000-08-14 | 2004-03-17 | 938d? |  | RP | 29336h | 29336h |  |  | Rel-4 |  |  |  |  |  |
| 5797 | 65.1 | Node B synchronization for TDD | 160d | 2000-08-14 A | 2001-03-23 A | 100% | 2000-08-14 | 2001-03-23 | 160d | finish no earlier than 2001-03-23 | R1 | 1280h | 1280h | Siemens | S. Oestreich | Rel-4 | Patrick | RANimp-NBsync | RANimp-NBsync |  |  |
| 5798 | 65.2 | RAB support enhancement for Rel-4 | 155d | 2000-08-21 A | 2001-03-23 A | 100% | 2000-08-21 | 2001-03-23 | 155d | finish no earlier than 2001-03-23 | R2 | 1240h | 1240h | Ericsson | M. Israelsson, A. Krishnarajah | Rel-4 | Yong-Jun | RANimp-RABSE | RANimp-RABSE |  |  |
| 5799 | 65.4 | **Deleted - Conformance Test Aspects - Rel-4 RAN Improvements** | 577d? | 2002-01-01 A | 2004-03-17 A | 100% | 2002-01-01 | 2004-03-17 | 577d? |  | T1 | 19312h | 19312h |  |  | Rel-4 | Ingbert |  |  |  | TP-23 |
| 5800 | 65.4.1 | Deleted - Testing Radio access bearer support enhancments | 175d | 2002-01-01 A | 2002-09-02 A | 100% | 2002-01-01 | 2002-09-02 | 175d | finish no earlier than 2002-09-02 | T1 | 1400h | 1400h |  |  | Rel-4 | Ingbert |  |  |  | TP-17 |
| 5801 | 65.4.2 | Deleted - Testing RAB support enhancements-Robust Header Compression | 332d | 2002-05-28 A | 2003-09-03 A | 100% | 2002-05-28 | 2003-09-03 | 332d | finish no earlier than 2003-09-03 | T1 | 2656h | 2656h |  |  | Rel-4 | Ingbert | RABimp-RoCH | RABimp-RoCH | 34.123-1, -2 | TP-21 |
| 5802 | 65.4.3 | Deleted - Testing RAB support enhancements-Robust Header Compression - TTCN | 472d | 2002-05-28 A | 2004-03-17 A | 100% | 2002-05-28 | 2004-03-17 | 472d | finish no earlier than 2004-03-17 | T1 | 3776h | 3776h |  |  | Rel-4 | Ingbert |  |  | 34.123-3 | TP-23 |
| 5803 | 65.4.4 | Testing of Extended Robut Header Compression | 270d | 2002-09-18 A | 2003-09-30 A | 100% | 2002-09-18 | 2003-09-30 | 270d | finish no earlier than 2003-09-30 | T1 | 2160h | 2160h |  |  | Rel-4 | Ingbert | Ext-RoHC | Ext-RoHC | 34.123-1, -2 |  |
| 5804 | 65.4.5 | Deleted - Testing of Extended Robut Header Compression - TTCN | 325d | 2002-09-18 A | 2003-12-16 A | 100% | 2002-09-18 | 2003-12-16 | 325d | finish no earlier than 2003-12-16 | T1 | 2600h | 2600h |  |  | Rel-4 | Ingbert |  |  | 34.123-3 | TP-22 |
| 5805 | 1462.3.6 | Deleted - General changes to TS34.121 corresponding to release 4 | 263d? | 2003-03-03 A | 2004-03-03 A | 100% | 2003-03-03 | 2004-03-03 | 263d? | finish no earlier than 2004-03-03 | T1 | 2104h | 2104h |  |  | Rel-4 | Ingbert | RANimp-test,TEI4 | RANimp-test, TEI4 | 34.108, 34.121 | TP-23 |

Notes:
- 5779: -
- 5780: -
- 5781: -
- 5782: -
- 5783: -
- 5784: -
- 5785: -
- 5786: -
- 5787: Stopped at RP#14
- 5788: -
- 5789: Marked as stopped 12/2008
- 5790: Marked as stopped 12/2008
- 5791: Marked as stopped 12/2008
- 5792: -
- 5793: -
- 5794: -
- 5795: -
- 5796: -
- 5797: -
- 5798: 29 Nov 2000: split into ROHC and non-ROHC part; 5 Mar 2001: splitting off of ROHC for Rel-4 agreed by R2
- 5799: Marked as stopped 12/2008
- 5800: Marked as stopped 12/2008
- 5801: UID changed. Marked as stopped 12/2008
- 5802: UID changed. Marked as stopped 12/2008
- 5803: Marked as closed 12/2008 (was marked 15% complete)
- 5804: Marked as stopped 12/2008
- 5805: Marked as stopped 12/2008

| ID | WBS | Task | Duration | Start | Finish | Complete | Baseline start | Baseline finish | Baseline duration | Constraint | Resources | Work | Actual work | Acronym | WI rapporteur name | Release | MCC resp | Special Focus Doc | Acronym_3GU_Export | TSG stopped | WI rapporteur e-mail | Status Report |
| --- | --- | --- | --- | --- | --- | --- | --- | --- | --- | --- | --- | --- | --- | --- | --- | --- | --- | --- | --- | --- | --- | --- |
| 5806 | 66 | **Rel-4 Emergency call enhancements** | 628d | 2000-01-03 A | 2002-05-28 A | 100% | 2000-01-03 | 2002-05-28 | 628d |  | N1; S1; T1 | 18672h | 18672h | EMC1-CS | Ericsson | Rel-4 | Frederic | Public Safety (I-A) | EMC1, EMC1-CS |  |  |  |
| 5807 | 66.1 | **For CS based calls** | 628d | 2000-01-03 A | 2002-05-28 A | 100% | 2000-01-03 | 2002-05-28 | 628d |  | N1 | 3600h | 3600h | EMC1-CS | Ericsson | Rel-4 | Frederic | Public Safety (I-A) | EMC1-CS |  |  |  |
| 5808 | 66.1.1 | Distinction in CS domain of emergency call types to different emergency services | 40d | 2000-05-01 A | 2000-06-23 A | 100% | 2000-05-01 | 2000-06-23 | 40d | finish no earlier than 2000-06-23 | S1 | 320h | 320h |  |  | Rel-4 | Alain | Public Safety (I-A) |  |  |  |  |
| 5809 | 66.1.2 | Distinction in CS domain of emergency calls to different emergency types | 22d | 2000-08-24 A | 2000-09-22 A | 100% | 2000-08-24 | 2000-09-22 | 22d | finish no earlier than 2000-09-22 | N1 | 176h | 176h |  |  | Rel-4 | Frederic | Public Safety (I-A) |  |  |  |  |
| 5810 | 66.1.3 | Deleted - Conformance Test Aspects - Emergency call enhancements | 151d | 2000-01-03 A | 2000-07-28 A | 100% | 2000-01-03 | 2000-07-28 | 151d |  | T1 | 1200h | 1200h |  |  | Rel-4 | Ingbert | Public Safety (I-A) |  | TP-08 |  |  |
| 5811 | 66.1.4 | Testing CS based emergency calls | 67d | 2002-02-25 A | 2002-05-28 A | 100% | 2002-02-25 | 2002-05-28 | 67d | finish no earlier than 2002-05-28 | T1 | 536h | 536h |  |  | Rel-4 | Ingbert | Public Safety (I-A) |  |  |  |  |
| 5812 | 66.1.5 | Testing CS based emergency calls - TTCN | 134d | 2001-11-22 A | 2002-05-28 A | 100% | 2001-11-22 | 2002-05-28 | 134d | finish no earlier than 2002-05-28 | T1 | 1072h | 1072h |  |  | Rel-4 | Ingbert | Public Safety (I-A) |  |  |  |  |
| 5813 | 67 | **Rel-4 Terminal interfaces** | 315d | 2000-01-03 A | 2001-03-15 A | 100% | 2000-01-03 | 2001-03-15 | 315d |  | T2 | 14296h | 14296h | TI |  | Rel-4 | Kimmo |  | TI |  |  |  |
| 5814 | 67.1 | **AT commands enhancements** | 314d | 2000-01-03 A | 2001-03-14 A | 100% | 2000-01-03 | 2001-03-14 | 314d |  | T2 | 5016h | 5016h | TI-ATC |  | Rel-4 | Kimmo |  | TI-ATC |  |  |  |
| 5815 | 67.1.1 | Specification of AT commands for new services | 314d | 2000-01-03 A | 2001-03-14 A | 100% | 2000-01-03 | 2001-03-14 | 314d | finish no earlier than 2001-03-14 | T2 | 2504h | 2504h |  |  | Rel-4 | Kimmo |  |  |  |  |  |
| 5816 | 67.2 | **Wide Area Data Synchronization** | 314d | 2000-01-03 A | 2001-03-14 A | 100% | 2000-01-03 | 2001-03-14 | 314d |  | T2 | 5016h | 5016h | TI-WADS |  | Rel-4 | Kimmo |  | TI-WADS |  |  |  |
| 5817 | 67.2.1 | Continues evolution of Synchronization protocol | 314d | 2000-01-03 A | 2001-03-14 A | 100% | 2000-01-03 | 2001-03-14 | 314d | finish no earlier than 2001-03-14 | T2 | 2504h | 2504h | TI-SYNC-EVOL |  | Rel-4 | Kimmo |  | TI-SYNC-EVOL |  |  |  |
| 5818 | 67.3 | Terminal local model | 218d | 2000-05-16 A | 2001-03-15 A | 100% | 2000-05-16 | 2001-03-15 | 218d | finish no earlier than 2001-03-15 | T2 | 1744h | 1744h | TLM | Ericsson | Rel-4 | Kimmo |  | TLM |  | Olga.Tome@ECS.ERICSSON.SE |  |
| 5819 | 68 | **Rel-4 Location Services enhancements** | 455d | 2000-04-03 A | 2001-12-28 A | 100% | 2000-04-03 | 2001-12-28 | 455d |  | S2; S1; T2; N1; N4; R3; R2 | 67671.2h | 67671.2h | LCS4 | Nokia | Rel-4 | Maurice |  | LCS1 |  | Jan Kall |  |
| 5820 | 68.1 | CBS interactions | 455d | 2000-04-03 A | 2001-12-28 A | 100% | 2000-04-03 | 2001-12-28 | 455d | finish no earlier than 2001-12-28 | T2 | 3640h | 3640h | LCS4-CBS |  | Rel-4 |  |  | LCS1-CBS |  |  |  |
| 5821 | 68.2 | LCS support in the CS domain | 180d | 2000-05-15 A | 2001-01-19 A | 100% | 2000-05-15 | 2001-01-19 | 180d | finish no earlier than 2001-01-19 | S2 | 1440h | 1440h | LCS4-CS |  | Rel-4 | Maurice |  | LCS1-CS |  |  |  |
| 5822 | 68.3 | **LCS support in the PS domain** | 435d | 2000-05-01 A | 2001-12-28 A | 100% | 2000-05-01 | 2001-12-28 | 435d |  | S2; S1; N1; N4 | 29880h | 29880h | LCS4-PS |  | Rel-4 | Maurice |  | LCS1-PS |  |  |  |
| 5823 | 68.3.1 | Stage 1 for LCS support in the PS domain | 40d | 2000-07-03 A | 2000-08-25 A | 100% | 2000-07-03 | 2000-08-25 | 40d | start no earlier than 2000-07-03 | S1 | 320h | 320h |  | Pacific Bell Wireless | Rel-4 | Alain |  |  |  | Randolph Wohlert (rwohlert@tri.sbc.com) |  |
| 5824 | 68.3.2 | Stage 2 for LCS support in the PS domain | 190d | 2000-05-01 A | 2001-01-19 A | 100% | 2000-05-01 | 2001-01-19 | 190d | finish no earlier than 2001-01-19 | S2; R2; G1 | 4560h | 4560h |  |  | Rel-4 | Maurice |  |  |  |  |  |
| 5825 | 68.3.3 | **Stage 3 for LCS support in the PS domain** | 355d | 2000-08-21 A | 2001-12-28 A | 100% | 2000-08-21 | 2001-12-28 | 355d |  | N1; N4 | 11080h | 11080h |  |  | Rel-4 | Frederic |  |  |  |  |  |
| 5826 | 68.3.3.1 | Layer 3 LCS signalling UE (MS) -SGSN (UMTS PS and and GSM-GPRS) | 355d | 2000-08-21 A | 2001-12-28 A | 100% | 2000-08-21 | 2001-12-28 | 355d | finish no earlier than 2001-12-28 | N1 | 2840h | 2840h |  | Nokia | Rel-4 | Frederic |  |  |  | Janne Muhonen |  |
| 5827 | 68.3.3.2 | MAP impacts of LCS | 160d | 2000-08-21 A | 2001-03-30 A | 100% | 2000-08-21 | 2001-03-30 | 160d | finish no earlier than 2001-03-30 | N4 | 1280h | 1280h |  |  | Rel-4 | Kimmo |  |  |  |  |  |
| 5828 | 68.3.3.3 | GTP signalling for LCS | 160d | 2000-08-21 A | 2001-03-30 A | 100% | 2000-08-21 | 2001-03-30 | 160d | finish no earlier than 2001-03-30 | N4 | 1280h | 1280h |  |  | Rel-4 | Kimmo |  |  |  |  |  |
| 5829 | 68.4 | **UE positioning Rel-4** | 260d | 2000-04-03 A | 2001-03-30 A | 100% | 2000-04-03 | 2001-03-30 | 260d |  | R3; R2 | 7231.2h | 7231.2h | LCS1-UEpos |  | Rel-4 | Issam |  | LCS1-UEpos |  |  | RP-010045 |
| 5830 | 68.4.1 | Iub/Iur interfaces for methods Rel 99 | 233.9d | 2000-04-03 A | 2001-03-30 A | 100% | 2000-04-03 | 2001-03-30 | 233.9d | finish no earlier than 2001-03-30 | R3 | 1871.2h | 1871.2h | LCS1-UEpos-IubIur | Ericsson | Rel-4 | Juha |  | LCS1-UEpos-IubIur |  | Yun-Chao Hu | RP-010045 |
| 5831 | 68.4.2 | UE positioning enhancements - IPDL for TDD | 150d | 2000-08-28 A | 2001-03-23 A | 100% | 2000-08-28 | 2001-03-23 | 150d | finish no earlier than 2001-03-23 | R2 | 1200h | 1200h | LCS1-UEpos-enh | Siemens | Rel-4 | Yong-Jun |  | LCS1-UEpos-enh |  | Armin Sitte | RP-010045 |

Notes:
- 5806: Acronym changed from EMC1, EMC1-CS
- 5807: WI approved in TSG_10
- 5808: -
- 5809: Calls to different emergency services such as ambulance, fire brigade, police, etc. can be routed to respective different emergency centres. / Impacted TSs and TRs: 24.008
- 5810: UID changed. Marked as stopped 12/2008
- 5811: - / Impacted TSs and TRs: 34.123-1
- 5812: - / Impacted TSs and TRs: 34.123-3
- 5813: -
- 5814: - / Impacted TSs and TRs: 27.007
- 5815: goal not completely achieved because of missing input / Impacted TSs and TRs: 27.007
- 5816: AS: Rel5 changed to Rel4 according to SP#10 decision, milestone on testing added
- 5817: - / Impacted TSs and TRs: 27.903, 27.103
- 5818: - / Impacted TSs and TRs: 23.227
- 5819: Acronym changed form LCS1
- 5820: - / Impacted TSs and TRs: 23.041
- 5821: Only MAP impact foreseen so far. To be further split if needed.
- 5822: -
- 5823: To be also considered: External LCS client identity, and Privacy options when PDP-context and when no PDP-context is established / Impacted TSs and TRs: 22.071
- 5824: SP#10 completed / Impacted TSs and TRs: 25.305 (UTRAN part), new 23.271 (CN part by S2, 43.059 (GERAN part)
- 5825: -
- 5826: -
- 5827: -
- 5828: -
- 5829: -
- 5830: - / Impacted TSs and TRs: 25.401, 25.420, 25.423, 25.430, 25.433, new TR 25.850
- 5831: 5 Mar 2001: split of IPDL for TDD agreed by R2 / Impacted TSs and TRs: new TR 25.847

| ID | WBS | Task | Duration | Start | Finish | Complete | Baseline start | Baseline finish | Baseline duration | Constraint | Resources | Work | Actual work | Acronym | Release | MCC resp | Acronym_3GU_Export | Impacted TSs and TRs | WI rapporteur name | WI rapporteur e-mail | TSG stopped |
| --- | --- | --- | --- | --- | --- | --- | --- | --- | --- | --- | --- | --- | --- | --- | --- | --- | --- | --- | --- | --- | --- |
| 5832 | 69 | **Rel-4 UICC/(U)SIM enhancements and interworking** | 175d | 2000-07-24 A | 2001-03-23 A | 100% | 2000-07-24 | 2001-03-23 | 175d |  | T3 | 2800h | 2800h | UICC1 | Rel-4 | Xavier | UICC1, Rel-4 |  |  |  |  |
| 5833 | 69.1 | Common PCN Handset Specification (CPHS) | 175d | 2000-07-24 A | 2001-03-23 A | 100% | 2000-07-24 | 2001-03-23 | 175d | finish no earlier than 2001-03-23 | T3 | 1400h | 1400h | UICC1-CPHS | Rel-4 | Xavier | UICC1-CPHS | 27.103 | One2One |  |  |
| 5834 | 70 | **Rel-4 (U)SIM toolkit enhancements** | 210d | 2000-06-05 A | 2001-03-23 A | 100% | 2000-06-05 | 2001-03-23 | 210d |  | T3; S1 | 6720h | 6720h | USAT4 | Rel-4 | Xavier | USAT1, USAT1-LocLnk, USAT1APIJAVA, USAT1SM | 23.048 (USAT1SM), 43.019 (USAT1APIJAVA) | Gemplus | Jean-Francois Rubon |  |
| 5835 | 70.1 | USAT local link | 210d | 2000-06-05 A | 2001-03-23 A | 100% | 2000-06-05 | 2001-03-23 | 210d | finish no earlier than 2001-03-23 | T3; S1 | 3360h | 3360h | USAT1-LocLnk | Rel-4 | Xavier | USAT1-LocLnk | 22.038, 31.111 | Gemplus | Jean-Francois Rubon |  |
| 5836 | 71 | **Rel-4 Security enhancements** | 576d | 2000-01-03 A | 2002-03-15 A | 100% | 2000-01-03 | 2002-03-15 | 576d |  | S3; N4; N1 | 38112h | 38112h | SEC4 | Rel-4 | Mirko | SEC1 |  | Vodafone | Peter.Howard@vodafone.com |  |
| 5837 | 54.2 | Rel-4 Lawful Interception | 155d | 2000-08-21 A | 2001-03-23 A | 100% | 2000-08-21 | 2001-03-23 | 155d | finish no earlier than 2001-03-23 | S3 | 1240h | 1240h | SEC4-LI | Rel-4 | Mirko | SEC1-LI | 33.107 |  |  |  |
| 5838 | 71.1 | Evolution of GSM CS algorithms (e.g. A5/3 development and deployment) | 272d | 2000-01-03 A | 2001-01-15 A | 100% | 2000-01-03 | 2001-01-15 | 272d | finish no earlier than 2001-01-15 | S3 | 2168h | 2168h | SEC1-CSALGO1 | Rel-4 | Mirko | SEC1-CSALGO1 | 33.102, 33.103, 33.105 | DTI, BIS | cbrookson@iee.org |  |
| 5839 | 71.2 | **Evolution of GSM PS algorithms (e.g. GEA 2 deployment)** | 219d | 2000-02-22 A | 2000-12-22 A | 100% | 2000-02-22 | 2000-12-22 | 219d |  | S3; N4; N1 | 9528h | 9528h | SEC1-PSALGO1 | Rel-4 | Mirko | SEC1-PSALGO1 | 33.102, 33.103, 33.105 | DTI, BIS | cbrookson@iee.org |  |
| 5840 | 71.2.1 | Deleted - Main aspects of Evolution of GSM PS algorithms (e.g. GEA 2 deployment) | 199d | 2000-02-22 A | 2000-11-24 A | 100% | 2000-02-22 | 2000-11-24 | 199d | finish no earlier than 2000-11-24 | S3 | 1592h | 1592h |  | Rel-4 | Mirko |  |  | DTI, BIS | cbrookson@iee.org | SP-69 |
| 5841 | 71.2.2 | Impact on GTP | 200d | 2000-03-20 A | 2000-12-22 A | 100% | 2000-03-20 | 2000-12-22 | 200d | finish no earlier than 2000-12-22 | N4 | 1600h | 1600h |  | Rel-4 | Kimmo |  |  | DTI, BIS | cbrookson@iee.org |  |
| 5842 | 71.2.3 | GEA capability indication in MS CM | 135d | 2000-06-19 A | 2000-12-22 A | 100% | 2000-06-19 | 2000-12-22 | 135d | finish no earlier than 2000-12-22 | N1 | 1080h | 1080h | SEC1-PSALGO1-GEACAP | Rel-4 | Frederic | SEC1-PSALGO1-GEACAP |  | Vodafone Airtouch | Duncan Mills |  |
| 5843 | 71.3 | **Deleted - MAP application layer security** | 576d | 2000-01-03 A | 2002-03-15 A | 100% | 2000-01-03 | 2002-03-15 | 576d |  | S3 | 11352h | 11352h | SEC1-MAPAL | Rel-4 | Mirko | SEC1-MAPAL |  |  |  | SP-15 |
| 5844 | 71.3.1 | Deleted - Main aspects of MAP application layer security | 199d | 2000-02-21 A | 2001-03-29 A | 100% | 2000-02-21 | 2001-03-29 | 199d | start no earlier than 2000-02-21 | S3 | 1592h | 1592h |  | Rel-4 | Mirko |  |  |  |  | SP-11 |
| 5845 | 71.3.2 | Deleted - Other stage 3 aspects | 199d | 2000-02-22 A | 2000-11-24 A | 100% | 2000-02-22 | 2000-11-24 | 199d | finish no earlier than 2000-11-24 | N4 | 1592h | 1592h |  | Rel-4 | Kimmo |  |  |  |  | CP-10 |
| 5846 | 71.3.3 | Deleted - Visibility and Configurability of security | 576d | 2000-01-03 A | 2002-03-15 A | 100% | 2000-01-03 | 2002-03-15 | 576d | finish no earlier than 2002-03-15 | S3 | 4600h | 4600h | SEC1-VCS | Rel-4 | Mirko | SEC1-VCS |  | France Telecom | Sebastien.nguyenngoc@rd.francetelecom.com | SP-15 |
| 5847 | 72 | **Rel-4 Charging and OAM&P** | 221d | 2000-12-01 A | 2001-10-05 A | 100% | 2000-12-01 | 2001-10-05 | 221d |  | S5 | 10472h | 10472h | OAM4 | Rel-4 | Mirko | OAM4 |  |  |  |  |
| 5848 | 72.1 | Rel-4 Principles, high level Requirements and Architecture | 145d | 2000-12-01 A | 2001-06-21 A | 100% | 2000-12-01 | 2001-06-21 | 145d | finish no earlier than 2001-06-21 | S5 | 1160h | 1160h |  | Rel-4 | Mirko |  | 32.101, 32.102 | Motorola, Telia | Michael.Truss@motorola.com, Tommy.R.Berggren@TELIA.SE |  |
| 5849 | 72.2 | Rel-4 Performance Management | 216d | 2000-12-01 A | 2001-09-28 A | 100% | 2000-12-01 | 2001-09-28 | 216d | finish no earlier than 2001-06-21 | S5 | 1728h | 1728h |  | Rel-4 | Mirko |  | 32.4xy, 52.402 | T-Mobile | karl-heinz.nenner@t-mobile.de |  |
| 5850 | 72.3 | Fault Management | 221d | 2000-12-01 A | 2001-10-05 A | 100% | 2000-12-01 | 2001-10-05 | 221d | finish no earlier than 2001-06-21 | S5 | 1768h | 1768h |  | Rel-4 | Mirko |  | 32.111-1/4 | Lucent |  |  |
| 5851 | 72.4 | Configuration Management | 145d | 2000-12-01 A | 2001-06-21 A | 100% | 2000-12-01 | 2001-06-21 | 145d | finish no earlier than 2001-06-21 | S5 | 1160h | 1160h |  | Rel-4 | Mirko |  | 32.106-1/8 | Ericsson | thomas.tovinger@ericsson.com |  |
| 5852 | 72.5 | Rel-4 Charging Management | 216d | 2000-12-01 A | 2001-09-28 A | 100% | 2000-12-01 | 2001-09-28 | 216d | finish no earlier than 2001-06-21 | S5 | 1728h | 1728h |  | Rel-4 | Mirko |  | 32.200, 32.205, 32.215, 32.235 | T-Mobile | karl-heinz.nenner@t-mobile.de |  |
| 5853 | 72.6 | UTRAN Operations and Maintenance procedures | 145d | 2000-12-01 A | 2001-06-21 A | 100% | 2000-12-01 | 2001-06-21 | 145d | finish no earlier than 2001-06-21 | S5 | 1160h | 1160h | UOAM | Rel-4 | Mirko | UOAM | 32.800 | Mannesmann Mobilfunk | bert.boden@d2mannesmann.de |  |
| 5854 | 73 | **Global Text Telephony** | 317d? | 2000-01-03 A | 2001-03-19 A | 100% | 2000-01-03 | 2009-09-18 | 2537d? |  | S1; S2; S4; T1; R5 | 18528h | 18528h | GTT | Rel-4 | Maurice | GTT |  | Ericsson | gunnar.hellstrom@omnitor.se |  |
| 5855 | 73.1 | Stage 1 for Global Text Telephony | 188d | 2000-04-05 A | 2000-12-22 A | 100% | 2000-04-05 | 2000-12-22 | 188d | finish no earlier than 2000-12-22 | S1 | 1504h | 1504h |  | Rel-4 | Alain |  | 22.226 |  |  |  |
| 5856 | 73.2 | Stage 2 for Global Text Telephony | 206d | 2000-01-03 A | 2000-10-13 A | 100% | 2000-01-03 | 2000-10-13 | 206d |  | S2 | 1640h | 1640h |  | Rel-4 | Maurice |  | 23.226 |  |  |  |

Notes:
- 5832: Acronym changed from UICC1, Rel-4
- 5833: 28/5/2001: CRs approved at TP-11. WI complete.
- 5834: Acronym changed from USAT1, USAT1-LocLnk, USAT1APIJAVA, USAT1SM
- 5835: 25/5/2001:CR was approved at TP-11. WI is complete
- 5836: acronym changed from SEC1
- 5837: Requirements capture: S3#14 (Aug 00), Feature specification: S3#15 (Sep 00), Definition of architecture. Should be included in general LI work mentioned above.. Acronym changed from SEC1-LI
- 5838: SP#8 approved WID
- 5839: SP#8 approved WID
- 5840: Complete TSG#09 (09/2000). S3#17: Proposed for deletion. TO BE DELETED
- 5841: -
- 5842: -
- 5843: REPLACED BY NDS-MAP and NDS-IP. Completed Auto Key Management -> Rel-6. Marked as stopped 12/2008
- 5844: UID changed. Marked as stopped 12/2008
- 5845: UID changed. Marked as stopped 12/2008
- 5846: CR approved at SA3#21 awaiting comments from CN1. Marked as stopped 12/2008
- 5847: SP#13 approved WID
- 5848: -
- 5849: -
- 5850: -
- 5851: -
- 5852: -
- 5853: -
- 5854: SP#12 updated WID SP-000162=>SP-010340
- 5855: -
- 5856: -

| ID | WBS | Task | Type | Duration | Start | Finish | Complete | Baseline start | Baseline finish | Baseline duration | Constraint | Resources | Work | Actual work | Acronym | Release | MCC resp | Acronym_3GU_Export | PCG stopped | TSG stopped |
| --- | --- | --- | --- | --- | --- | --- | --- | --- | --- | --- | --- | --- | --- | --- | --- | --- | --- | --- | --- | --- |
| 5857 | 73.3 | **Specification of Cellular Text telephone Modem** |  | 136d | 2000-09-11 A | 2001-03-19 A | 100% | 2000-09-11 | 2001-03-19 | 136d |  | S4 | 2704h | 2704h | GTT-CTM | Rel-4 | Paolo | GTT-CTM |  |  |
| 5858 | 73.3.1 | General description and C-code |  | 66d | 2000-09-11 A | 2000-12-11 A | 100% | 2000-09-11 | 2000-12-11 | 66d | finish no earlier than 2000-12-11 | S4 | 528h | 528h |  | Rel-4 | Paolo |  |  |  |
| 5859 | 73.3.2 | Minimum Performance requirements |  | 136d | 2000-09-11 A | 2001-03-19 A | 100% | 2000-09-11 | 2001-03-19 | 136d | finish no earlier than 2001-03-19 | S4 | 1088h | 1088h |  | Rel-4 | Paolo |  |  |  |
| 5860 | 73.5 | Deleted - Conformance Test Aspects - Global Text Telephony | milestone | 0d? | 2000-09-21 A | 2000-09-21 A | 100% | 2000-09-21 | 2009-09-18 | 2348d? | finish no earlier than 2009-09-18 | R5; T1 |  |  | GTT_Test | Rel-4 | Ingbert | GTT_Test | PCG-23 | RP-45 |
| 5861 | 1471 | Release 1999 Features |  | 261d? | 2000-01-03 A | 2000-12-29 A | 100% | 2000-01-03 | 2000-12-29 | 261d? |  | NP; SP; TP; SMG | 8352h | 8352h |  | R99 | All |  |  |  |
| 5862 | 1472 | **UMTS Features** |  | 261d? | 1999-01-01 A | 1999-12-31 A | 100% | 1999-01-01 | 1999-12-31 | 261d? |  | S1; S2; S4; SMG; N3; N4; RP | 39672h | 39672h |  | R99 | Alain |  |  |  |
| 5863 | 1472.1 | UMTS_SERVICES |  | 261d? | 1999-01-01 A | 1999-12-31 A | 100% | 1999-01-01 | 1999-12-31 | 261d? | start no earlier than 1999-01-01 | S1 | 2088h | 2088h | UMTS_SERVICES | R99 | Alain | UMTS_SERVICES |  |  |
| 5864 | 1472.2 | UMTS phase 1 |  | 261d? | 1999-01-01 A | 1999-12-31 A | 100% | 1999-01-01 | 1999-12-31 | 261d? | start no earlier than 1999-01-01 | S1 | 2088h | 2088h | UMTS1 | R99 | Alain | UMTS1 |  |  |
| 5865 | 1472.3 | UMTS Capabilities |  | 261d? | 1999-01-01 A | 1999-12-31 A | 100% | 1999-01-01 | 1999-12-31 | 261d? | start no earlier than 1999-01-01 | S1 | 2088h | 2088h | UMTS_Capabil | R99 | Alain | UMTS_Capabil |  |  |
| 5866 | 1472.4 | Architecture of the GSM-UMTS platform |  | 261d? | 1999-01-01 A | 1999-12-31 A | 100% | 1999-01-01 | 1999-12-31 | 261d? | start no earlier than 1999-01-01 | S2; N4 | 4176h | 4176h |  | R99 | Maurice |  |  |  |
| 5867 | 1472.5 | UMTS Terrestrial Radio Access Network |  | 261d? | 1999-01-01 A | 1999-12-31 A | 100% | 1999-01-01 | 1999-12-31 | 261d? | start no earlier than 1999-01-01 | RP | 2088h | 2088h | UTRAN | R99 | Yong-Jun | UTRAN |  |  |
| 5868 | 1472.6 | UMTS 1800, UMTS 1900 |  | 261d? | 1999-01-01 A | 1999-12-31 A | 100% | 1999-01-01 | 1999-12-31 | 261d? | start no earlier than 1999-01-01 | R2 | 2088h | 2088h | Rlnlmp19,Rlnlmp18 | R99 | Yong-Jun | Rlnlmp19, Rlnlmp18 |  |  |
| 5869 | 1472.7 | Mandatory speech codec for narrowband telephony service |  | 261d? | 1999-01-01 A | 1999-12-31 A | 100% | 1999-01-01 | 1999-12-31 | 261d? | start no earlier than 1999-01-01 | S4 | 2088h | 2088h | Mandatory_Speech_Codec,AMR-NB,AMR | R99 | Paolo | Mandatory_Speech_Codec, AMR-NB, AMR |  |  |
| 5870 | 1472.8 | Codec for low bitrate multimedia telephony service |  | 261d? | 1999-01-01 A | 1999-12-31 A | 100% | 1999-01-01 | 1999-12-31 | 261d? | start no earlier than 1999-01-01 | S4 | 2088h | 2088h | Low_bit_rate_codec_for_MM_Tel.,H.324M | R99 | Paolo | Low_bit_rate_codec_for_MM_Tel., H.324M |  |  |
| 5871 | 1472.9 | 3G Audio-Visual Terminal characteristics |  | 261d? | 1999-01-01 A | 1999-12-31 A | 100% | 1999-01-01 | 1999-12-31 | 261d? | start no earlier than 1999-01-01 | S4 | 2088h | 2088h | WI5TAC,3G-AVT,Terminal_Acoustic_Characteristics | R99 | Paolo | WI5TAC, 3G-AVT, Terminal_Acoustic_Characteristics |  |  |
| 5872 | 1472.10 | Updates_for_UMTS |  | 261d? | 1999-01-01 A | 1999-12-31 A | 100% | 1999-01-01 | 1999-12-31 | 261d? | start no earlier than 1999-01-01 | N3 | 2088h | 2088h | Updates_for_UMTS | R99 | Gwiho | Updates_for_UMTS |  |  |
| 5873 | 1472.11 | UMTS |  | 261d? | 1999-01-01 A | 1999-12-31 A | 100% | 1999-01-01 | 1999-12-31 | 261d? | start no earlier than 1999-01-01 | N3 | 2088h | 2088h | UMTS | R99 | Gwiho | UMTS |  |  |
| 5874 | 1473 | **UMTS and GSM Features** |  | 261d? | 1999-01-01 A | 1999-12-31 A | 100% | 1999-01-01 | 1999-12-31 | 261d? |  | S1; S2; SMG; T2; N1; N2; N3; N4; R2; R3 | 219240h | 219240h |  | R99 | Alain |  |  |  |
| 5875 | 1473.1 | Multimedia Messaging Service |  | 261d? | 1999-01-01 A | 1999-12-31 A | 100% | 1999-01-01 | 1999-12-31 | 261d? | start no earlier than 1999-01-01 | T2 | 2088h | 2088h | MMS | R99 |  | MMS |  |  |
| 5876 | 1473.2 | Location Services |  | 261d? | 1999-01-01 A | 1999-12-31 A | 100% | 1999-01-01 | 1999-12-31 | 261d? | start no earlier than 1999-01-01 | S1; S2; S3; SMG1; SMG2; SMG12; N1; N2; N4; R2; R3 | 22968h | 22968h | LCS | R99 | Alain | LCS |  |  |
| 5877 | 1473.3 | **Customised Application for Mobile network Enhanced Logic Phase 3** |  | 261d? | 1999-01-01 A | 1999-12-31 A | 100% | 1999-01-01 | 1999-12-31 | 261d? |  | S1; S2; N2; N4 | 18792h | 18792h | CAMEL3 | R99 | Alain | CAMEL3 |  |  |
| 5878 | 1473.3.1 | Global view |  | 261d? | 1999-01-01 A | 1999-12-31 A | 100% | 1999-01-01 | 1999-12-31 | 261d? | start no earlier than 1999-01-01 | S1; S2; N2; N4 | 8352h | 8352h |  | R99 | Alain |  |  |  |
| 5879 | 1473.3.2 | Multiple Subscriber Profile (MSP) based on CAMEL phase 3 |  | 261d? | 1999-01-01 A | 1999-12-31 A | 100% | 1999-01-01 | 1999-12-31 | 261d? | start no earlier than 1999-01-01 | S1 | 2088h | 2088h |  | R99 | Alain |  |  |  |
| 5880 | 1473.4 | Short Message Service enhancements / Enhanced Messaging Service (EMS) |  | 261d? | 1999-01-01 A | 1999-12-31 A | 100% | 1999-01-01 | 1999-12-31 | 261d? | start no earlier than 1999-01-01 | T2 | 2088h | 2088h | EMS | R99 |  | EMS |  |  |
| 5881 | 1473.5 | Mobile Station Execution Environment |  | 261d? | 1999-01-01 A | 1999-12-31 A | 100% | 1999-01-01 | 1999-12-31 | 261d? | start no earlier than 1999-01-01 | S1; SMG1; T2 | 6264h | 6264h | MExE | R99 | Alain | MExE |  |  |
| 5882 | 1473.6 | MS_Classmark |  | 261d? | 1999-01-01 A | 1999-12-31 A | 100% | 1999-01-01 | 1999-12-31 | 261d? | start no earlier than 1999-01-01 | N1 | 2088h | 2088h | MS_Classmark | R99 | Frederic | MS_Classmark |  |  |

Notes:
- 5857: -
- 5858: - / Impacted TSs and TRs: 26.226, 26.230
- 5859: - / Impacted TSs and TRs: 26.231
- 5860: RP#45 work item abandoned/closed (it was never really started)
- 5861: -
- 5862: -
- 5863: - / Impacted TSs and TRs: 22.101
- 5864: - / Impacted TSs and TRs: 22.100
- 5865: Requirement for high quality speech in UMTS Phase 1 but not in R99 / Impacted TSs and TRs: 22.105
- 5866: wid Architecture overview of the GSM-UMTS System, Architecture the GSM-UMTS Platform and New Access Network to Core Network (BSS-NSS) interface / Impacted TSs and TRs: 23.002, 23.008, 23.060, 23.101, 23.110
- 5867: - / Impacted TSs and TRs: 22.011, 22.038, 22.060, 22.078, 22.100, 22.101, 22.105, 22.115, 22.129, 23.002, 23.060, 24.007, 24.008, 25.101, 25.102, 25.104, 25.105, 25.113, 25.123, 25.133, 25.141, 25.142, 25.201, 25.211, 25.212, 25.213, 25.214, 25.215, 25.221, 25.222, 25.223, 25.224,
- 5868: - / Impacted TSs and TRs: 25.307 CR#0002, 0003 Inclusion of release independent RF related information
- 5869: Define the default speech codec for UMTS (both for FDD and TDD). Definition limited to selection of one codec among several existing ones/proposed codecs: GSM AMR, IS127 EVRC, ITU G.729 and MPEG-4 speech codec. / Impacted TSs and TRs: 04.08, 05.01, 05.02, 05.03, 05.05, 05.08, 05.09, 05.09, 05.50, 08.60, 08.61, 11.21, 26.071, 26.073, 26.074, 26.090, 26.091, 26.092, 26.093, 26.094, 26.101, 26.102, 26.103, 26.104, 26.975
- 5870: - / Impacted TSs and TRs: 26.104, 26.110, 26.111, 26.911, 26.912, 26.915
- 5871: - / Impacted TSs and TRs: 26.131, 26.132
- 5872: - / Impacted TSs and TRs: 24.022, 27.001, 29.007
- 5873: - / Impacted TSs and TRs: 27.060, 29.061
- 5874: -
- 5875: MMS allows users to send/receive messages e.g. almost unlimited text length, images, audio and video clips and new content types. R99 only includes the concept. MMS stage 3 is not included in 23.140. Rel-4 adds detailed architecture and protocols. / Impacted TSs and TRs: 22.140, 23.040, 23.140
- 5876: LCS provide ability to localize a terminal / Impacted TSs and TRs: 02.07, 03.71, 04.31, 04.35, 04.71, 05.05, 08.08, 08.31, 08.71, 09.31, 22.071, 23.002, 23.003, 23.007, 23.008, 23.016, 23.018, 23.032, 23.171, 24.007, 24.008, 24.030, 24.080, 25.305, 25.306, 25.331, 25.413, 25.423, 29.002, 29.010
- 5877: CAMEL is a network feature providing mechanisms to support services of operators which are not covered by standardised services, even when roaming outside the HPLMN. / Impacted TSs and TRs: 22.101, 23.008, 23.012, 23.016, 23.018, 23.060, 23.072, 23.078, 23.079, 23.082, 23.093, 29.002, 29.078
- 5878: - / Impacted TSs and TRs: 22.078, 23.078, 29.078
- 5879: MSP is an optional service enabling mobile subscribers to have several profiles associated with a single IMSI, with each profile being a subscription option. Each profile may be used for mobile originated and mobile terminated calls. / Impacted TSs and TRs: 22.097 (Advanced Addressing)
- 5880: SMS for 3G terminals compatible with GSM SMS. Added Enhanced Messaging Service (EMS) allowing small pictures, sounds, animations to be transferred via SMS. / Impacted TSs and TRs: 23.038, 23.039, 23.040, 23.042
- 5881: MExE provides a standardized MS execution environment and ability to negotiate its supported capabilities with a MExE SP. R99 enhances SIM MExE certificate management, security clarifications, QoS and defines two MExE classmarks WAP/Personal-Java based. / Impacted TSs and TRs: 02.57, 22.057, 22.101, 23.057
- 5882: MExE classmark identifies a category of MExE UE supporting MExE functionality with a minimum level of processing, memory, display, and interactive capabilities. Several MExE classmarks may be defined. / Impacted TSs and TRs: 24.008

| ID | WBS | Task | Duration | Start | Finish | Complete | Baseline start | Baseline finish | Baseline duration | Constraint | Resources | Work | Actual work | Acronym | Release | MCC resp | Acronym_3GU_Export | TSG stopped |
| --- | --- | --- | --- | --- | --- | --- | --- | --- | --- | --- | --- | --- | --- | --- | --- | --- | --- | --- |
| 5883 | 1473.7 | **MultiCall** | 261d? | 1999-01-01 A | 1999-12-31 A | 100% | 1999-01-01 | 1999-12-31 | 261d? |  | S1; N1; N2; N4 | 10440h | 10440h | Multicall | R99 | Alain | Multicall |  |
| 5884 | 1473.7.1 | Stage 1 for Multicall | 261d? | 1999-01-01 A | 1999-12-31 A | 100% | 1999-01-01 | 1999-12-31 | 261d? | start no earlier than 1999-01-01 | S1 | 2088h | 2088h |  | R99 | Alain |  |  |
| 5885 | 1473.8 | Virtual Home Environment | 261d? | 1999-01-01 A | 1999-12-31 A | 100% | 1999-01-01 | 1999-12-31 | 261d? | start no earlier than 1999-01-01 | S1; SMG1; S2 | 6264h | 6264h | VHE | R99 | Alain | VHE |  |
| 5886 | 1473.9 | Open Service Access | 261d? | 1999-01-01 A | 1999-12-31 A | 100% | 1999-01-01 | 1999-12-31 | 261d? | start no earlier than 1999-01-01 | S1; S2; N5 | 6264h | 6264h | OSA | R99 | Alain | OSA |  |
| 5887 | 1473.10 | Super Charger mechanism for signalling traffic associated with mobility | 261d? | 1999-01-01 A | 1999-12-31 A | 100% | 1999-01-01 | 1999-12-31 | 261d? | start no earlier than 1999-01-01 | N2; N4 | 4176h | 4176h | Super_Charger | R99 | Kimmo | Super_Charger |  |
| 5888 | 1473.11 | Follow_Me service | 261d? | 1999-01-01 A | 1999-12-31 A | 100% | 1999-01-01 | 1999-12-31 | 261d? | start no earlier than 1999-01-01 | S1; N2; N4 | 6264h | 6264h | Follow_Me | R99 | Alain | Follow_Me |  |
| 5889 | 1473.12 | Wide area network Synchronization and object exchange | 261d? | 1999-01-01 A | 1999-12-31 A | 100% | 1999-01-01 | 1999-12-31 | 261d? | start no earlier than 1999-01-01 | T2 | 2088h | 2088h | SYNC | R99 |  | SYNC |  |
| 5890 | 1473.13 | **R99 Terminal Interfaces** | 261d? | 1999-01-01 A | 1999-12-31 A | 100% | 1999-01-01 | 1999-12-31 | 261d? |  | T2 | 8352h | 8352h |  | R99 |  |  |  |
| 5891 | 1473.13.1 | AT commands for 3GPP | 261d? | 1999-01-01 A | 1999-12-31 A | 100% | 1999-01-01 | 1999-12-31 | 261d? | start no earlier than 1999-01-01 | T2 | 2088h | 2088h |  | R99 |  |  |  |
| 5892 | 1473.13.2 | Physical interfaces | 261d? | 1999-01-01 A | 1999-12-31 A | 100% | 1999-01-01 | 1999-12-31 | 261d? | start no earlier than 1999-01-01 | T2 | 2088h | 2088h |  | R99 |  |  |  |
| 5893 | 1473.13.3 | Multiplexer | 261d? | 1999-01-01 A | 1999-12-31 A | 100% | 1999-01-01 | 1999-12-31 | 261d? | start no earlier than 1999-01-01 | T2 | 2088h | 2088h | MUXMS-TE | R99 |  | MUX MS-TE |  |
| 5894 | 1473.14 | **Bearer Services** | 261d? | 1999-01-01 A | 1999-12-31 A | 100% | 1999-01-01 | 1999-12-31 | 261d? |  | S1; T2; N1; N3 | 41760h | 41760h |  | R99 | Alain |  |  |
| 5895 | 1473.14.1 | **Circuit Switched Bearer Services** | 261d? | 1999-01-01 A | 1999-12-31 A | 100% | 1999-01-01 | 1999-12-31 | 261d? |  | S1; N3 | 16704h | 16704h | Circuit_switched_Bearer_Services | R99 | Alain | Circuit_switched_Bearer_Services |  |
| 5896 | 1473.14.1.1 | Stage 1 for Circuit Switched Bearer Services | 261d? | 1999-01-01 A | 1999-12-31 A | 100% | 1999-01-01 | 1999-12-31 | 261d? | start no earlier than 1999-01-01 | S1 | 2088h | 2088h | CS_Bearerss_in_UMTS | R99 | Alain | CS_Bearerss_in_UMTS |  |
| 5897 | 1473.14.1.2 | CS_Bearers | 261d? | 1999-01-01 A | 1999-12-31 A | 100% | 1999-01-01 | 1999-12-31 | 261d? | start no earlier than 1999-01-01 | N3 | 2088h | 2088h | CS_Bearers | R99 | Gwiho | CS_Bearers |  |
| 5898 | 1473.14.1.3 | CS_Bearerss | 261d? | 1999-01-01 A | 1999-12-31 A | 100% | 1999-01-01 | 1999-12-31 | 261d? | start no earlier than 1999-01-01 | N3 | 2088h | 2088h | CS_Bearerss | R99 | Gwiho | CS_Bearerss |  |
| 5899 | 1473.14.1.4 | CS_Data | 261d? | 1999-01-01 A | 1999-12-31 A | 100% | 1999-01-01 | 1999-12-31 | 261d? | start no earlier than 1999-01-01 | N3 | 2088h | 2088h | CS_Data | R99 | Gwiho | CS_Data |  |
| 5900 | 1473.14.1.5 | CS_Data_Bearers | 261d? | 1999-01-01 A | 1999-12-31 A | 100% | 1999-01-01 | 1999-12-31 | 261d? | start no earlier than 1999-01-01 | N3 | 2088h | 2088h | CS_Data_Bearers | R99 | Gwiho | CS_Data_Bearers |  |
| 5901 | 1473.14.1.6 | Deleted - CN3 poart of Circuit Switched Bearer Services | 261d? | 1999-01-01 A | 1999-12-31 A | 100% | 1999-01-01 | 1999-12-31 | 261d? | start no earlier than 1999-01-01 | N3 | 2088h | 2088h | CSBS | R99 | Gwiho | CSBS | NP-06 |
| 5902 | 1473.14.2 | Frame Tunnelling Mode | 261d? | 1999-01-01 A | 1999-12-31 A | 100% | 1999-01-01 | 1999-12-31 | 261d? | start no earlier than 1999-01-01 | T2; N1; N3 | 6264h | 6264h | FTM | R99 | Gwiho | FTM |  |
| 5903 | 1473.14.3 | Access to ISPs and Intranets – Wireless/Remote access to LANs | 261d? | 1999-01-01 A | 1999-12-31 A | 100% | 1999-01-01 | 1999-12-31 | 261d? | start no earlier than 1999-01-01 | N3 | 2088h | 2088h | InterworkingwithPDN(DHCP) | R99 | Gwiho | Interworking with PDN (DHCP) |  |
| 5904 | 1473.14.4 | **PHS Internet Access Forum Specification** | 261d? | 1999-01-01 A | 1999-12-31 A | 100% | 1999-01-01 | 1999-12-31 | 261d? |  | S1; N3 | 8352h | 8352h | PIAFS | R99 | Alain | PIAFS |  |
| 5905 | 1473.14.4.1 | Personal Handyphone System Internet Access Forum Standard (PIAFS) | 261d? | 1999-01-01 A | 1999-12-31 A | 100% | 1999-01-01 | 1999-12-31 | 261d? | start no earlier than 1999-01-01 | S1 | 2088h | 2088h |  | R99 | Alain |  |  |
| 5906 | 1473.14.4.2 | Support_of_PIAFS_in_UMTS | 261d? | 1999-01-01 A | 1999-12-31 A | 100% | 1999-01-01 | 1999-12-31 | 261d? | start no earlier than 1999-01-01 | N3 | 2088h | 2088h | Support_of_PIAFS_in_UMTS | R99 | Gwiho | Support_of_PIAFS_in_UMTS |  |

Notes:
- 5883: Multicall allows several simultaneous CS calls with dedicated bearers of independent traffic and performance characteristics. R99 Multicall was defined as a supplementary service limited to one CS bearer to be used for speech at any time. / Impacted TSs and TRs: 22.030, 22.083, 22.087, 23.008, 23.009, 23.016, 23.018, 23.108, 23.135, 24.008, 24.080, 24.135, 29.002, 29.010
- 5884: - / Impacted TSs and TRs: 22.030, 22.083, 22.087
- 5885: Information exists in SP#5-8 reports & in SP-99416,SP-000095,SP 000155. OSA allows service development by operators and 3rd parties by making use of network functionality through open, standardised, secure, extensible and scalable interfaces. / Impacted TSs and TRs: 02.01, 22.105, 22.121,23.127
- 5886: Open Service Architecture became in later Releases Open Service Access. Produced by Parlay, ETSI SPAN (TISPAN), 3GPP SA1 (Stage 1), SA2 (Stage 2) and CN5 (Stage 3), resulting in a single set of standard OSA APIs for the whole development community. / Impacted TSs and TRs: 22.121, 23.127, 29.198, 29.998
- 5887: Super Charger reduces mobility management cost by reducing the volume of location update signalling. It changes subscriber data management associated with inter-VLR and SGSN location updates. It also applies to packet services (SGSN replaces VLR and / Impacted TSs and TRs: 21.905, 23.007, 23.008, 23.012, 23.016, 23.018, 23.040, 23.060, 23.116, 23.912, 29.002
- 5888: Follow Me enables a mobile subscriber A to manipulate the Follow Me data of a party B in such a way that - under certain conditions - subsequent calls directed to party B will be forwarded to subscriber A. It is PLMN-specific and control based on USSD / Impacted TSs and TRs: 21.905, 22.004, 22.030, 22.082, 22.090, 22.094, 23.090, 24.090, 22.094, 23.011, 23.015, 23.082, 29.002
- 5889: Allows data stored in ME/USIM to be synchronized with the outside world. TS 27.103 defines protocols based upon IrMC level 4 and will evaluate new technologies (XML) for inclusion. From Rel-4 IrMC was replaced by SyncML in 27.103. / Impacted TSs and TRs: 27.103, 27.903
- 5890: -
- 5891: AT commands to control a 3G ME via an external Terminal Equipment (TE), fully compatible with GSM AT commands. R99 adds new AT commands e.g. to control Advanced Speech Call Items (ASCI) services. / Impacted TSs and TRs: 27.005, 27.007
- 5892: Conclusion: 3GPP should not produce any technical specification for terminal interfaces other than radio interface and USIM interface. SDOs could develop own optional physical connector specification based on market requirements / Impacted TSs and TRs: 27.901
- 5893: Multiplexing protocol allowing a number of simultaneous sessions between a MS and a terminal; used to send any data (voice, SMS, USSD, fax etc.). 27.010 describes the protocol, but not the commands or data transported with it. / Impacted TSs and TRs: 27.010
- 5894: -
- 5895: CS and real-time data services provided for interworking with PSTN/ISDN so that user is unaware of access network used (UMTS, GSM or handover between ANs). Transparent(constant delay) & non-transparent(zero error with flow control) services are supported / Impacted TSs and TRs: 22.002, 23.910, 27.001, 29.007
- 5896: CS and real-time data services provided for interworking with PSTN/ISDN so that user is unaware of access network used (UMTS, GSM or handover between ANs). Transparent(constant delay) & non-transparent(zero error with flow control) services are supported / Impacted TSs and TRs: 22.002
- 5897: - / Impacted TSs and TRs: 29.007
- 5898: - / Impacted TSs and TRs: 04.21, 23.910, 27.001, 29.007
- 5899: - / Impacted TSs and TRs: 27.001, 27.002, 27.003, 29.007
- 5900: - / Impacted TSs and TRs: 23.910, 27.001, 29.007
- 5901: No CR or new TS/TR approved under this WI / Impacted TSs and TRs: 23.910, 27.001, 29.007
- 5902: FTM is a type of async non-transparent CS bearer service (22.002). Generic term for HDLC and HDLC-related transmission protocols. Converts async non-transp data stream towards mobile side & sync data stream using X.31 flag stuffing on fixed network side. / Impacted TSs and TRs: 22.002, 27.001, 27.007, 29.007
- 5903: Access to an Intranet or ISP by running DHCP between the TE and a server in the Intranet/ISP domain. / Impacted TSs and TRs: 29.061
- 5904: PIAFS is one type of CS bearer data service (22.002). It refers to async CS tx protocol over ISDN 64 kbit/s unrestricted digital line. Facilitates interworking between PHS-MS and UMTS-UE & UMTS-UE and existing PIAFS TA (Terminal Adapter). / Impacted TSs and TRs: 22.002, 27.001, 27.007, 29.007
- 5905: PIAFS was originally standardised by the PHS Internet Access Forum in Japan. More information can be found at: http://www.infopro.or.jp/piaf / Impacted TSs and TRs: 22.002
- 5906: - / Impacted TSs and TRs: 27.001, 27.007, 29.007

| ID | WBS | Task | Duration | Start | Finish | Complete | Baseline start | Baseline finish | Baseline duration | Constraint | Resources | Work | Actual work | Acronym | Release | MCC resp | Acronym_3GU_Export | TSG stopped |
| --- | --- | --- | --- | --- | --- | --- | --- | --- | --- | --- | --- | --- | --- | --- | --- | --- | --- | --- |
| 5907 | 1473.15 | **Universal Integrated Circuit Card (UICC) and Universal Subscriber Identity Module (USIM)** | 261d? | 1999-01-01 A | 1999-12-31 A | 100% | 1999-01-01 | 1999-12-31 | 261d? |  | T3 | 31320h | 31320h | UICC,USIM | R99 | Xavier | UICC, USIM |  |
| 5908 | 1473.15.1 | UICC / Terminal interface; Physical and logical characteristics | 261d? | 1999-01-01 A | 1999-12-31 A | 100% | 1999-01-01 | 1999-12-31 | 261d? | start no earlier than 1999-01-01 | T3 | 2088h | 2088h | UICC | R99 | Xavier | UICC |  |
| 5909 | 1473.15.2 | UICC/(U)SIM enhancements and interworking | 261d? | 1999-01-01 A | 1999-12-31 A | 100% | 1999-01-01 | 1999-12-31 | 261d? | start no earlier than 1999-01-01 | T3 | 2088h | 2088h | UICC99 | R99 | Xavier | UICC1 |  |
| 5910 | 1473.15.3 | Characteristics of the USIM application | 261d? | 1999-01-01 A | 1999-12-31 A | 100% | 1999-01-01 | 1999-12-31 | 261d? | start no earlier than 1999-01-01 | T3 | 2088h | 2088h | USIM | R99 | Xavier | USIM |  |
| 5911 | 1473.15.4 | UICC Application Identifiers | 261d? | 1999-01-01 A | 1999-12-31 A | 100% | 1999-01-01 | 1999-12-31 | 261d? | start no earlier than 1999-01-01 | T3 | 2088h | 2088h | AID,Application_Identifiers | R99 | Xavier | AID, Application_Identifiers |  |
| 5912 | 1473.15.5 | SIM Application Toolkit | 261d? | 1999-01-01 A | 1999-12-31 A | 100% | 1999-01-01 | 1999-12-31 | 261d? | start no earlier than 1999-01-01 | S1; T3 | 4176h | 4176h | SAT | R99 | Alain | SAT |  |
| 5913 | 1473.15.6 | USIM Application Toolkit | 261d? | 1999-01-01 A | 1999-12-31 A | 100% | 1999-01-01 | 1999-12-31 | 261d? | start no earlier than 1999-01-01 | T3 | 2088h | 2088h | USAT | R99 | Xavier | USAT |  |
| 5914 | 1473.15.7 | Bearer Independent Protocol for SAT applications to exchange data over the GSM network | 261d? | 1999-01-01 A | 1999-12-31 A | 100% | 1999-01-01 | 1999-12-31 | 261d? | start no earlier than 1999-01-01 | T3 | 2088h | 2088h | BIP | R99 | Xavier | BIP |  |
| 5915 | 1473.15.8 | Administrative commands and functions for IC cards | 261d? | 1999-01-01 A | 1999-12-31 A | 100% | 1999-01-01 | 1999-12-31 | 261d? | start no earlier than 1999-01-01 | T3 | 2088h | 2088h |  | R99 | Xavier |  |  |
| 5916 | 1473.15.9 | USIM and UICC requirements | 261d? | 1999-01-01 A | 1999-12-31 A | 100% | 1999-01-01 | 1999-12-31 | 261d? | start no earlier than 1999-01-01 | T3 | 2088h | 2088h |  | R99 | Xavier |  |  |
| 5917 | 1473.15.10 | SIM_API | 261d? | 1999-01-01 A | 1999-12-31 A | 100% | 1999-01-01 | 1999-12-31 | 261d? | start no earlier than 1999-01-01 | T3 | 2088h | 2088h | SIM_API | R99 | Xavier | SIM_API |  |
| 5918 | 1473.15.11 | SIM_toolkit_API | 261d? | 1999-01-01 A | 1999-12-31 A | 100% | 1999-01-01 | 1999-12-31 | 261d? | start no earlier than 1999-01-01 | SMG9; T3 | 4176h | 4176h | SIM_toolkit | R99 | Xavier | SIM_toolkit |  |
| 5919 | 1473.15.12 | Deleted - 1.8 Volt SIM ME interface | 261d? | 1999-01-01 A | 1999-12-31 A | 100% | 1999-01-01 | 1999-12-31 | 261d? | start no earlier than 1999-01-01 | SMG9 | 2088h | 2088h | SMIME_1.8V | R99 | Xavier | SMIME_1.8V | TP-06 |
| 5920 | 1473.16 | **USIM/UICC Testing** | 261d? | 1999-01-01 A | 1999-12-31 A | 100% | 1999-01-01 | 1999-12-31 | 261d? |  | T3 | 10440h | 10440h |  | R99 | Xavier |  |  |
| 5921 | 1473.16.1 | Terminal tests for the UICC Interface | 261d? | 1999-01-01 A | 1999-12-31 A | 100% | 1999-01-01 | 1999-12-31 | 261d? | start no earlier than 1999-01-01 | T3 | 2088h | 2088h |  | R99 | Xavier |  |  |
| 5922 | 1473.16.2 | USIM application test specification | 261d? | 1999-01-01 A | 1999-12-31 A | 100% | 1999-01-01 | 1999-12-31 | 261d? | start no earlier than 1999-01-01 | T3 | 2088h | 2088h |  | R99 | Xavier |  |  |
| 5923 | 1473.16.3 | USIM conformance test specification | 261d? | 1999-01-01 A | 1999-12-31 A | 100% | 1999-01-01 | 1999-12-31 | 261d? | start no earlier than 1999-01-01 | T3 | 2088h | 2088h |  | R99 | Xavier |  |  |
| 5924 | 1473.16.4 | SIM toolkit test specification | 261d? | 1999-01-01 A | 1999-12-31 A | 100% | 1999-01-01 | 1999-12-31 | 261d? | start no earlier than 1999-01-01 | T3 | 2088h | 2088h |  | R99 | Xavier |  |  |
| 5925 | 1473.17 | **Security for UMTS and GSM Features** | 261d? | 1999-01-01 A | 1999-12-31 A | 100% | 1999-01-01 | 1999-12-31 | 261d? |  | S3; N2; N4 | 16704h | 16704h | Security | R99 | Mirko | Security |  |
| 5926 | 1473.17.1 | Fraud Information Gathering Service (for connection-orientated services) | 261d? | 1999-01-01 A | 1999-12-31 A | 100% | 1999-01-01 | 1999-12-31 | 261d? | start no earlier than 1999-01-01 | S3 | 2088h | 2088h | FIGS | R99 | Mirko | FIGS |  |
| 5927 | 1473.17.2 | Immediate Service Termination / SECurity Immediate Service Termination | 261d? | 1999-01-01 A | 1999-12-31 A | 100% | 1999-01-01 | 1999-12-31 | 261d? | start no earlier than 1999-01-01 | S3; N2; N4 | 6264h | 6264h | IST,SECIST | R99 | Mirko | IST, SECIST |  |
| 5928 | 1473.17.3 | Core_Network_Security | 261d? | 1999-01-01 A | 1999-12-31 A | 100% | 1999-01-01 | 1999-12-31 | 261d? | start no earlier than 1999-01-01 | N4 | 2088h | 2088h | Core_Network_Security | R99 | Kimmo | Core_Network_Security |  |
| 5929 | 1474 | **GSM Features** | 261d? | 1999-01-01 A | 1999-12-31 A | 100% | 1999-01-01 | 1999-12-31 | 261d? |  | S1; S2; SMG; T2; N1; N2; N3; N4 | 164952h | 164952h |  | R99 | Alain |  |  |
| 5930 | 1474.1 | **Dual Transfer Mode within GSM and GPRS** | 261d? | 1999-01-01 A | 1999-12-31 A | 100% | 1999-01-01 | 1999-12-31 | 261d? |  | SMG; N1 | 10440h | 10440h | DTM | R99 | Frederic | DTM |  |
| 5931 | 1474.1.1 | Class A Dual Transfer Mode | 261d? | 1999-01-01 A | 1999-12-31 A | 100% | 1999-01-01 | 1999-12-31 | 261d? | start no earlier than 1999-01-01 | SMG | 2088h | 2088h | Class_A_Dual_Transfer_Mode_(DTM) | R99 | Frederic | Class_A_Dual_Transfer_Mode_(DTM) |  |
| 5932 | 1474.1.2 | Dual Transfer Mode | 261d? | 1999-01-01 A | 1999-12-31 A | 100% | 1999-01-01 | 1999-12-31 | 261d? | start no earlier than 1999-01-01 | SMG; N1 | 4176h | 4176h |  | R99 | Frederic |  |  |

Notes:
- 5907: For 3G, GSM 11.11 was divided into two parts: a platform comprised of basic physical, electrical and logical specification (31.101) and an application specification (31.102)
- 5908: Defines a generic Terminal/Integrated Circuit Card (ICC) interface. Is independent of 3G USIM application => platform for any IC card application. Ensures interoperability between ICC and terminal independently of manufacturer, card issuer or operator. / Impacted TSs and TRs: 31.101 (Since 10/2000, ETSI EP SCP is responsible for the generic Terminal/Integrated Circuit Card (ICC) interface TS 102 221)
- 5909: Acronym changed from UICC1 / Impacted TSs and TRs: 31.102, 31.900
- 5910: Defines Universal Subscriber Identity Module (USIM) application for 3G telecom network operation & resides on UICC, an IC card specified in 31.101. UICC can be used as a multi-application card: several USIMs and/or other applications can co-exist / Impacted TSs and TRs: 31.102
- 5911: Defines and administers Application IDentifiers (AID) for UICC. AID is used to address an application in the card. Consists of Registered application provider ID (RID) & Proprietary application ID exception (PIX - according to ISO/IEC 7816-5). / Impacted TSs and TRs: 21.111, 31.110
- 5912: - / Impacted TSs and TRs: 11.14, 22.030, 22.100, 22.101
- 5913: Defines UICC - ME interface, and mandatory ME procedures for USAT. Based on GSM 11.14 (SIM Application Toolkit). Commands and procedures defined in USIM and 3G Terminal for using USAT. Service and security requirements defined in 22.100 and 22.101. / Impacted TSs and TRs: 31.111
- 5914: Defines at SIM-ME interface a basic protocol allowing SIM Toolkit applications to determine available bearers and to exchange data by selecting using the most appropriate bearer available (CS data, GPRS, SMS, Unstructured Supplementary Service Data (USSD) / Impacted TSs and TRs: 03.48, 11.10, 11.14
- 5915: Defines function and syntax of administrative commands for telecommunication IC Card used during installation, activation and de-activation of applications. Compliant to ISO/IEC 7816 series. Handed over to ETSI Project Smart Card Platform (SCP) in 2000. / Impacted TSs and TRs: ETSI TS 102 222
- 5916: High level requirements for 3GPP IC card and its interface to 3GPP terminal (USIM&UICC reqs). Service&security reqs in 322.01,22.00. USIM is a 3GPP application on an IC card. Inter-operates with 3GPP terminals and provides access to 3GPP services / Impacted TSs and TRs: 21.111
- 5917: - / Impacted TSs and TRs: 03.19
- 5918: - / Impacted TSs and TRs: 03.48, 11.11, 11.14
- 5919: No CR or new TS/TR approved under this WI / Impacted TSs and TRs: 11.18
- 5920: -
- 5921: Test spec for the interface between UICC and terminal (originally based GSM 11.10-1 clause 27). Ensures UICC - terminal interoperability independently of manufacturer, card issuer or operator. Tests for applications residing on UICC are in 31.121 / Impacted TSs and TRs: 31.120
- 5922: Application test spec originally based on GSM 11.17. Aspects related to UICC administrative management phase are not defined. Any internal technical realisation of either UICC or terminal is only specified where these are reflected over the interface. / Impacted TSs and TRs: 31.121
- 5923: Conformance Test specification for UICC defined in 31.101 with USIM defined in 31.102. / Impacted TSs and TRs: 31.122
- 5924: SIM Application Toolkit (SAT) has major impact on ME design and enhances SIM/ME interface. Contains tests for SIM/ME interface optional features (no network related signalling issues involved). Doesn't form basis for any type approval or regulatory tests. / Impacted TSs and TRs: 11.10-4
- 5925: - / Impacted TSs and TRs: 02.09, 03.20, 21.133, 22.022, 23.003, 23.007, 23.008, 23.012, 23.018, 24.007, 24.008, 24.010, 24.011, 29.002, 29.060, New (33.102, 33.103, 33.105, 33.107, 35.201)
- 5926: HPLMN can monitor its subscribers in VPLMN, which collects info on a defined set of monitored subscribers activities & sends it to HPLMN, which can perform service limitation control eg Operator Determined Barring (ODB) and IST to limit financial exposure / Impacted TSs and TRs: New 22.031, 23.031
- 5927: HPLMN can terminate all activities of its subscriber in VPLMN, if decides (based on info via eg FIGS) that a roaming subscriber is behaving in fraudulent/suspicious way. HPLMN can terminate all subscriber activities including calls in progress. / Impacted TSs and TRs: 03.35, 22.032, 23.008, 23.016, 23.035, 29.002
- 5928: - / Impacted TSs and TRs: 29.002
- 5929: -
- 5930: 2-99-1780 (2-99-H80 from SMG2#32) WID on BSS co-ordination of Radio Resource allocation for class A GPRS services - GSM Radio Access (R99) / Impacted TSs and TRs: 03.55, 03.64, 04.18, 04.60, 05.01, 05.02, 05.08, 08.08, 23.060, 24.007, 24.008
- 5931: - / Impacted TSs and TRs: 05.10
- 5932: - / Impacted TSs and TRs: 03.55, 03.64, 04.18, 05.01, 05.02, 05.08, 24.008

| ID | WBS | Task | Duration | Start | Finish | Complete | Baseline start | Baseline finish | Baseline duration | Constraint | Resources | Work | Actual work | Acronym | Release | MCC resp | Acronym_3GU_Export | TSG stopped | WI rapporteur name | WI rapporteur e-mail |
| --- | --- | --- | --- | --- | --- | --- | --- | --- | --- | --- | --- | --- | --- | --- | --- | --- | --- | --- | --- | --- |
| 5933 | 1474.2 | **General Packet Radio Service enahancements** | 261d? | 1999-01-01 A | 1999-12-31 A | 100% | 1999-01-01 | 1999-12-31 | 261d? |  | S1; S2; SMG1; SMG2; SMG7; N1; N2; N3; N4; T2 | 50112h | 50112h | GPRSenhancements | R99 | Alain | GPRS enhancements |  |  |  |
| 5934 | 1474.2.1 | General Packet Radio Service | 261d? | 1999-01-01 A | 1999-12-31 A | 100% | 1999-01-01 | 1999-12-31 | 261d? | start no earlier than 1999-01-01 | S1; S2; SMG1; SMG2; SMG7; N1; N2; N3; N4; T2 | 20880h | 20880h | GPRS | R99 | Alain | GPRS |  |  |  |
| 5935 | 1474.2.2 | GPRS2 | 261d? | 1999-01-01 A | 1999-12-31 A | 100% | 1999-01-01 | 1999-12-31 | 261d? | start no earlier than 1999-01-01 | SMG1; N2 | 4176h | 4176h | GPRS2 | R99 |  | GPRS2 |  |  |  |
| 5936 | 1474.2.3 | GPRS Tunnelling Protocol enhancement | 261d? | 1999-01-01 A | 1999-12-31 A | 100% | 1999-01-01 | 1999-12-31 | 261d? | start no earlier than 1999-01-01 | N4; N2 | 4176h | 4176h | GTP_enhancement | R99 | Kimmo | GTP_enhancement |  |  |  |
| 5937 | 1474.3 | **Enhanced Data rates for GSM Evolution - Phase 1** | 261d? | 1999-01-01 A | 1999-12-31 A | 100% | 1999-01-01 | 1999-12-31 | 261d? |  | SMG2; SMG1; SMG3; SMG4; SMG7; SMG9; SMG10; N1; N3; T2 | 73080h | 73080h | EDGE-Phase1 | R99 | Maurice | EDGE - Phase 1 |  |  |  |
| 5938 | 1474.3.1 | Enhanced Data rates for GSM Evolution | 261d? | 1999-01-01 A | 1999-12-31 A | 100% | 1999-01-01 | 1999-12-31 | 261d? | start no earlier than 1999-01-01 | SMG2; SMG1; SMG3; SMG4; SMG7; SMG9; SMG10; N1; N3; T2 | 20880h | 20880h | EDGE | R99 | Maurice | EDGE |  |  |  |
| 5939 | 1474.3.2 | EDGE-Layer1 | 261d? | 1999-01-01 A | 1999-12-31 A | 100% | 1999-01-01 | 1999-12-31 | 261d? | start no earlier than 1999-01-01 | SMG2 | 2088h | 2088h | EDGE-Layer1 | R99 |  | EDGE-Layer1 |  |  |  |
| 5940 | 1474.3.3 | High Speed Circuit Switched Data | 261d? | 1999-01-01 A | 1999-12-31 A | 100% | 1999-01-01 | 1999-12-31 | 261d? | start no earlier than 1999-01-01 | SMG1; SMG2; SMG7 | 6264h | 6264h | HSCSD | R99 |  | HSCSD |  |  |  |
| 5941 | 1474.3.4 | Enhanced Circuit Switched Data - Phase 1 | 261d? | 1999-01-01 A | 1999-12-31 A | 100% | 1999-01-01 | 1999-12-31 | 261d? | start no earlier than 1999-01-01 | S1; SMG | 4176h | 4176h | ECSD | R99 | Alain | ECSD |  |  |  |
| 5942 | 1474.3.5 | EDGE-Enhanced Circuit Switched Data | 261d? | 1999-01-01 A | 1999-12-31 A | 100% | 1999-01-01 | 1999-12-31 | 261d? | start no earlier than 1999-01-01 | SMG2 | 2088h | 2088h | EDGE-ECSD | R99 |  | EDGE-ECSD |  |  |  |
| 5943 | 1474.3.6 | Enhanced GPRS - Phase 1 | 261d? | 1999-01-01 A | 1999-12-31 A | 100% | 1999-01-01 | 1999-12-31 | 261d? | start no earlier than 1999-01-01 | SMG; N1 | 4176h | 4176h | EGPRS | R99 |  | EGPRS |  |  |  |
| 5944 | 1474.3.7 | EDGE-EGPRS | 261d? | 1999-01-01 A | 1999-12-31 A | 100% | 1999-01-01 | 1999-12-31 | 261d? | start no earlier than 1999-01-01 | SMG2 | 2088h | 2088h | EDGE-EGPRS | R99 |  | EDGE-EGPRS |  |  |  |
| 5945 | 1474.3.8 | Packet Flow Context (PFC) | 261d? | 1999-01-01 A | 1999-12-31 A | 100% | 1999-01-01 | 1999-12-31 | 261d? | start no earlier than 1999-01-01 | SMG2 | 2088h | 2088h | PFC | R99 |  | PFC |  |  |  |
| 5946 | 1474.3.9 | Support for EGPRS in ANSI-136 networks and EDGE COMPACT | 261d? | 1999-01-01 A | 1999-12-31 A | 100% | 1999-01-01 | 1999-12-31 | 261d? | start no earlier than 1999-01-01 | SMG | 2088h | 2088h | EDGE-Compact | R99 |  | EDGE-Compact |  |  |  |
| 5947 | 1474.3.10 | EGPRS COMPACT | 261d? | 1999-01-01 A | 1999-12-31 A | 100% | 1999-01-01 | 1999-12-31 | 261d? | start no earlier than 1999-01-01 | SMG | 2088h | 2088h | EGPRS-Compact | R99 |  | EGPRS-Compact |  |  |  |
| 5948 | 1474.3.11 | COMPACT | 261d? | 1999-01-01 A | 1999-12-31 A | 100% | 1999-01-01 | 1999-12-31 | 261d? | start no earlier than 1999-01-01 | SMG; N1 | 4176h | 4176h | COMPACT | R99 |  | COMPACT |  |  |  |
| 5949 | 1474.4 | GSM_400 | 261d? | 1999-01-01 A | 1999-12-31 A | 100% | 1999-01-01 | 1999-12-31 | 261d? | start no earlier than 1999-01-01 | SMG2; SMG7; T2 | 6264h | 6264h | GSM_400 | R99 | Paolo | GSM_400 |  |  |  |
| 5950 | 1474.5 | GSM_450 | 261d? | 1999-01-01 A | 1999-12-31 A | 100% | 1999-01-01 | 1999-12-31 | 261d? | start no earlier than 1999-01-01 | SMG2 | 2088h | 2088h | GSM_450 | R99 |  | GSM_450 |  |  |  |
| 5951 | 1474.6 | GSM_700 | 261d? | 1999-01-01 A | 1999-12-31 A | 100% | 1999-01-01 | 1999-12-31 | 261d? | start no earlier than 1999-01-01 | SMG2 | 2088h | 2088h | GSM_700 | R99 |  | GSM_700 |  |  |  |
| 5952 | 1474.7 | Deleted - GERAN | 261d? | 1999-01-01 A | 1999-12-31 A | 100% | 1999-01-01 | 1999-12-31 | 261d? | start no earlier than 1999-01-01 | SMG2; S2 | 4176h | 4176h | GERAN | R99 | Maurice | GERAN | SP-06 |  |  |
| 5953 | 1475 | **GSM Features transposed to UMTS** | 261d? | 1999-01-01 A | 1999-12-31 A | 100% | 1999-01-01 | 1999-12-31 | 261d? |  | S1; S3; T2; N2; N4 | 31320h | 31320h |  | R99 | Alain |  |  |  |  |
| 5954 | 1475.1 | Cell Broadcast Service | 261d? | 1999-01-01 A | 1999-12-31 A | 100% | 1999-01-01 | 1999-12-31 | 261d? | start no earlier than 1999-01-01 | T2 | 2088h | 2088h | CBS | R99 |  | CBS |  |  |  |
| 5955 | 1475.2 | **GSM mobile number portability euro MNP / North American MNP** | 261d? | 1999-01-01 A | 1999-12-31 A | 100% | 1999-01-01 | 1999-12-31 | 261d? |  | S1; N2; N4 | 10440h | 10440h | MNP | R99 | Alain | MNP |  |  |  |
| 5956 | 1475.2.1 | Mobile Number Portability | 261d? | 1999-01-01 A | 1999-12-31 A | 100% | 1999-01-01 | 1999-12-31 | 261d? | start no earlier than 1999-01-01 | N2; N4 | 4176h | 4176h |  | R99 | Kimmo |  |  |  |  |
| 5957 | 1475.3 | Automatic establishment of roaming relations | 261d? | 1999-01-01 A | 1999-12-31 A | 100% | 1999-01-01 | 1999-12-31 | 261d? | start no earlier than 1999-01-01 | S1 | 2088h | 2088h |  | R99 | Alain |  |  | Telecom Italia | enrico.scarrone@telecomitalia.it |
| 5958 | 1475.4 | Advanced addressing | 261d? | 1999-01-01 A | 1999-12-31 A | 100% | 1999-01-01 | 1999-12-31 | 261d? | start no earlier than 1999-01-01 | S1 | 2088h | 2088h |  | R99 | Alain |  |  |  |  |
| 5959 | 1475.5 | UMTS numbering, addressing and identities | 261d? | 1999-01-01 A | 1999-12-31 A | 100% | 1999-01-01 | 1999-12-31 | 261d? | start no earlier than 1999-01-01 | S1 | 2088h | 2088h |  | R99 | Alain |  |  |  |  |
| 5960 | 1475.6 | Lawful Interception for GSM Features transposed to UMTS | 261d? | 1999-01-01 A | 1999-12-31 A | 100% | 1999-01-01 | 1999-12-31 | 261d? | start no earlier than 1999-01-01 | S3 | 2088h | 2088h | LI | R99 | Mirko | LI |  |  |  |

Notes:
- 5933: GPRS was introduced in Release 97. Release 99 brings a number of essential corrections e.g. on Downlink Power Control, Timing Advance procedure, Cell reselection delay time, PBCCH scheduling, PTCCH mapping, etc. / Impacted TSs and TRs: 05.02, 05.05, 05.08, 05.10, 05.50, 11.21, 23.064, 24.008, 24.060
- 5934: - / Impacted TSs and TRs: 02.60, 03.22, 03.64, 04.18, 04.60, 04.64, 04.65, 05.01, 05.02, 05.05, 05.08, 05.10, 08.08, 08.18, 11.10-1, 11.21, 22.041, 22.060, 23.003, 23.007, 23.060, 23.107, 23.122, 24.007, 24.008, 27.007, 27.060, 29.002, 29.016, 29.018, 29.060, 29.061
- 5935: Introduction of EGPRS (S1) + Introduction of Reserved Service Labels in the APN (N2) / Impacted TSs and TRs: 02.60, 23.003
- 5936: - / Impacted TSs and TRs: 23.003, 23.008, 29.060
- 5937: EDGE is independent of the frequency bands, so it can be deployed e.g. in 900 and 1900 MHz bands. The new physical layer based on 8-PSK modulation is introduced and EGPRS and ECSD facilitate the new modulation in single and multi slot constellation. / Impacted TSs and TRs: 10.59, 02.34, 02.60, 03.30, 05.10, 05.50, 11.26
- 5938: WID in SMG2 331/97, SMG 1147/97, SMG 1148/97 / Impacted TSs and TRs: 02.34, 03.10, 03.20, 03.64, 04.03, 04.04, 04.06, 04.08, 04.18, 04.21, 04.22, 04.60, 04.64, 05.01, 05.02, 05.03, 05.04, 05.05, 05.08, 05.10, 05.50, 07.01, 07.02, 07.03, 08.08, 08.20, 08.58, 08.60, 09.07, 09.18, 11.10-1, 11.11, 11.21, 11.26, 23.034, 24.008,
- 5939: WID in SMG2 331/97, SMG 1147/97, SMG 1148/97 / Impacted TSs and TRs: 05.05, 05.10, 05.50
- 5940: No additional features for R99. / Impacted TSs and TRs: 02.34, 04.18, 11.10-1
- 5941: ECSD supports both transparent and non-transparent services, up to 64 kbit/s and 57.6 kbit/s respectively. See Tdoc SMG2 670/99 ECSD Concept Evaluation for more info / Impacted TSs and TRs: 05.02, 08.58, 22.034
- 5942: - / Impacted TSs and TRs: 05.03
- 5943: - / Impacted TSs and TRs: 02.07, 03.64, 04.14, 04.18, 04.60, 05.05, 05.08, 24.008
- 5944: - / Impacted TSs and TRs: 05.03, 05.05, 05.08
- 5945: - / Impacted TSs and TRs: 04.18
- 5946: Support for EGPRS in ANSI-136 networks and EDGE Compact (for ANSI-136 networks only). COMPACT = Deployment of servicES in CP-150spectrum below 1 MHz / Impacted TSs and TRs: 03.22, 03.30, 03.64, 05.01, 05.02, 05.03, 05.05, 05.08, 05.10
- 5947: COMPACT = Deployment of servicES in CP-150spectrum below 1 MHz / Impacted TSs and TRs: 04.18, 05.02
- 5948: COMPACT = Deployment of servicES in CP-150spectrum below 1 MHz / Impacted TSs and TRs: 03.22, 04.18, 04.60, 05.08, 23.122, 24.008
- 5949: GSM in the 400 MHz bands allows to deploy GSM within frequency bands in the range 450 to 500 MHz, previously used for analogue cellular systems. See Tdoc SMG2 190/99 and 595/99 for further info. / Impacted TSs and TRs: 02.17, 03.22, 03.30, 04.04, 04.18, 04.60, 05.01, 05.02, 05.05, 05.08, 05.10, 05.50, 08.18, 08.58, 11.21, 24.008, 27.007
- 5950: - / Impacted TSs and TRs: 03.22, 03.30, 05.01, 05.05, 05.08
- 5951: - / Impacted TSs and TRs: 05.05
- 5952: No CR or new TS/TR approved under this WI / Impacted TSs and TRs: G2: 04.18 CR#A248 , 04.60 CR#B090
- 5953: -
- 5954: Moved to CT1 at TSG-T closure. Applicability of the Cell Broadcast Service (as defined for GSM network) to 3G networks / Impacted TSs and TRs: 23.041
- 5955: R98 MNP: mobile subscriber ability to change PLMN operator within the same country whilst retaining its original MS ISDN number (MSISDN). IMSI is changed, only MSISDN is kept. R99 adds requirements for North American Service Provider Number Portability. / Impacted TSs and TRs: 22.066
- 5956: - / Impacted TSs and TRs: 23.018, 23.066, 29.002
- 5957: framework for commercial and technical interworking between UMTS Home Environments and Serving Networks who have no direct prior commercial agreements with each other. / Impacted TSs and TRs: 22.101, 22.971
- 5958: - / Impacted TSs and TRs: 22.101, 22.75U, 22.975
- 5959: Also new requirements for Single and Multiple Numbering scheme was added (CR#20 and 21). Deleted the term International Mobile User Identifier (IMUI) and changed IMSI (International Mobile Station Identifier=>International Mobile Subscriber Identity. / Impacted TSs and TRs: 22.101
- 5960: Defines an interception system in UMTS that supports a number of regional interception regulations. Regional interception requirements shall be met in using specific (regional) mediation functions allowing only required information to be transported. / Impacted TSs and TRs: New 33.106, 33.107

| ID | WBS | Task | Duration | Start | Finish | Complete | Baseline start | Baseline finish | Baseline duration | Constraint | Resources | Work | Actual work | Release | MCC resp | Acronym | Acronym_3GU_Export | TSG stopped |
| --- | --- | --- | --- | --- | --- | --- | --- | --- | --- | --- | --- | --- | --- | --- | --- | --- | --- | --- |
| 5961 | 1476 | **Charging** | 261d? | 1999-01-01 A | 1999-12-31 A | 100% | 1999-01-01 | 1999-12-31 | 261d? |  | S1; S5 | 8352h | 8352h | R99 | Alain |  |  |  |
| 5962 | 1476.1 | R99 Charging | 261d? | 1999-01-01 A | 1999-12-31 A | 100% | 1999-01-01 | 1999-12-31 | 261d? | start no earlier than 1999-01-01 | S1 | 2088h | 2088h | R99 | Alain | Charging | Charging |  |
| 5963 | 1476.2 | R99 OAM Charging Management | 261d? | 1999-01-01 A | 1999-12-31 A | 100% | 1999-01-01 | 1999-12-31 | 261d? | start no earlier than 1999-01-01 | S5 | 2088h | 2088h | R99 | Mirko | OAMCH,CH | OAMCH, CH |  |
| 5964 | 1477 | **Operations, Administration, Maintenance and Provisioning (OAM&P)** | 261d? | 1999-01-01 A | 1999-12-31 A | 100% | 1999-01-01 | 1999-12-31 | 261d? |  | S5 | 12528h | 12528h | R99 | Mirko | OAM1999 | OAM1999 |  |
| 5965 | 1477.1 | OAM Principles and High-level Requirements | 261d? | 1999-01-01 A | 1999-12-31 A | 100% | 1999-01-01 | 1999-12-31 | 261d? | start no earlier than 1999-01-01 | S5 | 2088h | 2088h | R99 | Mirko | PR,Princs_&_Reqs_(PR) | PR, Princs_&_Reqs_(PR) |  |
| 5966 | 1477.2 | OAM Architecture | 261d? | 1999-01-01 A | 1999-12-31 A | 100% | 1999-01-01 | 1999-12-31 | 261d? | start no earlier than 1999-01-01 | S5 | 2088h | 2088h | R99 | Mirko | OAMAR,AR,Telecom_Management_Arch_(AR) | OAMAR, AR, Telecom_Management_Arch_(AR) |  |
| 5967 | 1477.3 | OAM Configuration Management | 261d? | 1999-01-01 A | 1999-12-31 A | 100% | 1999-01-01 | 1999-12-31 | 261d? | start no earlier than 1999-01-01 | S5 | 2088h | 2088h | R99 | Mirko | OAMCM,CM | OAMCM, CM |  |
| 5968 | 1477.4 | OAM Fault Management | 261d? | 1999-01-01 A | 1999-12-31 A | 100% | 1999-01-01 | 1999-12-31 | 261d? | start no earlier than 1999-01-01 | S5 | 2088h | 2088h | R99 | Mirko | OAMFM | OAMFM |  |
| 5969 | 1477.5 | OAM Performance Management | 261d? | 1999-01-01 A | 1999-12-31 A | 100% | 1999-01-01 | 1999-12-31 | 261d? | start no earlier than 1999-01-01 | S5 | 2088h | 2088h | R99 | Mirko | OAMPM,PM | OAMPM, PM |  |
| 5970 | 1478 | Vocabulary | 261d? | 1999-01-01 A | 1999-12-31 A | 100% | 1999-01-01 | 1999-12-31 | 261d? | start no earlier than 1999-01-01 | S1 | 2088h | 2088h | R99 | Alain | Vocabulary | Vocabulary |  |
| 5971 | 1479 | Emergency | 261d? | 1999-01-01 A | 1999-12-31 A | 100% | 1999-01-01 | 1999-12-31 | 261d? | start no earlier than 1999-01-01 | S1 | 2088h | 2088h | R99 | Alain | Emergency | Emergency |  |
| 5972 | 1480 | GSM General Bearer Services (GBS) and interworking scenarios support in UMTS | 261d? | 1999-01-01 A | 1999-12-31 A | 100% | 1999-01-01 | 1999-12-31 | 261d? | start no earlier than 1999-01-01 | S1 | 2088h | 2088h | R99 | Alain | GSM_to_UMTS_Evol | GSM_to_UMTS_Evol |  |
| 5973 | 1481 | GPRS_Mobile_IP_interworking | 261d? | 1999-01-01 A | 1999-12-31 A | 100% | 1999-01-01 | 1999-12-31 | 261d? | start no earlier than 1999-01-01 | N3 | 2088h | 2088h | R99 |  | GPRS_Mobile_IP_interworking | GPRS_Mobile_IP_interworking |  |
| 5974 | 1482 | GSM/UMTS interworking | 261d? | 1999-01-01 A | 1999-12-31 A | 100% | 1999-01-01 | 1999-12-31 | 261d? | start no earlier than 1999-01-01 | N1; N2; N4; R3; S1; SMG | 12528h | 12528h | R99 | Frederic | 2G3Ginterworking | 2G3Ginterworking |  |
| 5975 | 1483 | Handover | 261d? | 1999-01-01 A | 1999-12-31 A | 100% | 1999-01-01 | 1999-12-31 | 261d? | start no earlier than 1999-01-01 | S1; SMG2; N1; N2; N4 | 10440h | 10440h | R99 | Alain | Handover | Handover |  |
| 5976 | 1484 | 2G3Ghandover | 261d? | 1999-01-01 A | 1999-12-31 A | 100% | 1999-01-01 | 1999-12-31 | 261d? | start no earlier than 1999-01-01 | SMG2 | 2088h | 2088h | R99 |  | 2G3Ghandover | 2G3Ghandover |  |
| 5977 | 1485 | Service Provider Name Indication | 261d? | 1999-01-01 A | 1999-12-31 A | 100% | 1999-01-01 | 1999-12-31 | 261d? | start no earlier than 1999-01-01 | S1 | 2088h | 2088h | R99 | Alain | SPANME | SPANME |  |
| 5978 | 1486 | Data & Data_CleanUp | 261d? | 1999-01-01 A | 1999-12-31 A | 100% | 1999-01-01 | 1999-12-31 | 261d? | start no earlier than 1999-01-01 | SMG1 | 2088h | 2088h | R99 |  | Data,Data_CleanUp | Data, Data_CleanUp |  |
| 5979 | 1487 | Unstructured Supplementary Service Data (USSD) | 261d? | 1999-01-01 A | 1999-12-31 A | 100% | 1999-01-01 | 1999-12-31 | 261d? | start no earlier than 1999-01-01 | SMG1; N4 | 4176h | 4176h | R99 | Kimmo | USSD | USSD |  |
| 5980 | 1488 | Man-Machine Interface (MMI) of the User Equipment (UE) | 261d? | 1999-01-01 A | 1999-12-31 A | 100% | 1999-01-01 | 1999-12-31 | 261d? | start no earlier than 1999-01-01 | S1 | 2088h | 2088h | R99 | Alain | MMI | MMI |  |
| 5981 | 1489 | Network Identity and Timezone (NITZ) | 261d? | 1999-01-01 A | 1999-12-31 A | 100% | 1999-01-01 | 1999-12-31 | 261d? | start no earlier than 1999-01-01 | SMG1; SMG3 | 4176h | 4176h | R99 | Alain | NITZ | NITZ |  |
| 5982 | 1490 | Deleted - Operator Determined Barring for Packet Oriented Services | 261d? | 1999-01-01 A | 1999-12-31 A | 100% | 1999-01-01 | 1999-12-31 | 261d? | start no earlier than 1999-01-01 | S1 | 2088h | 2088h | R99 | Alain | ODB_Enh. | ODB_Enh. | SP-69 |
| 5983 | 1491 | Packet Flow Management | 261d? | 1999-01-01 A | 1999-12-31 A | 100% | 1999-01-01 | 1999-12-31 | 261d? | start no earlier than 1999-01-01 | SMG2 | 2088h | 2088h | R99 |  | Packet_Flow_Management | Packet_Flow_Management |  |
| 5984 | 1492 | GPRS_Point-To-Multipoint Group call | 261d? | 1999-01-01 A | 1999-12-31 A | 100% | 1999-01-01 | 1999-12-31 | 261d? | start no earlier than 1999-01-01 | SMG1 | 2088h | 2088h | R99 |  | GPRS_PTMG | GPRS_PTMG |  |

Notes:
- 5961: -
- 5962: - / Impacted TSs and TRs: 22.115, 23.121
- 5963: - / Impacted TSs and TRs: 32.005, 32.015
- 5964: -
- 5965: - / Impacted TSs and TRs: 32.101
- 5966: - / Impacted TSs and TRs: 32.101, 32.102
- 5967: - / Impacted TSs and TRs: 32.106, 32.106-1, 32.106-2, 32.106-3, 32.106-4, 32.106-5, 32.106-6, 32.106-7, 32.106-8
- 5968: - / Impacted TSs and TRs: 32.111, 32.111-1, 32.111-2, 32.111-3, 32.111-4
- 5969: - / Impacted TSs and TRs: 12.04, 32.104
- 5970: - / Impacted TSs and TRs: 21.905
- 5971: - / Impacted TSs and TRs: 22.101
- 5972: UMTS shall support GSM General Bearer Services (GBS) and interworking scenarios as specified in 02.02 / Impacted TSs and TRs: 22.105
- 5973: - / Impacted TSs and TRs: 29.061
- 5974: - / Impacted TSs and TRs: 03.22, 04.18, 04.60, 05.02, 05.08, 05.10, 08.08, 08.18, 08.58, 09.08, 22.011, 23.003, 23.009, 23.014, 23.034, 23.122, 24.007, 24.008, 24.011, 24.080, 29.108
- 5975: - / Impacted TSs and TRs: 04.18, 08.08, 08.58, 22.129, 23.009, 29.002, 29.010
- 5976: - / Impacted TSs and TRs: 04.18, 04.60, 05.02, 05.08, 05.10, 08.08, 29.010
- 5977: Service Provider Name Indication included in R98 (02.07) was not carried into R99 (22.101), but is in the SIM/USIM specification for R99 / Impacted TSs and TRs: 22.101
- 5978: - / Impacted TSs and TRs: 02.01, 02.02, 02.04, 02.34
- 5979: No additional features for R99. / Impacted TSs and TRs: 02.04, 02.90, 23.090, 29.002
- 5980: Data services streamlining + Support for Anonymous Call Rejection / Impacted TSs and TRs: 22.030
- 5981: - / Impacted TSs and TRs: 02.42, 04.08
- 5982: Remove ODB for Packet Oriented Services from R99 / Impacted TSs and TRs: 22.041
- 5983: - / Impacted TSs and TRs: 08.18
- 5984: - / Impacted TSs and TRs: 02.60

| ID | WBS | Task | Duration | Start | Finish | Complete | Baseline start | Baseline finish | Baseline duration | Constraint | Resources | Work | Actual work | Release | MCC resp | Acronym | Acronym_3GU_Export |
| --- | --- | --- | --- | --- | --- | --- | --- | --- | --- | --- | --- | --- | --- | --- | --- | --- | --- |
| 5985 | 1493 | **Call Forwarding** | 261d? | 1999-01-01 A | 1999-12-31 A | 100% | 1999-01-01 | 1999-12-31 | 261d? |  | SMG1; N2; N4 | 16704h | 16704h | R99 | Kimmo |  |  |
| 5986 | 1493.1 | Call Forwarding enhancements | 261d? | 1999-01-01 A | 1999-12-31 A | 100% | 1999-01-01 | 1999-12-31 | 261d? | start no earlier than 1999-01-01 | N4; N2 | 4176h | 4176h | R99 | Kimmo | CF_enhancements | CF_enhancements |
| 5987 | 1493.2 | Call_Forwarding | 261d? | 1999-01-01 A | 1999-12-31 A | 100% | 1999-01-01 | 1999-12-31 | 261d? | start no earlier than 1999-01-01 | SMG1; N2 | 4176h | 4176h | R99 | Kimmo | Call_Forwarding | Call_Forwarding |
| 5988 | 1493.3 | Call_Forwarding_Enhancements | 261d? | 1999-01-01 A | 1999-12-31 A | 100% | 1999-01-01 | 1999-12-31 | 261d? | start no earlier than 1999-01-01 | N4 | 2088h | 2088h | R99 | Kimmo | Call_Forwarding_Enhancements | Call_Forwarding_Enhancements |
| 5989 | 1494 | **Quality of Service** | 261d? | 1999-01-01 A | 1999-12-31 A | 100% | 1999-01-01 | 1999-12-31 | 261d? |  | S2; T2; N1; N2; N4 | 31320h | 31320h | R99 | Maurice |  |  |
| 5990 | 1494.1 | End-to-end UMTS Quality of Service management | 261d? | 1999-01-01 A | 1999-12-31 A | 100% | 1999-01-01 | 1999-12-31 | 261d? | start no earlier than 1999-01-01 | S2; T2; N1; N2; N4 | 10440h | 10440h | R99 | Maurice | QoS | QoS |
| 5991 | 1494.2 | End-to-end QoS for PS Domain including IMS | 261d? | 1999-01-01 A | 1999-12-31 A | 100% | 1999-01-01 | 1999-12-31 | 261d? | start no earlier than 1999-01-01 | S2 | 2088h | 2088h | R99 | Maurice | E2EQoS99 | E2EQoS |
| 5992 | 1494.3 | GPRS-enhanced_QoS | 261d? | 1999-01-01 A | 1999-12-31 A | 100% | 1999-01-01 | 1999-12-31 | 261d? | start no earlier than 1999-01-01 | T2 | 2088h | 2088h | R99 |  | GPRS-enhanced_QoS | GPRS-enhanced_QoS |
| 5993 | 1494.4 | QoS_enhancements | 261d? | 1999-01-01 A | 1999-12-31 A | 100% | 1999-01-01 | 1999-12-31 | 261d? | start no earlier than 1999-01-01 | N2; N1; N4 | 6264h | 6264h | R99 | Kimmo | QoS_enhancements | QoS_enhancements |
| 5994 | 1495 | Support of Localised Service Area | 261d? | 1999-01-01 A | 1999-12-31 A | 100% | 1999-01-01 | 1999-12-31 | 261d? | start no earlier than 1999-01-01 | SMG2; SMG3; SMG7; N2 | 8352h | 8352h | R99 | Maurice | SoLSA | SoLSA |
| 5995 | 1496 | Transcoder_location | 261d? | 1999-01-01 A | 1999-12-31 A | 100% | 1999-01-01 | 1999-12-31 | 261d? | start no earlier than 1999-01-01 | S2 | 2088h | 2088h | R99 | Maurice | Transcoder_location | Transcoder_location |
| 5996 | 1497 | Antenna_test_methods | 261d? | 1999-01-01 A | 1999-12-31 A | 100% | 1999-01-01 | 1999-12-31 | 261d? | start no earlier than 1999-01-01 | SMG2 | 2088h | 2088h | R99 |  | Antenna_test_methods | Antenna_test_methods |
| 5997 | 1498 | WBAMR / high quality speech in UMTS Phase 1 but not in R99 | 261d? | 1999-01-01 A | 1999-12-31 A | 100% | 1999-01-01 | 1999-12-31 | 261d? | start no earlier than 1999-01-01 | S1 | 2088h | 2088h | R99 | Alain | WBAMR | WBAMR |
| 5998 | 1499 | **Codec** | 261d? | 1999-01-01 A | 1999-12-31 A | 100% | 1999-01-01 | 1999-12-31 | 261d? |  | S4 | 27144h | 27144h | R99 | Paolo |  |  |
| 5999 | 1499.1 | **Codecs for Multimedia Telephony Service** | 261d? | 1999-01-01 A | 1999-12-31 A | 100% | 1999-01-01 | 1999-12-31 | 261d? |  | S4 | 14616h | 14616h | R99 | Paolo | Codec_for_Multimedia_Telephony | Codec_for_Multimedia_Telephony |
| 6000 | 1499.1.1 | Codecs for Multimedia Telephony Service | 261d? | 1999-01-01 A | 1999-12-31 A | 100% | 1999-01-01 | 1999-12-31 | 261d? | start no earlier than 1999-01-01 | S4 | 2088h | 2088h | R99 | Paolo | Multimedia_Codec | Multimedia_Codec |
| 6001 | 1499.1.2 | Codecs for Multimedia Telephony Service | 261d? | 1999-01-01 A | 1999-12-31 A | 100% | 1999-01-01 | 1999-12-31 | 261d? | start no earlier than 1999-01-01 | S4 | 2088h | 2088h | R99 | Paolo | CSM | CSM |
| 6002 | 1499.1.3 | Codecs for Multimedia Telephony Service | 261d? | 1999-01-01 A | 1999-12-31 A | 100% | 1999-01-01 | 1999-12-31 | 261d? | start no earlier than 1999-01-01 | S4 | 2088h | 2088h | R99 | Paolo | WI2MMC | WI2MMC |
| 6003 | 1499.1.4 | Codecs for Multimedia Telephony Service | 261d? | 1999-01-01 A | 1999-12-31 A | 100% | 1999-01-01 | 1999-12-31 | 261d? | start no earlier than 1999-01-01 | S4 | 2088h | 2088h | R99 | Paolo | Codec(s)_for_CS_MM_Tel._Serv | Codec(s)_for_CS_MM_Tel._Serv |
| 6004 | 1499.1.5 | Codecs for Multimedia Telephony Service | 261d? | 1999-01-01 A | 1999-12-31 A | 100% | 1999-01-01 | 1999-12-31 | 261d? | start no earlier than 1999-01-01 | S4 | 2088h | 2088h | R99 | Paolo | Codec(s)_for_MM_Tel_Service | Codec(s)_for_MM_Tel_Service |
| 6005 | 1499.1.6 | Codecs for Multimedia Telephony Service | 261d? | 1999-01-01 A | 1999-12-31 A | 100% | 1999-01-01 | 1999-12-31 | 261d? | start no earlier than 1999-01-01 | S4 | 2088h | 2088h | R99 | Paolo |  |  |
| 6006 | 1499.2 | QoS for Speech and Multimedia Codec | 261d? | 1999-01-01 A | 1999-12-31 A | 100% | 1999-01-01 | 1999-12-31 | 261d? | start no earlier than 1999-01-01 | S4 | 2088h | 2088h | R99 | Paolo | QoS_for_Speech_&_MM_Codecs_/_AMR | QoS_for_Speech_&_MM_Codecs_/_AMR |
| 6007 | 1499.3 | Tandem Free Operation - Adaptive Multi-Rate codec types | 261d? | 1999-01-01 A | 1999-12-31 A | 100% | 1999-01-01 | 1999-12-31 | 261d? | start no earlier than 1999-01-01 | S4 | 2088h | 2088h | R99 | Paolo | TFOAMR | TFOAMR |
| 6008 | 1499.4 | Noise Suppression for AMR | 261d? | 1999-01-01 A | 1999-12-31 A | 100% | 1999-01-01 | 1999-12-31 | 261d? | start no earlier than 1999-01-01 | S4 | 2088h | 2088h | R99 | Paolo | AMRNS | AMRNS |
| 6009 | 1499.5 | Out-of-Band Transcoder | 261d? | 1999-01-01 A | 1999-12-31 A | 100% | 1999-01-01 | 1999-12-31 | 261d? | start no earlier than 1999-01-01 | N1 | 2088h | 2088h | R99 | Frederic | OoBT | OoBT |
| 6010 | 1499.6 | Out-of-Band Transcoder Control | 261d? | 1999-01-01 A | 1999-12-31 A | 100% | 1999-01-01 | 1999-12-31 | 261d? | start no earlier than 1999-01-01 | N1 | 2088h | 2088h | R99 | Frederic | OoBTC | OoBTC |
| 6011 | 1500 | Advanced Speech Call Items enhancements | 261d? | 1999-01-01 A | 1999-12-31 A | 100% | 1999-01-01 | 1999-12-31 | 261d? | start no earlier than 1999-01-01 | SMG1; SMG2; SMG3; SMG7; SMG9; N1; N4; S1; T2 | 18792h | 18792h | R99 | Alain | ASCI | ASCI |
| 6012 | 1501 | Call Control improvements | 261d? | 1999-01-01 A | 1999-12-31 A | 100% | 1999-01-01 | 1999-12-31 | 261d? | start no earlier than 1999-01-01 | N1 | 2088h | 2088h | R99 | Frederic | CC_Related_items | CC_Related_items |
| 6013 | 1502 | Multimedia | 261d? | 1999-01-01 A | 1999-12-31 A | 100% | 1999-01-01 | 1999-12-31 | 261d? | start no earlier than 1999-01-01 | N1; N3 | 4176h | 4176h | R99 | Frederic | Multimedia | Multimedia |
| 6014 | 1503 | Sub-System Number allocation for RANAP, RNSAP | 261d? | 1999-01-01 A | 1999-12-31 A | 100% | 1999-01-01 | 1999-12-31 | 261d? | start no earlier than 1999-01-01 | N2 | 2088h | 2088h | R99 | Frederic | SSN_allocation | SSN_allocation |
| 6015 | 1504 | Intranet / ISP access with DHCP end-to-end | 261d? | 1999-01-01 A | 1999-12-31 A | 100% | 1999-01-01 | 1999-12-31 | 261d? | start no earlier than 1999-01-01 | N3 | 2088h | 2088h | R99 | Gwiho | ISPaccess | ISPaccess |
| 6016 | 1505 | Point_to_Multipoint_Services | 261d? | 1999-01-01 A | 1999-12-31 A | 100% | 1999-01-01 | 1999-12-31 | 261d? | start no earlier than 1999-01-01 | N3 | 2088h | 2088h | R99 | Gwiho | Point_to_Multipoint_Services | Point_to_Multipoint_Services |
| 6017 | 1506 | Facsimile | 261d? | 1999-01-01 A | 1999-12-31 A | 100% | 1999-01-01 | 1999-12-31 | 261d? | start no earlier than 1999-01-01 | S1 | 2088h | 2088h | R99 | Alain | FAX | FAX |
| 6018 | 1507 | Realtime_NT_FAX_in_UMTS | 261d? | 1999-01-01 A | 1999-12-31 A | 100% | 1999-01-01 | 1999-12-31 | 261d? | start no earlier than 1999-01-01 | N3 | 2088h | 2088h | R99 | Gwiho | Realtime_NT_FAX_in_UMTS | Realtime_NT_FAX_in_UMTS |
| 6019 | 1508 | Gateway Location Register (GLR) - Mobile Application Part (MAP) specification | 261d? | 1999-01-01 A | 1999-12-31 A | 100% | 1999-01-01 | 1999-12-31 | 261d? | start no earlier than 1999-01-01 | N4 | 2088h | 2088h | R99 | Kimmo | GLR | GLR |
| 6020 | 1509 | Multiple Subscriber Profile phase 2 | 261d? | 1999-01-01 A | 1999-12-31 A | 100% | 1999-01-01 | 1999-12-31 | 261d? | start no earlier than 1999-01-01 | S1; N4 | 4176h | 4176h | R99 | Alain | MSP2 | MSP2 |
| 6021 | 1510 | Prepaging | 261d? | 1999-01-01 A | 1999-12-31 A | 100% | 1999-01-01 | 1999-12-31 | 261d? | start no earlier than 1999-01-01 | N2; N4 | 4176h | 4176h | R99 | Kimmo | Prepaging | Prepaging |
| 6022 | 1511 | Re-definition of channel quality measure used for AMR link adaptation for Downlink Advanced Receiver Performance (DARP) MS | 261d? | 1999-01-01 A | 1999-12-31 A | 100% | 1999-01-01 | 1999-12-31 | 261d? | start no earlier than 1999-01-01 | SMG | 2088h | 2088h | R99 |  |  |  |
| 6023 | 1512 | Harmonized Standard | 261d? | 1999-01-01 A | 1999-12-31 A | 100% | 1999-01-01 | 1999-12-31 | 261d? | start no earlier than 1999-01-01 | SMG2 | 2088h | 2088h | R99 |  | HS | HS |
| 6024 | 1513 | Streamlining of specifications | 261d? | 1999-01-01 A | 1999-12-31 A | 100% | 1999-01-01 | 1999-12-31 | 261d? | start no earlier than 1999-01-01 | N3 | 2088h | 2088h | R99 | Gwiho | Streamlining | Streamlining |
| 6025 | 1514 | R99_Service_Clean_up | 261d? | 1999-01-01 A | 1999-12-31 A | 100% | 1999-01-01 | 1999-12-31 | 261d? | start no earlier than 1999-01-01 | N3 | 2088h | 2088h | R99 | Gwiho | R99_Service_Clean_up | R99_Service_Clean_up |

Notes:
- 5985: -
- 5986: No additional features for R99. / Impacted TSs and TRs: 23.078, 23.079, 23.082, 29.002, 29.078
- 5987: - / Impacted TSs and TRs: 02.82, 29.002
- 5988: - / Impacted TSs and TRs: 23.082
- 5989: WID SMG 98-0781 End To End UMTS QoS Management
- 5990: WID SMG 98-0781 End To End UMTS QoS Management / Impacted TSs and TRs: 23.107, 23.907, 24.008
- 5991: Acronym changed from E2EQos / Impacted TSs and TRs: 23.060, 23.170
- 5992: AT-commands for Enhanced QoS Support management / Impacted TSs and TRs: 27.007
- 5993: - / Impacted TSs and TRs: 23.008, 23.016, 24.008, 29.002, 29.060
- 5994: Mechanism which can be used as a platform for providing special tariffs and/or special set of service features for certain subscribers within a regionally restricted area or areas. No additional features for R99. / Impacted TSs and TRs: 04.08, 04.18, 08.08, 11.10-1, 29.002
- 5995: UE location identification: background information and associated primitives 2. Transcoder location at the core network and source depending coding belonging to the non-access stratum. / Impacted TSs and TRs: 23.110
- 5996: - / Impacted TSs and TRs: 03.30
- 5997: Add requirement for high quality speech in UMTS Phase 1 but not in R99 / Impacted TSs and TRs: 22.105
- 5998: -
- 5999: -
- 6000: - / Impacted TSs and TRs: 26.911, 26.104, 26.111
- 6001: - / Impacted TSs and TRs: 26.911, 26.104, 26.111
- 6002: - / Impacted TSs and TRs: 26.911, 26.104, 26.111
- 6003: - / Impacted TSs and TRs: 26.911, 26.104, 26.111
- 6004: - / Impacted TSs and TRs: 26.911, 26.104, 26.111
- 6005: - / Impacted TSs and TRs: 26.911, 26.104, 26.111
- 6006: - / Impacted TSs and TRs: 26.102, 26.912
- 6007: UMTS_AMR2 is default Codec Type in R99 dual_mode terminals / Impacted TSs and TRs: 26.103
- 6008: Combination of the AMR speech codec and the Noise Suppression function. TS 06.77 and TR 06.78 only apply to GSM. They apply to UMTS from Rel-4 onwards, when they were converted to TS 26.077 and TR 26.078. / Impacted TSs and TRs: 06.77, 06.78
- 6009: Transcoder handling in the CN at inter-system handover and relocation + Introduction of UMTS AMR / Impacted TSs and TRs: 23.009, 24.008
- 6010: 24.008 CR#0572 in NP-020220 was approved under this WI / Impacted TSs and TRs: 24.008 CR#0572 in NP-020220
- 6011: - / Impacted TSs and TRs: 02.30, 02.68, 03.68, 03.69, 04.18, 08.08, 11.10-1, 11.11, 23.067, 23.094, 24.008, 24.067, 27.007, 29.002
- 6012: Minor improvements to 24.007 and 24.008 to increase the number of simultaneous calls/sessions from the present 7: the TI value is increased (NP-99441). / Impacted TSs and TRs: 24.007, 24.008
- 6013: - / Impacted TSs and TRs: 24.008, 27.001, 29.007
- 6014: Sub-System Number allocation for Radio Access Network Application Part, Radio Network Subsystem Application Part / Impacted TSs and TRs: 23.003
- 6015: Access to an Intranet/ISP with DHCP end to end / Impacted TSs and TRs: 29.061
- 6016: Support for the IP-Multicast protocol / Impacted TSs and TRs: 29.061
- 6017: - / Impacted TSs and TRs: 22.003, 22.100
- 6018: Asynchronous Interface for real-time NT Fax + Introduction of Asynchronous interface for Real-time non-transparent FAX / Impacted TSs and TRs: 27.001, 27.003
- 6019: - / Impacted TSs and TRs: 29.120
- 6020: - / Impacted TSs and TRs: 22.097, 23.072, 23.083, 23.084, 23.091, 23.093, 23.097
- 6021: - / Impacted TSs and TRs: 23.018, 23.082, 29.002
- 6022: Re-definition of channel quality measure used for AMR link adaptation for DARP MS / Impacted TSs and TRs: 05.09
- 6023: - / Impacted TSs and TRs: 13.21
- 6024: - / Impacted TSs and TRs: 27.060, 29.061
- 6025: - / Impacted TSs and TRs: 03.10, 27.001, 27.002, 27.003, 27.060, 29.007, 29.061

| ID | WBS | Task | Type | Duration | Start | Finish | Complete | Baseline start | Baseline finish | Baseline duration | Constraint | Resources | Work | Actual work | Acronym | Release | MCC resp | Acronym_3GU_Export | Impacted TSs and TRs | TSG stopped | WI rapporteur name | WI rapporteur e-mail |
| --- | --- | --- | --- | --- | --- | --- | --- | --- | --- | --- | --- | --- | --- | --- | --- | --- | --- | --- | --- | --- | --- | --- |
| 6026 | 1515 | **(Small) Technical Enhancements and Improvements for R99** |  | 261d? | 1999-01-01 A | 1999-12-31 A | 100% | 1999-01-01 | 1999-12-31 | 261d? |  | N3 | 6264h | 6264h | TEI | R99 | Gwiho | TEI |  |  |  |  |
| 6027 | 1515.1 | TEI_[CS_Data] |  | 261d? | 1999-01-01 A | 1999-12-31 A | 100% | 1999-01-01 | 1999-12-31 | 261d? | start no earlier than 1999-01-01 | N3 | 2088h | 2088h | TEI_[CS_Data] | R99 | Gwiho | TEI_[CS_Data] |  |  |  |  |
| 6028 | 1515.2 | TEI_[GPRS] |  | 261d? | 1999-01-01 A | 1999-12-31 A | 100% | 1999-01-01 | 1999-12-31 | 261d? | start no earlier than 1999-01-01 | N3 | 2088h | 2088h | TEI_[GPRS] | R99 | Gwiho | TEI_[GPRS] |  |  |  |  |
| 6029 | 1516 | **R99 UE Conformance Testing** |  | 261d? | 1999-01-01 A | 1999-12-31 A | 100% | 1999-01-01 | 1999-12-31 | 261d? |  | R5; T1 | 6264h | 6264h | TEI_Test | R99 | Ingbert | TEI_Test | 34.108, 34.121, 34.122, 34.123-1, 34.123-2, 34.123-3 |  |  |  |
| 6030 | 1516.1 | Deleted - RTEI |  | 261d? | 1999-01-01 A | 1999-12-31 A | 100% | 1999-01-01 | 1999-12-31 | 261d? | start no earlier than 1999-01-01 | T1 | 2088h | 2088h | RTEI | R99 | Ingbert | RTEI | 34.123-1 CR#0650, 0651, 34.123-3 CR#0148, 0149, 0150 | TP-06 |  |  |
| 6031 | 1516.2 | Common test environments for User Equipment (UE); Conformance testing | milestone | 0d? | 1999-01-01 A | 1999-01-01 A | 100% | 1999-01-01 | 1999-01-01 | 0d? | start no earlier than 1999-01-01 | R5; T1 |  |  |  | R99 | Ingbert |  | 34.108 |  |  |  |
| 6032 | 1516.3 | Terminal conformance specification, Radio transmission and reception (FDD) | milestone | 0d? | 1999-01-01 A | 1999-01-01 A | 100% | 1999-01-01 | 1999-01-01 | 0d? | start no earlier than 1999-01-01 | R5; T1 |  |  |  | R99 | Ingbert |  | 34.121 |  |  |  |
| 6033 | 1516.4 | Terminal conformance specification, Radio transmission and reception (TDD) | milestone | 0d? | 1999-01-01 A | 1999-01-01 A | 100% | 1999-01-01 | 1999-01-01 | 0d? | start no earlier than 1999-01-01 | R5; T1 |  |  |  | R99 | Ingbert |  | 34.122 |  |  |  |
| 6034 | 1516.5 | UE conformance specification; Part 1: Protocol conformance specification | milestone | 0d? | 1999-01-01 A | 1999-01-01 A | 100% | 1999-01-01 | 1999-01-01 | 0d? | start no earlier than 1999-01-01 | R5; T1 |  |  |  | R99 | Ingbert |  | 34.123-1 |  |  |  |
| 6035 | 1516.6 | UE conformance specification; Part 2: Implementation Conformance Statement (ICS) specification | milestone | 0d? | 1999-01-01 A | 1999-01-01 A | 100% | 1999-01-01 | 1999-01-01 | 0d? | start no earlier than 1999-01-01 | R5; T1 |  |  |  | R99 | Ingbert |  | 34.123-2 |  |  |  |
| 6036 | 1516.7 | UE conformance specification; Part 3: Abstract test suites (ATSs) | milestone | 0d? | 1999-01-01 A | 1999-01-01 A | 100% | 1999-01-01 | 1999-01-01 | 0d? | start no earlier than 1999-01-01 | R5; T1 |  |  |  | R99 | Ingbert |  | 34.123-3 |  |  |  |
| 6037 | 1517 | Deleted - Dual Tone Multi-Frequency signalling : Support in the whole 3GPP system |  | 261d? | 1999-01-01 A | 1999-12-31 A | 100% | 1999-01-01 | 1999-12-31 | 261d? | start no earlier than 1999-01-01 | N1 | 2088h | 2088h | DTMF | R99 | Frederic | DTMF | 23.014 CR#0004 | NP-06 |  |  |
| 6038 | 1518 | Deleted - Intersystem_Change |  | 261d? | 1999-01-01 A | 1999-12-31 A | 100% | 1999-01-01 | 1999-12-31 | 261d? | start no earlier than 1999-01-01 | SMG | 2088h | 2088h | Intersystem_Change | R99 |  | Intersystem_Change | 04.18 CR#A243 | SMG |  |  |
| 6039 | 1519 | Deleted - Long_Forwardedto_Numbers |  | 261d? | 1999-01-01 A | 1999-12-31 A | 100% | 1999-01-01 | 1999-12-31 | 261d? | start no earlier than 1999-01-01 | N2 | 2088h | 2088h | Long_Forwardedto_Numbers | R99 | Kimmo | Long_Forwardedto_Numbers | 29.002 | NP-06 |  |  |
| 6040 | 1520 | Deleted - RANimp-FSEarlyUE |  | 261d? | 1999-01-01 A | 1999-12-31 A | 100% | 1999-01-01 | 1999-12-31 | 261d? | start no earlier than 1999-01-01 | R3 | 2088h | 2088h | RANimp-FSEarlyUE | R99 | Juha | RANimp-FSEarlyUE | 25.413 CR#0520, 0538, 0565, 0563, 0541, 0540, 0539, 0547 | RP-06 |  |  |
| 6041 | 1521 | Release 1999 Studies |  | 261d? | 1999-01-01 A | 1999-12-31 A | 100% | 1999-01-01 | 1999-12-31 | 261d? |  | S1; T2 | 4176h | 4176h |  | R99 | Alain |  |  |  |  |  |
| 6042 | 1522 | Advanced Addressing/Numbering |  | 261d? | 1999-01-01 A | 1999-12-31 A | 100% | 1999-01-01 | 1999-12-31 | 261d? | start no earlier than 1999-01-01 | S1 | 2088h | 2088h | Numbering | R99 | Alain | Numbering | 22.975 |  | Vodafone | mona.mustapha@vodafone.com |
| 6043 | 1523 | Combined GSM and Mobile IP mobility handling in UMTS IP CN |  | 261d? | 1999-01-01 A | 1999-12-31 A | 100% | 1999-01-01 | 1999-12-31 | 261d? | start no earlier than 1999-01-01 | S2 | 2088h | 2088h |  | R99 | Maurice |  | 23.923 |  |  |  |
| 6044 | 1524 | UE Capabilities Requirements |  | 261d? | 1999-01-01 A | 1999-12-31 A | 100% | 1999-01-01 | 1999-12-31 | 261d? | start no earlier than 1999-01-01 | T2 | 2088h | 2088h | UCR | R99 |  | UCR | 21.904 |  |  |  |
| 6045 | 1525 | Electrical safety requirements and regulations |  | 261d? | 1999-01-01 A | 1999-12-31 A | 100% | 1999-01-01 | 1999-12-31 | 261d? | start no earlier than 1999-01-01 | T2 | 2088h | 2088h |  | R99 |  |  | 34.907 |  |  |  |
| 6046 | 1526 | Specific Absorbtion Rate (SAR) requirements and regulations in different regions |  | 261d? | 1999-01-01 A | 1999-12-31 A | 100% | 1999-01-01 | 1999-12-31 | 261d? | start no earlier than 1999-01-01 | T2 | 2088h | 2088h |  | R99 |  |  | 34.925 |  |  |  |
| 6047 | 1527 | Multi-mode UE issues |  | 261d? | 1999-01-01 A | 1999-12-31 A | 100% | 1999-01-01 | 1999-12-31 | 261d? | start no earlier than 1999-01-01 | T2 | 2088h | 2088h |  | R99 |  |  | 21.810, 21.910 |  |  |  |
| 6048 | 1528 | Provision of fax service in GSM and UMTS |  | 261d? | 1999-01-01 A | 1999-12-31 A | 100% | 1999-01-01 | 1999-12-31 | 261d? | start no earlier than 1999-01-01 | T2 | 2088h | 2088h |  | R99 |  |  | 22.945 |  | Ericsson | peter.bleckert@ericsson.com |
| 6049 | 1529 | Separating Radio Resources and Mobility Management specific parts of the MS Classmark |  | 261d | 1999-01-01 A | 1999-12-31 A | 100% | 1999-01-01 | 1999-12-31 | 261d |  | T2 | 2088h | 2088h |  | R99 |  |  | 23.814 |  |  |  |

Notes:
- 6026: -
- 6027: -
- 6028: -
- 6029: Specifies Conformance Tests for a 3G UE to be recognised as 3GPP-standard compliant. A 3GPP-external body, GCF (Global Certification Forum), delivers certificates to prove that a UE has correctly passed tests and is then conform to the 3GPP standard.
- 6030: No CR or new TS/TR approved under this WI
- 6031: -
- 6032: measurement procedures for the conformance test of the UE that contain transmitting characteristics, receiving characteristics and performance requirements in addition to requirements for support of RRM (Radio Resource Management) in FDD mode.
- 6033: measurement procedures for the conformance test of the UE that contain transmitting characteristics, receiving characteristics and performance requirements in addition to requirements for support of RRM (Radio Resource Management) in TDD mode.
- 6034: TS 34.123, composed of three parts, actually specifies the protocol conformance testing for the 3G UE. Part 1 describes the overall test structure.
- 6035: Part 2 contains the applicability of each test case defined as the Implementation Conformance Statement (ICS) proforma, in compliance with the relevant requirements, and in accordance with the relevant guidance given in ISO/IEC 9646-7 and ETS 300 406.
- 6036: Part 3 specifies the protocol conformance testing in TTCN for the 3G UE at the Uu interface. It defines the TTCN test specification and design considerations in Abstract Test Suites based on the test cases specified in prose in part 1.
- 6037: No CR or new TS/TR approved under this WI
- 6038: No CR or new TS/TR approved under this WI
- 6039: -
- 6040: No CR or new TS/TR approved under this WI
- 6041: -
- 6042: Study on requirements for numbering and addressing for UMTS
- 6043: -
- 6044: Moved to CT1 at TSG-T closure
- 6045: Moved to RAN4 at TSG-T closure. TR summarizes differences between international and national standards relevant to IEC60950 and refers to regulations for conformity assessment due to different regulatory environments in different countries / regions.
- 6046: Moved to RAN4 at TSG-T closure.
- 6047: Moved to CT1 at TSG-T closure. Consequences on roaming capabilities and service availability (e.g. handover) of multi-mode UEs while roaming in various regions with various network configurations. Case studies for each of the possible scenarios in specs
- 6048: CP#27: Moved to C1 on closure of T2; see TP-050062. CP#28: C1->C3
- 6049: CP#27: change of WG as a result of closure of CN and T.
